# Run IIb Installation Schedule

Schedule from MS Project, 2004-01-05 to 2006-01-20, status date 2004-08-27, costs in $, A marks actual dates.
Fermilab
Working to standardize this schedule for first run through COBRA.

## Calendars

- Standard: Mon-Fri 08:00-12:00, 13:00-17:00; Sat-Sun off. Exceptions (off unless hours are given): 2004-01-19, 2004-05-31, 2004-07-02, 2004-09-06, 2004-11-25 to 2004-11-26, 2004-12-24, 2004-12-27 to 2004-12-31, 2005-01-03, 2005-01-17, 2005-05-30, 2005-07-04, 2005-09-05, 2005-11-24 to 2005-11-25, 2005-12-23, 2005-12-26 to 2005-12-30, 2006-01-02, 2006-01-16.

## Resources

| Resource | Group | Rate | Notes |
| --- | --- | --- | --- |
| MechEngF | F | 46.35 | Mechanical Engineer-Fermilab |
| MechEngU | U |  | Mechanical Engineer-Non-Fermilab (University) |
| ElecEngF | F | 46.9 | Electrical Engineer-Fermilab |
| ElecEngU | U |  | Electrical Engineer-Non-Fermilab (University) |
| MechTechSF | F | 28.73 | Mechanical Tech-SiDet -Fermilab |
| MechTechU | U |  | Mechanical Tech-Non-Fermilab (University) |
| ElecTechSF | F | 30 | Electrical Tech-Fermilab |
| ElecTechU | U |  | Electrical Tech-Non-Fermilab (University) |
| PhysicistF | F |  | Physicist-Fermilab, avg SWF rate is $1998 per week, but set to zero here. |
| PhysicistU | U |  | Physicist-Non-Fermilab (University);rate based on FNAL avg SWF rate of $1998 per week but set to zero here. |
| CompProfF | F | 38 | Computing Professional-Fermilab |
| CompProfU | U |  | Computing Professional-Non-Fermilab (University) |
| DesignerF | F | 34.65 | Designer/Drafter-Fermilab |
| DesignerU | U |  | Designer/Drafter-Non-Fermilab (University) |
| WBNDR | F |  | Wire Bonding Machine-Fermilab |
| CMMS | F |  | Small Coordinate Measuring Machine-Fermilab |
| CMMM | F |  | Medium Coordinate Measuring Machine-Fermilab |
| CMML | F |  | Large Coordinate Measuring Machine-Fermilab |
| WirebonderSF | F | 28.73 | Wire Bonder Tech-Fermilab |
| CMMOperatorSF | F | 28.73 | Coordinate Measuring Machine Tech-Fermilab |
| CMMProgrammerSF | F | 28.73 | Coordinate Measuring Machine Programmer-Fermilab |
| UMC850 |  |  |  |
| SASEQTestStandF | F |  |  |
| Chiller |  |  |  |
| OGP |  |  |  |
| LK |  |  |  |
| HybridBurnInStand |  |  | each stand tests 16 at a time for 3 days |
| ModuleBurnInStand |  |  | each stand test 40 at a time for 3 days |
| SASEQTestStandU | U |  |  |
| ElecTechF | F | 29.43 |  |
| MechTechF | F | 27.75 | Mechanical Tech - Fermilab |
| PostDocF | F |  |  |
| PostDocU | U |  |  |
| StudentU | U |  |  |
| PostDoc | UorF |  |  |
| Student | UorF |  |  |
| SeniorElecEngF | F | 47.15 | Senior Electrical Engineer-Fermilab |
| SeniorElecTechF | F | 30 | Senior Electrical Technician-Fermilab |
| SeniorMechEngF | F | 47.45 | Senior Mechanical Engineer-Fermilab |
| SeniorMechTechF | F | 28.73 | Senior Mechnical Technician-Fermilab |
| SurveyorF | F | 28.73 | Survey/Alignment-Fermilab |
| WelderF | F | 28.73 | Welder-Fermilab |
| AdminAsstF | F |  | Administrative Assistant-Fermilab |
| SeniorElecEngU | U |  |  |
| SeniorElecTechU | U |  |  |
| SeniorMechEngU | U |  |  |
| SeniorMechTechU | U |  |  |
| MandS |  | 1 |  |
| GapN |  |  |  |
| GapS |  |  |  |
| Cathedral |  |  |  |
| D0 Tech |  |  |  |
| SiDet Tech |  |  |  |
| Physicist |  |  |  |
| Surveyors |  |  |  |
| Lyn Bagby |  |  |  |
| Dave Butler |  |  |  |
| Ron Lipton |  |  |  |
| Bill Cooper |  |  |  |
| Russ Rucinski |  |  |  |
| Dan Markely |  |  |  |
| Rich Smith |  |  |  |
| Petros Rapidis |  |  |  |
| Ken Schulz |  |  |  |
| Dennis Graham |  |  |  |
| Ron Sidwell |  |  |  |
| Andre Numerotski |  |  |  |
| Jim Fast |  |  |  |
| Eric Kajfasz |  |  |  |
| John Fogelsong |  |  |  |
| Mike Matulik |  |  |  |
| Eliza Shabalina |  |  |  |
| John Anderson |  |  |  |
| Kurt Krempetz |  |  |  |
| Youri Orlov |  |  |  |
| Alan Stone |  |  |  |
| Tom Regan |  |  |  |
| Dan Edmunds |  |  |  |
| Phillipe Laurens |  |  |  |
| Jamieson Olson |  |  |  |
| Stefan Grunendahl |  |  |  |
| Steve Linn |  |  |  |
| Stefano Rapisarda |  |  |  |

## Schedule

| ID | WBS | Task | Type | Duration | Start | Finish | Predecessors | Complete | Remaining | Total slack | Free slack | Constraint | Resources | Work | Cost | Text27 | Text28 | Text1 |
| --- | --- | --- | --- | --- | --- | --- | --- | --- | --- | --- | --- | --- | --- | --- | --- | --- | --- | --- |
| 1 | 1.5 | **Run IIb Installation** |  | 508d | 2004-01-05 A | 2006-01-20 |  |  | 508d | 0d |  |  |  | 78276.4h | 719,663.58 |  |  |  |
| 2 | 1.5.1 | 2004 Shutdown | milestone | 0w | 2004-08-23 A | 2004-08-23 A |  | 100% |  |  |  | must start on 2004-08-23 |  |  |  |  |  |  |
| 3 | 1.5.2 | Shutdown for Installation Begins | milestone | 0w | 2005-06-29 | 2005-06-29 | 55SF, 62SF |  |  | 9d | 0d |  |  |  |  |  |  |  |
| 4 | 1.5.3 | Silicon Ready To Move To DAB | milestone | 0w | 2005-07-21 | 2005-07-21 |  |  |  | 0d |  | start no earlier than 2005-07-21 |  |  |  |  |  |  |
| 5 | 1.5.4 | **Layer 0 Silicon Installation** |  | 423d | 2004-01-05 | 2005-09-09 |  |  |  | 85d |  |  |  | 23590.3h | 255,773.48 |  |  |  |
| 6 | 1.5.4.1 | **Prepare Silicon Infrastructure** |  | 332d | 2004-01-05 | 2005-05-02 |  |  |  | 91d |  |  |  | 19566.3h | 214,976.58 |  |  |  |
| 7 | 1.5.4.1.1 | Prepare L0 Adapter Cards and Mounting |  | 50w | 2004-01-05 | 2005-01-05 |  |  |  | 91d | 0d |  | DesignerF [4%]; MandS; PhysicistU [5%]; Lyn Bagby [5%]; Ron Sidwell [5%]; Andre Numerotski [5%]; PhysicistF [10%]; SeniorMechTechF [2%] | 720h | 18,921 | FNAL | OP |  |
| 8 | 1.5.4.1.2 | Prepare New HV Power Supply Systems |  | 8w | 2004-11-16 | 2005-01-24 | 3FS-30w |  |  | 246d |  |  | Lyn Bagby [50%]; John Anderson [50%]; PhysicistF [50%]; SeniorElecEngF [50%] | 640h | 7,544 | FNAL | OP |  |
| 9 | 1.5.4.1.3 | Refurbish dry gas system |  | 8w | 2005-02-08 | 2005-04-04 | 3FS-20w |  |  | 195d | 86d |  | PhysicistF [25%]; SeniorMechTechF; MandS [50000%]; SeniorElecEngF [25%]; SeniorMechEngF [50%]; Russ Rucinski [25%]; Bill Cooper [25%]; Kurt Krempetz [25%] | 880h | 21,056 | FNAL | OP |  |
| 10 | 1.5.4.1.4 | Interface L0 Temp Monitoring System to DMACS |  | 2w | 2004-11-16 | 2004-12-01 | 3FS-30w |  |  | 275d | 166d |  | Dan Markely [25%]; CompProfF [25%] | 40h | 760 |  | OP |  |
| 11 | 1.5.4.1.5 | **Fall 2004 Shutdown** |  | 89d | 2004-07-26 | 2004-12-01 |  |  |  | 0d |  |  |  | 8662.35h | 95,031.59 |  |  |  |
| 12 | 1.5.4.1.5.1 | Label and Test TempMon Cables |  | 1w | 2004-08-30 | 2004-09-03 | 2FS+1w |  |  | 56.5d | 0d |  | PhysicistF [25%]; SeniorElecTechF; MandS [50000%]; Lyn Bagby [25%] | 60h | 1,700 | FNAL | OP |  |
| 13 | 1.5.4.1.5.2 | Install Temperature Monitor Cables |  | 0.5w | 2004-09-07 | 2004-09-09 | 12 |  |  | 56.5d |  | start no earlier than 2004-08-23 | PhysicistF [50%]; SeniorMechTechF; Lyn Bagby [50%] | 40h | 574.5 | FNAL | OP |  |
| 14 | 1.5.4.1.5.3 | Install L0 Temp Monitor Junction Brackets on Horseshoes |  | 0.25w | 2004-09-07 | 2004-09-08 | 2FS+2w |  |  | 57.75d |  | start no earlier than 2004-08-23 | PhysicistF [10%]; SeniorMechTechF [50%]; PhysicistU [10%]; Lyn Bagby [10%] | 8h | 143.63 | FNAL | OP |  |
| 15 | 1.5.4.1.5.4 | Prepare New LV Power Supply System for L0 |  | 4w | 2004-07-26 | 2004-08-20 | 2FS-4w |  |  | 67d | 0d |  | MandS [750000%]; Lyn Bagby [50%]; John Fogelsong [50%]; John Anderson [25%]; SeniorMechTechF [50%]; SeniorMechEngF [25%]; PhysicistF [50%]; SeniorElecEngF [75%] | 520h | 17,354 |  |  | 9/1 |
| 16 | 1.5.4.1.5.5 | Test Isolated PS Interlock System |  | 0.4w | 2004-08-23 | 2004-08-24 | 15, 45 |  |  | 67d |  |  | PhysicistF [25%]; Dan Markely; Bill Cooper [25%]; John Fogelsong; CompProfF; SeniorElecEngF | 72h | 1,362.4 | FNAL | OP |  |
| 17 | 1.5.4.1.5.6 | **Refurbish H disks** |  | 63d | 2004-08-09 | 2004-11-04 |  |  |  | 16d |  |  | PhysicistF; SeniorMechTechF; SeniorElecTechF; SASEQTestStandF; CMMOperatorSF; PhysicistU [400%] | 7962.35h | 73,897.06 |  |  |  |
| 18 | 1.5.4.1.5.6.1 | Prepare Fixtures and CMM |  | 2w | 2004-08-09 | 2004-08-20 | 2FS-2w |  |  | 27d | 11d |  | SiDet Tech; Jim Fast [50%]; PhysicistF [50%] | 160h |  | FNAL | OP |  |
| 19 | 1.5.4.1.5.6.2 | Disconnect N Tev Beampipe |  | 0.6w | 2004-08-23 | 2004-08-25 | 2 |  |  | 16d | 0d |  | PhysicistF [10%]; SeniorMechEngF [10%]; SeniorMechTechF [200%]; GapN; Russ Rucinski [10%]; Bill Cooper [10%] | 81.6h | 1,492.68 | FNAL | OP |  |
| 20 | 1.5.4.1.5.6.3 | Disconnect S Tev Beampipe |  | 0.6w | 2004-08-26 | 2004-08-30 | 19 |  |  | 16d | 0d |  | PhysicistF [10%]; SeniorMechEngF [10%]; SeniorMechTechF [200%]; GapS; Bill Cooper [10%]; Russ Rucinski [10%] | 81.6h | 1,492.68 | FNAL | OP |  |
| 21 | 1.5.4.1.5.6.4 | Open CF, EC, Install Platforms and Walkways |  | 0.6w | 2004-08-30 | 2004-09-01 | 20FS-0.2w |  |  | 16d | 0d |  | SeniorMechTechF [400%]; PhysicistF; SeniorMechEngF [50%]; Russ Rucinski [50%] | 144h | 3,327 | FNAL | OP |  |
| 22 | 1.5.4.1.5.6.5 | Remove North H disks |  | 0.6w | 2004-09-02 | 2004-09-07 | 21, 19 |  |  | 16d | 0d |  | SeniorMechTechF [200%]; PhysicistF [50%]; GapN [200%]; Dennis Graham; Dave Butler; Bill Cooper [50%] | 96h | 344.7 | FNAL | OP |  |
| 23 | 1.5.4.1.5.6.6 | Photograph North area and begin Si survey |  | 1w | 2004-09-08 | 2004-09-14 | 22 |  |  | 28d | 5d |  | Surveyors [200%]; GapN [200%]; PhysicistF [50%]; Bill Cooper [50%]; Youri Orlov; SeniorMechEngF | 280h | 1,898 | FNAL | OP |  |
| 24 | 1.5.4.1.5.6.7 | Refurbish North H disks |  | 2w | 2004-09-08 | 2004-09-21 | 22, 18 |  |  | 16d | 0d |  | SiDet Tech; PhysicistF | 160h |  | FNAL | OP |  |
| 25 | 1.5.4.1.5.6.8 | Reinstall North H disks |  | 1w | 2004-09-22 | 2004-09-28 | 24, 23 |  |  | 23d | 7d |  | GapN [200%]; SeniorMechTechF [300%]; PhysicistF [50%]; Bill Cooper [50%]; Dave Butler; Ken Schulz; Dennis Graham; Cathedral | 180.89h | 1,225.6 | FNAL | OP |  |
| 26 | 1.5.4.1.5.6.9 | Remove South H disks |  | 0.6w | 2004-09-08 | 2004-09-10 | 22, 20 |  |  | 23d | 0d |  | PhysicistF [50%]; GapS [200%]; SeniorMechTechF [200%]; Bill Cooper [50%]; Dave Butler; Dennis Graham | 122.26h | 1,378.8 | FNAL | OP |  |
| 27 | 1.5.4.1.5.6.10 | Photograph South and complete Si Survey |  | 2w | 2004-09-13 | 2004-09-24 | 26 |  |  | 23d | 7d |  | Surveyors [200%]; PhysicistF [50%]; GapS [200%]; Bill Cooper [50%]; Youri Orlov; SeniorMechEngF | 560h | 3,796 | FNAL | OP |  |
| 28 | 1.5.4.1.5.6.11 | Refurbish South H disks |  | 2w | 2004-09-22 | 2004-10-05 | 24, 26, 18 |  |  | 16d | 0d |  | SiDet Tech; PhysicistF | 160h |  | FNAL | OP |  |
| 29 | 1.5.4.1.5.6.12 | Reinstall South H disks |  | 0.4w | 2004-10-06 | 2004-10-07 | 28, 27 |  |  | 16d | 0d |  | SeniorMechTechF [300%]; PhysicistF [50%]; GapS [200%]; Ken Schulz [50%]; Dennis Graham; Dave Butler; Bill Cooper [50%]; Cathedral | 152h | 1,378.8 | FNAL | OP |  |
| 30 | 1.5.4.1.5.6.13 | Complete testing and checkout of H-disks |  | 1w | 2004-10-08 | 2004-10-14 | 29, 25 |  |  | 16d | 0d |  | PhysicistF [400%]; Cathedral [200%]; GapN; GapS; Ron Lipton; Petros Rapidis; Andre Numerotski; Eric Kajfasz | 480h |  | FNAL | OP |  |
| 31 | 1.5.4.1.5.6.14 | Reconnect North Tev Beampipe |  | 1w | 2004-10-15 | 2004-10-21 | 30 |  |  | 16d | 0d |  | SeniorMechTechF [200%]; SeniorMechEngF [10%]; PhysicistF [10%]; GapN; Bill Cooper [10%]; Russ Rucinski [10%] | 136h | 2,487.8 | FNAL | OP |  |
| 32 | 1.5.4.1.5.6.15 | Reconnect South Tev Beampipe |  | 1w | 2004-10-15 | 2004-10-21 | 30 |  |  | 16d | 0d |  | SeniorMechTechF [200%]; GapS; SeniorMechEngF [10%]; PhysicistF [10%]; Bill Cooper [10%]; Russ Rucinski [10%] | 136h | 2,487.8 | FNAL | OP |  |
| 33 | 1.5.4.1.5.6.16 | Pumpout and Leakcheck Beampipe |  | 1w | 2004-10-22 | 2004-10-28 | 32, 31 |  |  | 16d | 0d |  | SeniorMechTechF [400%]; SeniorMechEngF [25%]; GapS [200%]; GapN [200%]; Russ Rucinski [25%] | 340h | 5,070.5 | FNAL | OP |  |
| 34 | 1.5.4.1.5.6.17 | Remove Platforms and Walkways, Close EF, CF |  | 0.6w | 2004-10-29 | 2004-11-02 | 33 |  |  | 16d | 0d |  | SeniorMechEngF [50%]; Russ Rucinski [50%]; SeniorMechTechF [400%] | 120h | 3,327 | FNAL | OP |  |
| 35 | 1.5.4.1.5.6.18 | Survey CF, EF |  | 0.4w | 2004-11-03 | 2004-11-04 | 34 |  |  | 16d | 0d |  | Surveyors [200%]; SeniorMechTechF [25%] | 36h | 114.9 | FNAL | OP |  |
| 36 | 1.5.4.1.5.6.19 | H Disk Refurbishment Complete | milestone | 0w | 2004-11-04 | 2004-11-04 | 30, 35 |  |  | 16d |  |  |  |  |  |  |  |  |
| 37 | 1.5.4.1.5.7 | End of Fall 2004 Shutdown | milestone | 0w | 2004-12-01 | 2004-12-01 | 36, 12, 13, 14, 16 |  |  | 0d |  | must start on 2004-12-01 |  |  |  |  |  |  |
| 38 | 1.5.4.1.6 | Design, Fabricate, and Test Silicon Transport Fixture |  | 4w | 2004-11-16 | 2004-12-15 | 3FS-30w |  |  | 89d | 80d |  | DesignerF [50%]; PhysicistF [50%]; SeniorMechEngF [50%]; SeniorMechTechF [50%]; MandS [250000%]; Bill Cooper [50%] | 400h | 11,366 | FNAL | OP | 9/1 |
| 39 | 1.5.4.1.7 | Design, Fabricate, and Test Silicon Installation Fixture |  | 4w | 2004-12-16 | 2005-01-24 | 3FS-26w |  |  | 69d | 60d |  | DesignerF; PhysicistF [50%]; SeniorMechEngF; SeniorMechTechF [50%]; MandS [250000%]; Bill Cooper [50%] | 560h | 17,934 | FNAL | OP |  |
| 40 | 1.5.4.1.8 | Design and Fabricate Silicon Alignment Fixtures |  | 4w | 2005-01-25 | 2005-02-21 | 3FS-22w |  |  | 49d | 40d |  | PhysicistF [50%]; DesignerF; SeniorMechEngF; MandS [500000%]; Bill Cooper [50%] | 480h | 18,136 | FNAL | OP |  |
| 41 | 1.5.4.1.9 | Design, fabricate and test Beampipe Handling Fixtures |  | 2w | 2005-02-22 | 2005-03-07 | 3FS-18w |  |  | 39d | 0d |  | DesignerF; PhysicistF [50%]; SeniorMechEngF; MandS [250000%]; Bill Cooper [50%] | 240h | 9,068 | FNAL | OP |  |
| 42 | 1.5.4.1.10 | Modify RunIIa L3/Offline Silicon Software - U |  | 16w | 2004-08-23 | 2004-12-15 | 3FS-42w |  |  | 99d | 90d |  | PhysicistU [150%] | 960h |  |  | DOE-base |  |
| 43 | 1.5.4.1.11 | Modify RunIIa L3/Offline Silicon Software - FNAL |  | 16w | 2004-08-23 | 2004-12-15 | 3FS-42w |  |  | 99d | 90d |  | PhysicistF | 640h |  | FNAL | OP |  |

Notes:
- 1: WBS Definition- / This summary task has as its scope the removal of the Run IIa silicon Hdisks and the installation of a new L0 tracker, and the installation of the L1 Calorimeter tracking trigger, the L1 Calorimeter track matching system, upgrades to the Level 2 beta processors, the L2 silicon track trigger upgrade, and the technical commissioning of all the new systems prior to the closing of the detector and the restart of the colliding beam program.
- 5: WBS Definition- / This summary task covers the effort to install the L0 silicon tracker for the D0 Run IIb upgrade project. The detector will augment the existing silicon microstrip tracker currently in use for Run IIa, and it assumes the use of the Vicor LV supplies and special adapter cards plus SVX4 readouts for the L0 channels, and it assumes the use of 80-conductor cables for the 300V HV supply.
- 6: WBS Definition- / This summary task includes activities that must take place to ensure that all infrastructure components required for the Run II b silicon (cables, adapter cards, chiller and dry gas systems, transportation and alignment fixtures, temperature monitoring system and HV and LV systems) are in hand prior to shutdown.
- 7: WBS Definition- / This task provides for the design, plus considerations for mounting and cooling, of the L0 adapter cards required for the SVX4 silicon readout. The adapter cards will be mounted on the existing horseshoes on the N and S faces of the Central Calorimeter in the RunIIa H-disk locations, and powered by new Wiener LV supplies. / Attention to cooling is required and measurements of power loads at the adapter cards will be made to quantify the heat load created at the horseshoes. / Included in the design task are considerations of cable routing (re-use of the 80-conductor cables of the H-disks) and considerations of the radiation monitor boards and cables, and L0 temperature monitor boards and cables) that must be added to the existing horseshoes on the N and S faces of the Central Calorimeter. / M&S BOE- / Adding cooling for new adapter cards may require a small amount of parts fabrication for active air-flow or passive conductive cooling for the new adapter cards. Until heat load (<100 W ?) is established, the choice of technology is not known. Contingency on this estimate is therefore set at 100%. / Labor BOE- / 1/2 man-month of designer (i.e. Jack Mateski), and 2 man-months of physicst time are required to complete this task, but contingency is put at 100% until the details of the task are better understood. Some combination of Ron Sidwell, Andre Numerotski, and Lyn Bagby are the preferred physicists.
- 8: WBS Definition- / This task provides for the consideration of the high voltage fanouts for the L0 channels -- additional fanouts may be necessary in MCH2 if those released by the removal of the H-disks are inappropriate. / M&S BOE- / Added HV channels may be required in MCH2, but no additional 34-conductor cables are required. / Labor BOE- / Two man-months of physicst time and the like for Electrical Engineer are required to complete this task. Lynn Bagby and John Foglesong are the preferred personne
- 9: WBS Definition- / This task provides for required refurbishment of the existing dry air system for the silicon, including overhaul of the (dual) compressors, refurbishment of the driers, and any other needed preventive maintenance (e.g. tube trailer recertification) . Because the components are dual, the refurbishment takes place prior to the shutdown for RunIIb during normal physics operation of the Tevatron. / M&S BOE- / A small amount of hardware (electrical, valves, etc.) may be required for the refurbishment, $500 Contingency is set at 100% given the lack of detail available for this system. / Labor BOE- / The estimated labor requirements are based on RunIIA experience with the dry air system. One full time mechanical technician, plus 2w of a mechanical engineer, 2 weeks of an electrical engineer, and 2w of a physicist to guide the task, are required. Contingency is set at 150%. Dan Markley is the preferred electrical engineer, Bill Cooper the preferred physicist, and Russ Rucinski the preferred mechanical engineer.
- 10: WBS Definition- / This task provides for the intervacing of the L0 Temp Mon system to the Cryo Computer Control system DMACS. / M&S BOE- / NA / Labor BOE- / The estimated labor requirements are based on RunIIA experience, where hundreds of channels of temperature monitoring were interfaced to the DMACS system. Dan Markley is the preferred electrical engineer.
- 12: WBS Definition- / This task tests, labels and bundles he temperature monitoring cables for the L0 detector (DMarkley chassis in Platform to horseshoes). Summer 2004 shutdown provides adequate window for installation of cables. / M&S BOE- / $500 for cables / Labor BOE- / Testing, labeling, bundling effort: 12 temperature monitoring cables. / Labeling & Testing: Glenair tester permits testing of 1 cable in 5--10 minutes. Labeling and bundling make the task a full day's job.
- 13: WBS Definition- / This task installs the temperature monitoring cables for the L0 detector (DMarkley chassis in Platform to horseshoes). Summer 2004 shutdown provides adequate window for installation of cables. / M&S BOE- / Labor BOE- / Installing effort: 12 temperature monitoring cables.
- 14: WBS Definition- / This task installs new L0 silicon temperature monitoring junction brackets on the horsehoes. This task to be done during the 2004 shutdown. / M&S BOE- / NA / Labor BOE- / Estimates are based on a considertion of the complexity of the task. Lyn Bagby and Marge Corcoran will provide supervision.
- 15: WBS Definition- / One new Wiener LVPS unit (4 modules) are required in MCH2, plus 10 cables to the Cathedral minifuse panels. In addition to design of cables and fuse panels, the task includes linking the system to the Silicon glycol system so a cooling trip also shuts down the Wiener PS. / At least 3 modules in a unit will be installed in the 2004 shutdown, plus the minifuse panels. / The trip system will be installed and tested in the 2004 shutdown. / M&S BOE- / M&S ($7.5K) for contingent purchase of 1 extra Wiener unit is allotted. / Labor BOE- / One man-months of physicst time and the like for Electrical Engineer are required to complete this task. Lynn Bagby and John Foglesong are the preferred personnel.
- 16: WBS Definition- / This task installs and tests the new L0 silicon LV system temperature interlock. It will be done in the 2004 shutdown. Safety/PORC review needed prior to test/operation. / M&S BOE- / NA / Labor BOE- / Estimates are based on a considertion of the task. Dan Markley and John Foglesong, plus Bill Cooper, and an Operations Tech are required.
- 17: WBS Definition- / This task removes, refurbishes, and reinstalls H-disks during summer 2004 shutdown. / Included is task of reworking test stand at SiDet for SVX2's. / M&S BOE- / NA / Labor BOE- / Technicians for decabling, removal, repair at SiDet, then reinstallation into detector, plus physicist effort to guide task, and test system after reinstallation.
- 18: WBS Definition- / This task begins before the 2004 shutdown. It gathers the RunIIa H-disk fabrication fixtures into the SiDet cleanroom, locates and tests the CMM software used during the RunIIa assembly of the H-disks / M&S BOE- / NA / Labor BOE- / Estimates are based on RunIIa experience.
- 19: WBS Definition- / This task takes place during the 2004 shutdown. / This task opens the N muon shield clamshells in the N EMC truss, retracts the N Muon shield into the clamshells, opens EFN, disconnects the Tevatron beampipe at the N EC beampipe, removes the FPD Veto counters, supports the Tev beampipe, closes NEF, disconnects the Tevatron beampipe at the isolation valve/X/bellows near the low beta quad, removes the Tevatron beampipe spoolpiece, and reopens N EF. / M&S BOE- / NA / Labor BOE- / RunIIa experience, when the Tevatron beampipe was originally installed, forms the basis of estimate for effort (the three motions of EF alone will consume approximately three half-shifts).
- 20: WBS Definition- / This task takes place during the 2004 shutdown. / This task opens the S muon shield clamshells in the S EMC truss, retracts the S Muon shield into the clamshells, opens EFS, disconnects the Tevatron beampipe at the S EC beampipe, removes the FPD Veto counters, supports the Tev beampipe, closes SEF, disconnects the Tevatron beampipe at the isolation valve/X/bellows near the low beta quad, removes the Tevatron beampipe spoolpiece, and reopens S EF. / M&S BOE- / NA / Labor BOE- / RunIIa experience, when the Tevatron beampipe was originally installed, forms the basis of estimate for effort (the three motions of EF alone will consume approximately three half-shifts).
- 21: WBS Definition- / This task opens the CF steel, and the two end calorimeters, and installs the platforms and accessways needed for access to the gaps and cathedral. / M&S BOE- / NA / Labor BOE- / RunIIa experience, where this task was done on occasion, forms the basis of estimate for effort. Six people are required (4 as observers), to ensure cables, etc. aren't damaged during the motion of the heavy pieces.
- 22: WBS Definition- / This task takes place during the 2004 shutdown. / This task disconnects the NEC beampipe from the beryllium beampipe (and slides it into NEC), removes the dry-gas seal from the silicon area, disconnects the cooling from the H-disks (check tritium content of small amount of coolant removed), disconnects and secures in an out-of-the way area 24 low-mass cables from the North H-disks, removes both the H-disks, inserts them into existing handling cases, and transports them to SiDet. / M&S BOE- / NA / Labor BOE- / Estimates are based on RunIIa experience. Dave Butler, Lyn Bagby, and Denny Graham are the preferred personnel.
- 23: WBS Definition- / This task takes place during the 2004 shutdown. / This task photographs the N H-disk area, installs survey equipment in the N gap and begins the survey of the gap between the beryllium beampipe and the RunIIa silicon bulkheads (especially those at Z = 0). / M&S BOE- / NA / Labor BOE- / Estimates are based on discussions with surveyors and experience with mockup. Youri Orlov, Bill Cooper and Dave Butler are the preferred personnel.
- 24: WBS Definition- / This task takes place during the 2004 shutdown. / This task removes defective wedges from the inner H-disk, replaces them with working wedges from spares and the outer H-disk to provide a "100%" inner disk. All remaining working wedges are placed in the outer H-disk bringing it to ~ 60% working. Both disks are tested at SiDet then shipped back to DAB. / M&S BOE- / NA / Labor BOE- / Estimates are based on RunIIa experience when the H-disks were originally fabricated.
- 25: WBS Definition- / This task takes place during the 2004 shutdown. / This task installs the H-disks, reconnects the low-mass cables, the dry-gas seal, and the cooling lines. / M&S BOE- / NA / Labor BOE- / Estimates are based on RunIIa experience. Dave Butler, Lyn Bagby, and Denny Graham are the preferred personnel, assisted by Ken Schulz and Bill Cooper.
- 26: WBS Definition- / This task takes place during the 2004 shutdown. / This task disconnects the SEC beampipe from the beryllium beampipe (and slides it into SEC), removes the dry-gas seal from the silicon area, disconnects the cooling of the H-disks, disconnects and secures in an out-of-the way area 24 low-mass cables from the South H-disks, and removes both the H-disks, inserts them existing handling cases, and transports them to SiDet. / M&S BOE- / NA / Labor BOE- / Estimates are based on RunIIa experience. Dave Butler, Lyn Bagby, and Denny Graham are the preferred personnel.
- 27: WBS Definition- / This task takes place during the 2004 shutdown. / This task photographs the S H-disk area and installs survey equipment in the S gap and surveys the gap between the beryllium beampipe and the RunIIa silicon bulkheads (especially those at Z = 0). / M&S BOE- / NA / Labor BOE- / Estimates are based on discussions with surveyors and experience with mockup. Youri Orlov, Bill Cooper and Dave Butler are the preferred personnel.
- 28: WBS Definition- / This task takes place during the 2004 shutdown. / This task removes defective wedges from the inner H-disk, replaces them with working wedges from spares and the outer H-disk to provide a "100%" inner disk. All remaining working wedges are placed in the outer H-disk bringing it to ~ 60% working. Both disks are tested at SiDet then shipped back to DAB. / M&S BOE- / NA / Labor BOE- / Estimates are based on RunIIa experience when the H-disks were originally fabricated.
- 29: WBS Definition- / This task takes place during the 2004 shutdown. / This task installs the H-disks, reconnects the low-mass cables, the dry-gas seal, and the cooling lines. / M&S BOE- / NA / Labor BOE- / Estimates are based on RunIIa experience. Dave Butler, Lyn Bagby, and Denny Graham are the preferred personnel, assisted by Ken Schulz and Bill Cooper.
- 30: WBS Definition- / This task takes place during the 2004 shutdown. / This task completes the rull readout chain test of the H-disks. / M&S BOE- / NA / Labor BOE- / Estimates are based on RunIIa experience, abetted by the fact that only the low-mass cable connection is suspect (the balance of the readout chain, and the detector, are presumed fully operational). Ron Lipton, Andre Numerotski, Eric Kajfasz and Petros Rapidis are the preferred personnel. Work can proceed on a two-shift basis.
- 31: WBS Definition- / This task takes place during the 2004 shutdown. / This task pulls the ECN beampipe south, connects it to the bellows at the beryllium beampipe, removes the scaffolds in the gap, closes ECN and connects the Tev spoolpiece to the ECN beampipe, closes EFN and connects the spoolpiece to the Tev isolation valve near the low beta quad. / M&S BOE- / NA / Labor BOE- / RunIIa experience forms the basis of estimate for effort (typically an EF can be opened in 1/2 shift, the calorimeter in 1/2 shift.
- 32: WBS Definition- / This task takes place during the 2004 shutdown. / This task pulls the ECS beampipe north, connects it to the bellows at the beryllium beampipe, removes the scaffolds in the gap, closes ECS and connects the Tev spoolpiece to the ECS beampipe, closes EFS and connects the spoolpiece to the Tev isolation valve near the low beta quad. / M&S BOE- / NA / Labor BOE- / RunIIa experience forms the basis of estimate for effort (typically an EF can be opened in 1/2 shift, the calorimeter in 1/2 shift. Two shifts per day assumed.
- 33: WBS Definition- / This task takes place during the 2004 shutdown. / This task pumps down and leakchecks the beampipe. The joint where the TeV spoolpieces connect to the bellows/X/valve near the N & S low beta quads are checked first, then the EF's are opened and the joints between the Tev spoolpieces and the EC beampipes are checked, then the EC are opened and the joints at the beryllium beampipes are checked. Time is allowed for re-manipulation of the EC and the EF to chase recalcitrant leaks. / M&S BOE- / NA / Labor BOE- / RunIIa experience forms the basis of estimate for effort. Two shifts per day assumed.
- 34: WBS Definition- / This task takes place during the 2004 shutdown. / This task removes accessways from the cathedral (and any scaffolding put in the gaps for leak checking), and closes CF and the EF. / M&S BOE- / NA / Labor BOE- / RunIIa experience forms the basis of estimate for effort.
- 35: WBS Definition- / This task takes place during the 2004 shutdown. / This task energizes the toroid magnets to "set" the position of CF, then makes stickmike survey of CF and EF. / M&S BOE- / NA / Labor BOE- / RunIIa experience forms the basis of estimate for effort.
- 36: WBS Definition- / Milestone- H-disks have been removed, refurbished, replaced, tested and surveyed.
- 38: WBS Definition- / This task prepares the transportation fixture required to safely move the L0 silicon from SiDet to DAB. / M&S BOE- / $1000 M&S is provided to make a tube-like container with purge system for transport of L0 to DAB / Labor BOE- / Design effort: 2 week engineer, 2 week designer, 4 weeks physicist but contingency is put at 5 / 50% until the details of the silicon installation are better understood.
- 39: WBS Definition- / This task designs and tests the fixturing needed for installing the L0 silicon into the existing RunIIa silcon array. Additional fixturing will also enable the precise location of the L0 array with respect to the existing RunIIa silicon to be verified. / M&S BOE- / $2500 is allowed for the fabrication of the needed fixturing, / Labor BOE- / The labor to install the L0 detector is expected to be small, but contingency is put at 100% until the details of the task are better understood.
- 40: WBS Definition- / Design the fixtures to aid in aligning the Layer Zero silicon with the RunIIa silicon. / M&S BOE- / $5000 is allowed for the fabrication of needed fixtures. / Labor BOE- / The fixtures required are expected to be modest in complexity, but contingency on labor estimates are set at 100%. Bill Cooper is the preferred physicist, Youri Orlov is the preferred engineer.
- 41: WBS Definition- / This task provides improvement to the RunIIa beampipe handling fixture, for removal of the beryllium beampipe from the silicon / M&S BOE- / $2500 is allowed for the fabrication of the needed fixtures. / Labor BOE- / This fixture is expected to improve on that used for RunIIa, so the estimate of labor is based on considerations of that device: 2 weeks mechanical engineer, 2 weeks physicist, and 2 weeks designer, contingency is put at 150% until the details of the task are better understood. Bill Cooper is the preferred physicist, Youri Orlov is the preferred ME.
- 42: WBS Definition- / This task modifies the L3/offline software needed for the L0 silicon system at DAB. Included is simulation(D0gstar), unpacking and calibration, cluster reconstruction, L3 algorithms, track resonstruction(RECO), monitoring (Examine, event display). / M&S BOE- / NA / Labor BOE- / The effort estimates are made by assessing the time needed to make a series of well-defined modifications to the existing Run IIa software. The effort estimates and capable individuals are: simulation 8mw (Chabalina), unpacking and calibration 4 mw (Kulik, Zdrazil), cluster reconstruction 8mw (Barberis, Kulik), L3 algorithms 3mw (Illingworth), track reconstruction 6mw (Kulik, Khanov, Borisov), monitoring 12mw (Chabalina, Hesketh, Dean).
- 43: WBS Definition- / This task modifies the L3/offline software needed for the L0 silicon system at DAB. Included is simulation(D0gstar), unpacking and calibration, cluster reconstruction, L3 algorithms, track resonstruction(RECO), monitoring (Examine, event display). / M&S BOE- / NA / Labor BOE- / The effort estimates are made by assessing the time needed to make a series of well-defined modifications to the existing Run IIa software. The effort estimates and capable individuals are: simulation 8mw (Chabalina), unpacking and calibration 4 mw (Kulik, Zdrazil), cluster reconstruction 8mw (Barberis, Kulik), L3 algorithms 3mw (Illingworth), track reconstruction 6mw (Kulik, Khanov, Borisov), monitoring 12mw (Chabalina, Hesketh, Dean).

| ID | WBS | Task | Type | Duration | Start | Finish | Predecessors | Total slack | Free slack | Deadline | Resources | Work | Cost | Text27 | Text28 | Text1 |
| --- | --- | --- | --- | --- | --- | --- | --- | --- | --- | --- | --- | --- | --- | --- | --- | --- |
| 44 | 1.5.4.1.12 | **Prepare Safety and PORC documentation** |  | 332d | 2004-01-05 | 2005-05-02 |  | 9d |  |  | PhysicistF; SeniorElecEngU [50%] | 5344h | 15,160 |  |  |  |
| 45 | 1.5.4.1.12.1 | Prepare Si LVPS Safety and PORC Documentation |  | 4w | 2004-01-05 | 2004-02-02 |  | 209d | 142d |  | PhysicistF [50%]; SeniorElecEngF [50%]; John Anderson [50%]; Lyn Bagby [50%] | 320h | 3,772 | FNAL | OP |  |
| 46 | 1.5.4.1.12.2 | Prepare L0 Si Cooling Safety and PORC Documentation |  | 4w | 2005-03-08 | 2005-04-04 | 3FS-16w | 29d | 20d |  | PhysicistF [50%]; Bill Cooper [50%]; Russ Rucinski [50%]; SeniorMechEngF [50%] | 320h | 3,796 | FNAL | OP |  |
| 47 | 1.5.4.1.12.3 | Prepare L0 Si Dry Gas Safety and PORC Documentation |  | 4w | 2005-04-05 | 2005-05-02 | 3FS-12w | 9d | 0d |  | PhysicistF [50%]; SeniorMechEngF [50%]; Bill Cooper [50%]; Russ Rucinski [50%] | 320h | 3,796 | FNAL | OP |  |
| 48 | 1.5.4.1.12.4 | Prepare L0 Si Transport, Install, Align Safety and PORC Documentation |  | 2w | 2005-04-19 | 2005-05-02 | 38, 39, 40, 3FS-10w | 9d | 0d |  | PhysicistF [50%]; SeniorMechEngF [50%]; Bill Cooper [50%]; Youri Orlov [50%] | 160h | 1,898 | FNAL | OP |  |
| 49 | 1.5.4.1.12.5 | Prepare Beampipe Handling Safety Documentation |  | 2w | 2005-03-08 | 2005-03-21 | 41 | 39d | 30d |  | PhysicistF; Rich Smith | 160h |  | FNAL | OP |  |
| 50 | 1.5.4.1.12.6 | Prepare Tevatron Beampipe Leak Checking Procedure |  | 2w | 2005-02-08 | 2005-02-21 | 3FS-20w | 59d | 50d |  | SeniorMechEngF [50%]; Kurt Krempetz [50%] | 80h | 1,898 | FNAL | OP |  |
| 51 | 1.5.4.1.12.7 | Safety and PORC Documentation Completed | milestone | 0w | 2005-05-02 | 2005-05-02 | 45, 46, 47, 48, 49, 50 | 9d | 0d |  |  |  |  |  |  |  |
| 52 | 1.5.4.1.13 | Silicon Infrastructure Prepared | milestone | 0w | 2005-05-02 | 2005-05-02 | 7, 38, 39, 40, 42, 41, 12, 13, 14, 16, 36, 51, 43 | 9d |  | 2005-05-13 |  |  |  |  |  |  |
| 53 | 1.5.4.2 | **Open Detector and Install CC-EC Scaffolding** |  | 7d | 2005-06-28 | 2005-07-08 |  | 9d |  |  |  | 332h | 5,759.9 |  |  |  |
| 54 | 1.5.4.2.1 | Perform CH Rad Survey |  | 0.2w | 2005-06-28 | 2005-06-29 | 55SF | 9d | 0d |  | PhysicistF | 8h |  | FNAL | OP |  |
| 55 | 1.5.4.2.2 | Disconnect N Tev Beampipe |  | 0.4w | 2005-06-29 | 2005-07-01 | 56SF | 9d | 0d |  | SeniorMechTechF [400%]; SeniorMechEngF [25%]; Russ Rucinski [25%] | 72h | 2,028.2 | FNAL | OP |  |
| 56 | 1.5.4.2.3 | Disconnect S Tev Beampipe |  | 0.4w | 2005-07-01 | 2005-07-06 | 57SF | 9d | 0d |  | SeniorMechTechF [400%]; SeniorMechEngF [25%]; Russ Rucinski [25%] | 72h | 2,028.2 | FNAL | OP |  |
| 57 | 1.5.4.2.4 | Open CF, End Calorimeters |  | 0.2w | 2005-07-06 | 2005-07-07 | 59SF | 9d | 0d |  | PhysicistF [400%]; Cathedral [400%]; GapN; GapS; SeniorMechTechF [200%]; SeniorMechEngF [25%]; Russ Rucinski [25%] | 100h | 554.5 | FNAL | OP |  |
| 58 | 1.5.4.2.5 | Make Be assay of beampipe |  | 0.2w | 2005-07-06 | 2005-07-07 | 59SF | 131d | 1d |  | SeniorMechTechF; GapS [50%]; GapN [50%] | 16h | 229.8 | FNAL | OP |  |
| 59 | 1.5.4.2.6 | Install accesways, CC-EC gap scaffolds |  | 0.2w | 2005-07-07 | 2005-07-08 | 63SF | 9d | 0d |  | GapN; GapS; Cathedral [200%]; SeniorMechTechF [400%] | 64h | 919.2 | FNAL | OP |  |
| 60 | 1.5.4.2.7 | Detector Open and Ready for Access | milestone | 0w | 2005-07-08 | 2005-07-08 | 57, 56, 55, 59, 58 | 130d |  |  |  |  |  |  |  |  |
| 61 | 1.5.4.3 | **Decable and Remove RunIIa H Disks, EC beampipes** |  | 13d | 2005-06-28 | 2005-07-18 |  | 9d |  |  |  | 568h | 6,788.9 |  |  |  |
| 62 | 1.5.4.3.1 | Warm Silcon to CH Dewpoint |  | 0.2w | 2005-06-28 | 2005-06-28 | 54SS | 9d | 1d | 2005-07-12 | PhysicistF [50%]; SeniorMechEngF [25%]; SeniorMechTechF; Bill Cooper [50%] | 18h | 324.7 | FNAL | OP |  |
| 63 | 1.5.4.3.2 | Remove EC Beampipe flanges and bellows |  | 0.2w | 2005-07-08 | 2005-07-11 | 64SF | 9d | 0d |  | PhysicistF [25%]; GapN; GapS; SeniorMechEngF [50%]; SeniorMechTechF [200%]; Russ Rucinski [50%]; Bill Cooper [25%] | 44h | 649.4 | FNAL | OP |  |
| 64 | 1.5.4.3.3 | Close ECN, remove ECN beampipe, reopen ECN |  | 0.2w | 2005-07-11 | 2005-07-12 | 65SF | 9d | 0d |  | SeniorMechTechF [400%]; GapN [200%]; Cathedral [200%] | 64h | 919.2 | FNAL | OP |  |
| 65 | 1.5.4.3.4 | Remove H-disks |  | 0.4w | 2005-07-12 | 2005-07-14 | 66SF | 9d | 0d |  | PhysicistF [50%]; GapN [200%]; GapS [200%]; SeniorMechEngF [50%]; SeniorMechTechF [600%]; Dennis Graham; Dave Butler; Bill Cooper [50%]; Russ Rucinski [50%]; Cathedral [400%] | 288h | 3,137.2 | FNAL | OP |  |
| 66 | 1.5.4.3.5 | Install N L0 Junction Cards, Adapter Cards |  | 0.2w | 2005-07-14 | 2005-07-15 | 68SF | 9d | 0d |  | PhysicistF [50%]; GapS; GapN; SeniorMechTechF [400%]; Lyn Bagby [50%]; John Fogelsong [25%]; Dave Butler; Dennis Graham | 74h | 919.2 | FNAL | OP | 9/1 |
| 67 | 1.5.4.3.6 | Install S L0 Junction Cards, Adapter Cards |  | 0.2w | 2005-07-15 | 2005-07-15 | 66 | 124d |  |  |  |  |  |  |  | 9/1 |
| 68 | 1.5.4.3.7 | Install L0 Installation Cradle in ECN Gap |  | 0.2w | 2005-07-15 | 2005-07-18 | 71SF | 9d | 0d |  | GapN [200%]; SeniorMechTechF [200%]; Surveyors [200%]; Youri Orlov; Bill Cooper [50%]; SeniorMechEngF; Cathedral; PhysicistF [50%] | 80h | 839.2 | FNAL | OP |  |
| 69 | 1.5.4.3.8 | RunIIa H-Disks and EC Beampipes Removed | milestone | 0w | 2005-07-18 | 2005-07-18 | 68 | 124d |  |  |  |  |  |  |  |  |

Notes:
- 44: WBS Definition- / This task provides effort the preparation of any required safety documentation (e.g. extended silicon HV and LV systems, Be beampipe handling procedures, etc.) and drafts the necessary PORC's so that only final "walk-thrus" are needed as installation is completed. The task is scheduled to begin somewhat arbitrarily 1 year before the beginning of the shutdown. / HV in 2005? / Beampipe leak check procedures. (Russ to review 2004 SNEG item) / M&S BOS- / None. / Labor BOE- / Ongoing physicist and engineering effort required to assure paperwork completion in a timely maner. Rich Smith, Russ Rucniski, Bill Cooper, Lyn Bagby, Youri Orlov, Dan Marlkey, are the preferred physicsts and engineers to prepare the documentation.
- 45: WBS Definition- / This task provides effort for the preparation of the new SI Low Voltage Power Supply system and cooling interlock safety documentation and PORCS, including "walk-thrus" required for permission to operate the system. / M&S BOS- / None. / Labor BOE- / Based on RunIIa experience and considering that review/updating of existing documentation constitutes the bulk of the task, two weeks time by an electrical engineer, and physicist are required for this task. John Anderson and Lyn Bagby are the preferred personnel.
- 46: WBS Definition- / This task provides effort for the preparation of the Layer Zero Si cooling system safety documentation and PORCS, including "walk-thrus" required for permission to operate the system. / M&S BOS- / None. / Labor BOE- / Based on RunIIa experience and considering that review/updating of existing documentation constitutes the bulk of the task, two weeks time by an mechanical engineer, and physicist are required for this task. Bill Cooper and Russ Rucinski are the preferred personnel.
- 47: WBS Definition- / This task provides effort for the preparation of the Layer Zero Si dry gas system safety documentation and PORCS, including "walk-thrus" required for permission to operate the system. / M&S BOS- / None. / Labor BOE- / Based on RunIIa experience and considering that review/updating of existing documentation constitutes the bulk of the task, two weeks time by an mechanical engineer, and physicist are required for this task. Bill Cooper and Russ Rucinski are the preferred personnel.
- 48: WBS Definition- / This task provides effort for the preparation of the Layer Zero Si dry gas system safety documentation and PORCS, including "walk-thrus" required for permission to operate the system. / M&S BOS- / None. / Labor BOE- / Based on RunIIa experience and considering that review/updating of existing documentation constitutes the bulk of the task, two weeks time by an mechanical engineer, and physicist are required for this task. Bill Cooper and Youri Orlov are the preferred personnel.
- 49: WBS Definition- / This task provides effort for the preparation of the beryllium beampipe safety documentation. / M&S BOS- / None. / Labor BOE- / Based on RunIIa experience and considering that review/updating of existing documentation constitutes the bulk of the task, one week time by a physicist is required for this task. Rich Smith is the preferred personnel.
- 50: WBS Definition- / This task provides effort for the preparation of the Tevatron beampipe leak checking safety documentation. / M&S BOS- / None. / Labor BOE- / Based on RunIIa experience and considering that review/updating of existing documentation constitutes the bulk of the task, one week time by an engineer is required for this task. Russ Rucinski is the preferred personnel.
- 51: WBS Definition- / All safety and PORC documentation for RunIIb are complete.
- 52: WBS Definition- / Milestone-All infrastructure required by the silicon (cables, chiller and piping, dry gas system, HV and LV systems, installation fixtures) is complete.
- 53: WBS Definition- / This summary task opens the detector, disconnects the Tevatron beampipe, and prepares the CC-EC gaps for use by the people who will uncable and remove the H disks and install the Layer Zero silicon. Included is the erection of scaffolding and the installation of lighting, with masks to protect the CFT fibers. / M&S BOE- / NA / Labor BOE- / Run IIa experience, based on the number of people (peaks at 6 during EC opening) required to open the detector, and the reduced number (4) who can efficiently work in the CC/EC gaps at any one time to install the scaffolding. / Text8: Based on the number of people who can successfully work in the enclosed area
- 54: WBS Definition- / This task performs the required rad survey of the collision hall before general personnel access permitted. / M&S BOE- / NA / Labor BOE- / RunIIa experience where radiation survey of the collision hall was done on several occasions, forms the basis of estimate for effort.
- 55: WBS Definition- / This task opens the N muon shield clamshells in the N EMC truss, retracts the N Muon shield into the clamshells, opens EFN, disconnects the Tevatron beampipe at the N EC beampipe, removes the FPD Veto counters, supports the Tev beampipe, closes NEF, disconnects the Tevatron beampipe at the isolation valve/X/bellows near the low beta quad, removes the Tevatron beampipe spoolpiece, and reopens N EF. / M&S BOE- / NA / Labor BOE- / RunIIa experience, when the Tevatron beampipe was originally installed, forms the basis of estimate for effort (the three motions of EF alone will consume approximately three half-shifts). Two shifts per day assumed.
- 56: WBS Definition- / This task opens the S muon shield clamshells in the S EMC truss, retracts the S Muon shield into the clamshells, opens EFS, disconnects the Tevatron beampipe at the S EC beampipe, removes the FPD Veto counters, supports the Tev beampipe, closes SEF, disconnects the Tevatron beampipe at the isolation valve/X/bellows near the low beta quad, removes the Tevatron beampipe spoolpiece, and reopens S EF. / M&S BOE- / NA / Labor BOE- / RunIIa experience, when the Tevatron beampipe was originally installed, forms the basis of estimate for effort (the three motions of EF alone will consume approximately three half-shifts). Two shifts per day assumed.
- 57: WBS Definition- / This task opens the CF and the end calorimeters. / M&S BOE- / NA / Labor BOE- / RunIIa experience, where this task was done on occasion, forms the basis of estimate for effort. Six people are required (4 as observers), to ensure cables, etc. aren't damaged.
- 58: WBS Definition- / This task assays for loose beryllium oxides on beryllium beampipe before general personnel access permitted. The beampie is wiped and the coupons sent out for chemical assay. / M&S BOE- / NA / Labor BOE- / RunIIa experience where radiation survey of the collision hall was done on several occasions, forms the basis of estimate for effort. The potential for greater luminosity prior to the RunIIb shutdown makes the conclusion that the beam pipe won't be measurably radioactive less certain.
- 59: WBS Definition- / This task installs the accessways into the cathedral, and the special scaffolds in the CC/EC gaps, plus needed lighting. / M&S BOE- / NA / Labor BOE- / RunIIa experience, forms the basis of estimate for effort. Two shifts per day are assumed.
- 60: WBS definition- / Milestone-The detector is open and ready for all authorized access.
- 61: WBS Dictionary- / This summary task completes the mechanical disconnection of the Run IIa beampipe and removes it and the H-disks from the detector.
- 62: WBS Definition- / Adjust silicon cooling temperature to slightly exceed dewpoint of collision hall (~ 10C). Maintain dry gas flow to silicon enclosures and CFT gap to control local dewpoint. / M&S BOE- / NA / Labor BOE- / Estimates based on understanding of system complexity and access, plus Run2a experience with cooling system. / Text8: Run2a experience
- 63: WBS Definition- / Cut the end calorimeter beam tube flange and bellows assemblies from the inboard ends of the beam tubes passing through each end calorimeter. / M&S BOE- / NA / Labor BOE- / Estimates are derived from Run2a experience where similar preparation of the end calorimeter beam pipes was required for the Run2a silicon. Two shifts per day assumed.
- 64: WBS Definition- / Remove the scaffolds in the ECN gap, close ECN, withdraw the ECN beampipe, reopen ECN, reinstall the scaffolds in the ECN gap. / M&S BOE- / NA / Labor BOE- / Estimates are derived from Run2a experience where similar work during preparation of the end calorimeter beam pipes was required for the Run2a silicon. Two shifts per day assumed.
- 65: WBS Definition- / Disconnect coolant lines to H disks (check tritium content of small amount of coolant removed). Uncable and remove the S and N H-disks from CFT barrel 3. The low mass cables (24 per side) are uncabled and the H disks are removed from the CFT mounts, inserted in existing handling cases, and removed from the work area (the inner disks will be reinstalled after the L0 silicon is installed). / M&S BOE- / NA / Labor BOE- / Estimates are based on Run2a installation experience, reduced by considerations of the expected simpler task of removal as compared with installation. Two shifts per day assumed.
- 66: WBS Definition- / This task installs the 12 2-channel junction cards per side, and new adapter cards ( 6 on each horseshoe). The junction cards connect to the twisted pair cables that go to the adapter cards on the horseshoes. Six inner junction cards are installed all the way to the adapter cards on the horseshoes, and tested (junction card + twisted pair cable + adapter card, before proceeding with the outer ring of 6 junction cards. / The 80-conductor cables and clock cables are reconnected to the adapter cards also. / (Consider rad mon cables here?) / M&S BOE- / NA / Labor BOE- / A maximum of two people can work in each CC/EC gap at any one time. / Four junction cards/twisted pair cable/adapter card can be done per person per shift; two shifts per day assumed. Dave Butler, Denny Graham, John Fogelsong and Lyn Bagby are the preferred personnel.
- 67: WBS Definition- / This task installs the 12 2-channel junction cards per side, and new adapter cards ( 6 on each horseshoe). The junction cards connect to the twisted pair cables that go to the adapter cards on the horseshoes. Six inner junction cards are installed all the way to the adapter cards on the horseshoes, and tested (junction card + twisted pair cable + adapter card, before proceeding with the outer ring of 6 junction cards. / The 80-conductor cables and clock cables are reconnected to the adapter cards also. / (Consider rad mon cables here?) / M&S BOE- / NA / Labor BOE- / A maximum of two people can work in each CC/EC gap at any one time. / Four junction cards/twisted pair cable/adapter card can be done per person per shift; two shifts per day assumed. Dave Butler, Denny Graham, John Fogelsong and Lyn Bagby are the preferred personnel.
- 68: WBS Definition- / This task installs the "cradle" that spans the gap between ECN and the existing Si support structure. / M&S BOE- / NA / Labor BOE- / RunIIa experience, where a more complex trolley was used to install the silicon. Assistance from AMG is required. Bill Cooper and Youri Orlov are the preferred personne.
- 69: WBS Definition- / Milestone-The RunIIa silicon beam pipe and H-disks have been removed from the detector.

| ID | WBS | Task | Type | Duration | Start | Finish | Predecessors | Total slack | Free slack | Resources | Work | Cost | Text8 | Text27 | Text28 | Text1 |
| --- | --- | --- | --- | --- | --- | --- | --- | --- | --- | --- | --- | --- | --- | --- | --- | --- |
| 70 | 1.5.4.4 | **Install RunIIb L0 Silicon Detector** |  | 9d | 2005-07-18 | 2005-07-28 |  | 3d |  |  | 888h | 10,050.8 |  |  |  |  |
| 71 | 1.5.4.4.1 | Install L0 Mounts |  | 0.8w | 2005-07-18 | 2005-07-22 | 73SF | 9d | 0d | PhysicistF; GapN; GapS; SeniorMechEngF [50%]; SeniorMechTechF [200%]; Youri Orlov; Bill Cooper | 240h | 2,597.6 | 2 days of measurements that need verification | FNAL | OP |  |
| 72 | 1.5.4.4.2 | Transport silicon detector to DAB |  | 0.2w | 2005-07-21 | 2005-07-21 | 4 | 0d |  | PhysicistF [200%]; SeniorMechTechF [300%] | 40h | 689.4 | Run2a experience | FNAL | OP |  |
| 73 | 1.5.4.4.3 | Install Silicon Detector |  | 0.6w | 2005-07-22 | 2005-07-26 | 72 | 0d |  | PhysicistF; GapN [200%]; GapS [200%]; Cathedral [200%]; SeniorMechEngF; SeniorMechTechF [400%]; Bill Cooper; Youri Orlov | 336h | 3,896.4 | Run2a experience | FNAL | OP |  |
| 74 | 1.5.4.4.4 | Remove RunIIa beryllium beam pipe |  | 0.2w | 2005-07-26 | 2005-07-26 | 73FF | 0d |  | SeniorMechTechF [400%]; SeniorMechEngF [50%]; PhysicistF; GapS [200%]; Bill Cooper; Cathedral [200%]; Russ Rucinski [50%] | 88h | 1,109 |  | FNAL | OP |  |
| 75 | 1.5.4.4.5 | Connect inner SS beam pipe spools to beryllium pipe |  | 0.4w | 2005-07-27 | 2005-07-28 | 74 | 0d |  | PhysicistF; GapN [200%]; GapS [200%]; SeniorMechTechF [200%]; WelderF; Bill Cooper; Russ Rucinski [50%]; SeniorMechEngF [50%]; Cathedral [150%] | 184h | 1,758.4 |  | FNAL | OP |  |
| 76 | 1.5.4.4.6 | L0 Silicon Detector Installed In RunIIa Silicon | milestone | 0w | 2005-07-28 | 2005-07-28 | 75 | 115d |  |  |  |  |  |  |  |  |
| 77 | 1.5.4.5 | **Cable L0 Silicon, Reconnect Cooling System** |  | 6d | 2005-07-29 | 2005-08-05 |  | 0d |  |  | 640h | 6,464.2 |  |  |  |  |
| 78 | 1.5.4.5.1 | Connect Silicon Digital Cables to the Junction Cards |  | 0.4w | 2005-07-29 | 2005-08-01 | 75 | 0d |  | GapN [200%]; GapS [200%]; SeniorMechTechF [400%]; PhysicistF [400%]; Cathedral [200%]; Dave Butler; Ken Schulz | 256h | 1,838.4 |  | FNAL | OP |  |
| 79 | 1.5.4.5.2 | Reinstall inner H-disks |  | 0.4w | 2005-08-02 | 2005-08-03 | 78 | 0d |  | PhysicistF; GapN [200%]; GapS [200%]; SeniorMechTechF [400%]; SeniorMechEngF; John Fogelsong; Dave Butler; Dennis Graham; Lyn Bagby | 224h | 2,597.6 |  | FNAL | OP | 9/1 |
| 80 | 1.5.4.5.3 | Make up L0 Cooling and Dry Gas Connections |  | 0.2w | 2005-08-04 | 2005-08-04 | 62, 79 | 0d |  | PhysicistF [50%]; GapN [50%]; GapS [50%]; SeniorMechTechF [200%]; Dennis Graham; Dave Butler; Bill Cooper [50%] | 48h | 459.6 |  | FNAL | OP |  |
| 81 | 1.5.4.5.4 | Load EC beampipes into the EC |  | 0.2w | 2005-08-05 | 2005-08-05 | 80 | 109d |  | SeniorMechTechF [400%]; GapN; GapS; Russ Rucinski [50%]; SeniorMechEngF [50%] | 56h | 1,109 |  |  | OP |  |
| 82 | 1.5.4.5.5 | Seal dry gas volume |  | 0.2w | 2005-08-05 | 2005-08-05 | 80 | 0d |  | SeniorMechTechF [200%]; GapN; GapS; Dave Butler; Dennis Graham; Bill Cooper [50%]; PhysicistF [50%] | 56h | 459.6 |  | FNAL | OP |  |
| 83 | 1.5.4.5.6 | L0 Silicon Cable-up Complete | milestone | 0w | 2005-08-05 | 2005-08-05 | 82 | 109d |  |  |  |  |  |  |  |  |
| 84 | 1.5.4.6 | **Reconnect Tev Beam Tube** |  | 6d | 2005-08-05 | 2005-08-12 |  | 1d |  |  | 348h | 6,537.9 |  |  |  |  |
| 85 | 1.5.4.6.1 | Begin Silicon Cooldown |  | 0.2w | 2005-08-05 | 2005-08-05 | 80, 10, 9, 12, 13, 14, 16 | 109d |  | PhysicistF; SeniorMechTechF; SeniorElecEngF [50%]; Bill Cooper; John Fogelsong [50%]; CompProfU [50%]; Dan Markely [50%] | 40h | 418.4 |  | FNAL | OP |  |
| 86 | 1.5.4.6.2 | Reconnect Beam Pipes, Leakcheck |  | 1w | 2005-08-08 | 2005-08-12 | 82 | 0d |  | PhysicistF [10%]; WelderF [50%]; GapN [50%]; GapS [50%]; Cathedral; SeniorMechEngF [50%]; SeniorMechTechF [400%]; Russ Rucinski [50%]; Bill Cooper [10%] | 308h | 6,119.5 | Run2a experience | FNAL | OP |  |
| 87 | 1.5.4.6.3 | Tevatron Beam Pipe Connected | milestone | 0w | 2005-08-12 | 2005-08-12 | 86 | 104d |  |  |  |  |  |  |  |  |
| 88 | 1.5.4.7 | **Technical commissioning of detector** |  | 5d | 2005-08-15 | 2005-08-19 |  | 0d |  |  | 640h |  | Run2a experience |  |  |  |
| 89 | 1.5.4.7.1 | Demonstrate Full Operability of all Channels from Control Room |  | 1w | 2005-08-15 | 2005-08-19 | 86 | 0d |  | PhysicistF [400%]; PhysicistU [400%]; GapS [200%]; Cathedral [600%] | 640h |  |  | FNAL | OP |  |
| 90 | 1.5.4.8 | Silicon Ready for Resumption of Tevatron Operation | milestone | 0w | 2005-08-19 | 2005-08-19 | 89, 86 | 99d | 0d | PhysicistF [400%]; PhysicistU [400%]; GapN [200%]; GapS [200%]; Cathedral [400%] |  |  |  |  |  |  |
| 91 | 1.5.4.9 | **Commission Online Readout Software, Close Detector** |  | 14d | 2005-08-22 | 2005-09-09 |  | 0d |  |  | 608h | 5,195.2 |  |  |  |  |
| 92 | 1.5.4.9.1 | Verify functionality of all SMT software |  | 2w | 2005-08-22 | 2005-09-02 | 89 | 0d |  | PhysicistU [200%]; PhysicistF [200%] | 320h |  |  | FNAL | OP |  |
| 93 | 1.5.4.9.2 | Close calorimeter and muon system, Survey Detector |  | 0.8w | 2005-09-06 | 2005-09-09 | 92 | 0d |  | PhysicistF [200%]; SeniorMechTechF [400%]; SeniorMechEngF; Surveyors [200%] | 288h | 5,195.2 |  | FNAL | OP |  |
| 94 | 1.5.4.10 | Silicon System Ready for Physics Commissioning | milestone | 0w | 2005-09-09 | 2005-09-09 | 93, 92 | 0d |  |  |  |  |  |  |  |  |

Notes:
- 70: WBS Dictionary- / This summary task installs the Layer Zero silicon mounts, transports the silicon from SiDet to DAB and installs it in CFT, removes the RunIIa Be beampipe, and installs the temperture monitoring system and cooling systems for the silicon.
- 71: WBS Definition- / This task provides for the installation of the Layer Zero mounts on the existing SI support cylinder. / M&S BOE- / NA / Labor BOE- / Estimates based on use of manual precision gauges, etc, in tight confined space, with verification done in as real-time as possible. Bill Cooper and Youri Orlov are the preferred personnel.
- 72: WBS Definition- / Transport silicon from SiDet to D0. / M&S BOE- / NA / Labor BOE- / Estimate based on Run2a experience, for which operation is essentially identical; included is effort required to establish and maintain gas purge and weather cover during move, load detector into transport vehicle at SiDet, and unload detector at DAB, all the while maintaining specified low shock loadings and accelerations.
- 73: WBS Definition- / Move L0 silicon from the D0 high bay into position within Run IIa silicon. In detail, the L0 is inserted in ECN, pushed S until it reaches the installation cradle in the ECN gap, and attached to the RunIIa Be beampipe. The assembly is pushed S until the Si is in place and the RunIIa Be beampipe is in ECS. / M&S BOE- / NA / Labor BOE- / Estimates based on Run2a experience, but with simpler logistics required. Individuals that will be involved: Bill Cooper, Youri Orlov, Kurt Krempetz; Dave Butler, Denny Graham, Del Miller.
- 74: WBS Definition- / The pipe is removed via the beampipe through the south end calorimeter. Both ECS and EFS are closed to facilitate the removal. Upon removal from the detector the beampipe is wrapped in plastic sheeting, labeled with appropriate ESH tag(s), establish a purge, and store at DAB. EFS and ECS are reopened when job is done. / M&S BOE- / NA / Labor BOE- / Estimates derived from Run2a experience. Additional engineers/physicists are "drafted" as necessary when ECS is closed/opened.
- 75: WBS Definition- / Connect stainless steel spool pieces to beryllium beam pipe ends. Outer ends of spool pieces are supported with fixturing until bellows segments are installed and connected to EC beampipes. Leak check assembly. / M&S BOE- / NA / Labor BOE- / Estimates based on Run2a experience. Two shifts per day assumed.
- 76: WBS Definition- / Milestone-The detector is fully installed in the CFT and connected to the dry gas and cooling systems, whose proper operation have been verified. It is ready for cabling and electronic commissioning.
- 77: WBS Definition- / This summary task installs the new adapter cards on the N and S horseshoes.
- 78: WBS Definition- / This task connect the 48 digital cables from the silicon tracker to the junction cards and tested (full readout chain) before proceeding. Each junction card is fastened in place when done. / M&S BOE- / NA / Labor BOE- / A maximum of two people can work in each CC/EC gap at any one time. Ron Lipton, Bill Cooper, Lyn Bagby and Andrei Numerotski are the preferred physicits. Dave Butler, Chris Tolian, Ken Schultz, and Bert Gonzalez are the preferred techs.
- 79: WBS Definition- / This task reinstalls the inner H-disks to the CFT mounts, and connects the low mass cables to them. The outer ends of the low-mass cables are re-routed at the horseshoe as required, and tested from the adapter cards forward to the silicon. / M&S BOE- / NA / Labor BOE- / Estimates based on Run2a H-disk installation, but reduced in consideration of the fact that only half of the H-disks will be reinstalled. Dave Butler, Denny Graham, Lyn Bagby, and John Fogelsong are the preferred personnel.
- 80: WBS Definition- / Make and test the connections from the cooling and dry gas system to the new L0 silicon manifolds. / M&S BOE- / NA / Labor BOE- / The L0 silicon cooling supply and return lines connect to "tees" added to the existing silicon cooling lines. The dry gas supply line connects to spargers on each end of the detector. Time is allowed for the making of the connections and leak checking them. Dave Butler and Denny Graham are the preferred personnel.
- 81: WBS Definition- / This task closes the EC and EF, and inserts the EC beampipes into the EC. The EC and EF are reopened when the pipes are in place. / M&S BOE- / NA / Labor BOE- / This task is done on the second shift when delicate work in the gap is not being done.
- 82: WBS Definition- / This task closes the dry gas volume around the silicon. / M&S BOE- / NA / Labor BOE- / The access holes, etc. are closed/sealed and the dry gas volume made hermetic. Two shifts per day are possible. Dave Butler, Denny Graham, and Bill Cooper are the preferred personnel.
- 84: WBS Definition- / This summary task makes and leak checks the connections from the beryllium beam tube to the Tevatron beam tubes passing through the end calorimeters.
- 85: WBS Definition- / Rinstall gas enclosure membranes and operate the cooling system and verify temperature calibration of L0 RTD's. / M&S BOE- / NA / Labor BOE- / Effort is allowed for verification of proper operation of entire cooling system.
- 86: WBS Definition- / Weld bellows on EC beampipes and make and leak check all beampipe connections. Leak checking requires that other activities in the gaps be suspended, the scaffolds removed, and the EC's and EF's be closed and opened to expose pipe connections. / M&S BOE- / NA / Labor BOE- / Effort is required to weld EC bellows and flanges onto EC beampipes before connecting the beryllium beam tube. All connections must be leak checked, so time and effort are allowed for manipulation of the EC/EF. Physicists and technicians are "drafted" as necessary when the EC are closed/opened, and this work can be done on the second shift if desired.
- 87: WBS Definition- / Milestone-The RunIIb beryllium beam tube is mated to the beam tubes in the end calorimeters, and all connections leak checked. The Tevatron beampipe is once again continuous through D0.
- 88: WBS Definition- / This summary element provides for checking the integrity, quadrant by quadrant, of the silicon readout chain. Tested are the digital and high-mass cables, the HDI, the junction cards, the adapter cards, the silicon sensors and SVX preamps, the bias voltage system, and the interface board cards. This task can assume the full functionality of the trigger framework (master clock, serial command link, etc.).
- 89: WBS Definition- / All of the electrical connections for the silicon are checked in this task. Testing proceeds on a quadrant-by-quadrant basis. / M&S BOE- / NA / Labor BOE- / Run2a experience forms the basis of the estimates for labor. Some occupancy of the gaps is assumed. Two shifts per day assumed.
- 90: WBS Definition- / Milestone-The Silicon installation is completed to the point that access to the collision hall is no longer needed on a continuous basis. Further commissioning can proceed with Tevatron operations underway if needed.
- 91: WBS Definition- / This task provides for the testing of the Online Readout Software, which includesthe unpacking software which facilitates the data transfer from electronic coordinates to physics coordinates, and the unpacking software for L3 and offline analysis. The majority of this software is taken from Run IIa and modified for use at SiDet for the 1% and 10% silicon test stands, prior to the start of the Run IIb shutdown. / The elapsed times for the tasks assume immediate access to the detector to resolve mapping, etc. If the Tevatron has resumed operations, the task durations dialate.
- 92: WBS Definition- / This task verifies the functionality of the monitoring and downloading software of all silicon crates, / data unpacking software (electronics to physics addressing), L3/offline software (Examine). / M&S BOE- / NA / Labor BOE- / This effort is primarily based on verifying the proper function of well-understood modifications made to the Run IIa software.
- 93: WBS Definition- / Remove scaffolding, close EC's, and close CF and EF toroids to detector centerbeam. Provide time for survey of EC's, CF, and EF. Task can be delayed so that it occurs sometime during Tevatron startup. / M&S BOE- / NA / Labor BOE- / Run IIa experience, including time to check clearance between central and end calorimeters for cable system, verify all technical operation aspects of the silicon system after final closeup of the end calorimeters. Two shifts per day assumed.
- 94: WBS Definition- / Milestone-The RunIIb silicon system has been installed, technically commisioned, and is ready for physics commissioning.

| ID | WBS | Task | Type | Duration | Start | Finish | Predecessors | Total slack | Free slack | Constraint | Resources | Work | Cost | Text27 | Text28 | Text1 | Text6 |
| --- | --- | --- | --- | --- | --- | --- | --- | --- | --- | --- | --- | --- | --- | --- | --- | --- | --- |
| 95 | 1.5.5 | **Run IIb Trigger Installation** |  | 452d | 2004-01-05 | 2005-10-20 |  | 56d |  |  |  | 36406h | 463,890.1 |  |  |  |  |
| 96 | 1.5.5.1 | **Prepare Infrastructure at DAB** |  | 349d | 2004-01-05 | 2005-05-26 |  | 159d |  |  |  | 11816h | 153,731.7 |  |  |  |  |
| 97 | 1.5.5.1.1 | Infrastructure Engineering Design and Oversight |  | 32w | 2004-01-05 | 2004-08-18 |  | 348d |  |  | SeniorElecEngF; SeniorElecEngU [200%] | 3840h | 60,352 | FNAL | OP |  |  |
| 98 | 1.5.5.1.2 | Prepare new L1 Cal Racks |  | 12w | 2004-01-05 | 2004-03-29 | 7SS | 345d | 289d |  | MandS; PhysicistU [50%]; SeniorElecEngF [10%]; SeniorElecTechF [300%]; John Anderson [10%]; Alan Stone [50%]; Tom Regan [25%] | 2136h | 82,963.2 | FNAL | OP |  |  |
| 99 | 1.5.5.1.3 | Preliminary commission of Cal Trig Elements |  | 19w | 2005-01-12 | 2005-05-26 | 110FF | 159d | 0d |  | PhysicistU [400%] | 3040h |  | BU | DOE-base |  |  |
| 100 | 1.5.5.1.4 | Develop L1 Cal Commissioning Software? |  | 1w | 2004-01-05 | 2004-01-09 | 7SS | 503d |  |  |  |  |  |  |  |  |  |
| 101 | 1.5.5.1.5 | Plan new cable plant: UIC |  | 8w | 2004-01-05 | 2004-03-01 | 7SS | 355d | 309d |  | PhysicistU [50%]; Alan Stone [50%] | 320h |  | UIC | DOE-base |  |  |
| 102 | 1.5.5.1.6 | Modify MCH Racks for L1 Cal/Track Match |  | 1w | 2004-08-23 | 2004-08-27 |  | 316d | 0d | start no earlier than 2004-08-23 | SeniorMechTechF [50%]; PhysicistF [50%] | 40h | 574.5 | FNAL | OP |  |  |
| 103 | 1.5.5.1.7 | Install L1CTM VME crates and power supplies |  | 1w | 2004-08-30 | 2004-09-03 | 102 | 316d | 30d |  | PhysicistU | 40h |  | AZ | DOE-base |  |  |
| 104 | 1.5.5.1.8 | Install L1CTM splitter crate and power supply |  | 4w | 2004-08-23 | 2004-09-20 | 7SS | 286d | 0d | start no earlier than 2004-08-23 | PhysicistU [50%] | 80h |  | AZ | DOE-base |  |  |
| 105 | 1.5.5.1.9 | Install L1CTM rack services |  | 4w | 2004-09-21 | 2004-10-18 | 104 | 286d | 0d |  | SeniorMechTechF [50%]; SeniorElecEngF [50%] | 160h | 6,070 | FNAL | OP |  |  |
| 106 | 1.5.5.1.10 | Install L1 CTT/CTMcables |  | 4w | 2004-10-19 | 2004-11-15 | 103, 105 | 286d | 165d |  | PhysicistU; SeniorElecEngF [50%] | 240h | 3,772 | AZ | DOE-base |  |  |
| 107 | 1.5.5.1.12 | Develop Trigsim Software |  | 16w | 2004-08-23 | 2004-12-15 | 3FS-42w | 266d | 107d |  | PhysicistF [150%]; PhysicistU [150%] | 1920h |  |  |  |  |  |
| 108 | 1.5.5.1.11 | Trigger Infrastructure Prepared | milestone | 0w | 2005-05-26 | 2005-05-26 | 98, 99, 101, 102, 103, 104, 105, 107 | 159d |  |  |  |  |  |  |  |  |  |
| 109 | 1.5.5.2 | **Level 1 Calorimeter Trigger** |  | 260d | 2004-09-28 | 2005-10-13 |  | 61d |  |  |  | 19260h | 285,493.9 |  |  |  |  |
| 110 | 1.5.5.2.1 | L1 Cal Trigger Production And Testing Complete | milestone | 0w | 2005-05-26 | 2005-05-26 |  | 36d | 0d | start no earlier than 2005-05-26 |  |  |  |  |  |  |  |
| 111 | 1.5.5.2.2 | **Installation And Technical Commissioning** |  | 260d | 2004-09-28 | 2005-10-13 |  | 61d |  |  |  | 19260h | 285,493.9 |  |  |  |  |
| 112 | 1.5.5.2.2.1 | Engineering and Computer Professional Support - FNAL |  | 52w | 2004-09-28 | 2005-10-13 | 177FF-1w | 61d |  |  | SeniorElecEngF; CompProfF [200%]; Jamieson Olson | 8320h | 256,152 | FNAL | OP | 9/1 |  |
| 113 | 1.5.5.2.2.2 | Engineering and Computer Professional Support - U |  | 52w | 2004-09-28 | 2005-10-13 | 177FF-1w | 61d |  |  | SeniorElecEngU [200%]; Dan Edmunds; Phillipe Laurens | 8320h |  | MSU | OP | 9/1 |  |
| 114 | 1.5.5.2.2.3 | Complete System Integration Tests on Sidewalk |  | 4w | 2005-05-26 | 2005-06-23 | 110 | 36d | 18d |  | PhysicistU [400%] | 640h |  | BU | DOE-base |  |  |
| 115 | 1.5.5.2.2.4 | Remove old racks |  | 1w | 2005-06-29 | 2005-07-06 | 3 | 18d | 0d |  | SeniorElecEngF [10%]; SeniorElecTechF; Tom Regan; John Anderson [10%]; SeniorMechTechF [600%] | 328h | 8,282.6 | FNAL | OP |  |  |
| 116 | 1.5.5.2.2.5 | Redress cables |  | 2w | 2005-07-07 | 2005-07-20 | 115, 101 | 18d | 0d |  | SeniorMechTechF [150%]; SeniorElecEngF [50%]; SeniorElecTechF [150%]; Tom Regan | 360h | 8,933 | UIC | DOE-base |  |  |
| 117 | 1.5.5.2.2.6 | Install new racks in MCH |  | 0.6w | 2005-07-21 | 2005-07-25 | 98, 116, 114 | 18d | 0d |  | SeniorMechTechF [400%]; SeniorMechEngF [25%]; Tom Regan; Russ Rucinski [25%] | 132h | 3,042.3 | FNAL | OP |  |  |
| 118 | 1.5.5.2.2.7 | Connect new rack services |  | 1w | 2005-07-26 | 2005-08-01 | 117 | 18d | 0d |  | MandS [250000%]; SeniorElecTechF [200%]; Tom Regan; SeniorMechTechF [200%] | 200h | 7,198 | FNAL | OP |  |  |
| 119 | 1.5.5.2.2.8 | Connect BLS & Intermediate cables |  | 1w | 2005-08-02 | 2005-08-08 | 118 | 18d | 0d |  | PhysicistU [600%]; SeniorElecEngF; Alan Stone | 320h | 1,886 | MSU | DOE-base |  |  |
| 120 | 1.5.5.2.2.9 | Technical commissioning in MCH1 |  | 4w | 2005-08-09 | 2005-09-06 | 119, 110 | 18d | 0d |  | PhysicistU [400%] | 640h |  | MSU | DOE-base |  | 1.2.1.4.1(0.1) |
| 121 | 1.5.5.2.2.10 | Level 1 Calorimeter Trigger Installed & Technical Commissioing Complete | milestone | 0w | 2005-09-06 | 2005-09-06 | 120 | 63d | 27d |  |  |  |  |  |  |  |  |

Notes:
- 95: WBS Definition- / The Run IIb trigger upgrade includes upgrades to three systems - the Level 1 calorimeter trigger, a calorimeter cluster track match at Level 1, and the Level 1 central track trigger, as well as upgrades to the Level 2 beta processors and the Level 2 Silicon Track Trigger. This summary WBS element includes the effort required to install and initially commission these trigger upgrades.
- 96: WBS Definition- / This summary task includes activities that must take place to ensure that all infrastructure components required for the Run IIb trigger (Cal L1 racks, Cal BLS cables, L1 Cal/Track Match crates, boards, and cables) are in hand prior to shutdown.
- 97: WBS Definition- / This task provides for the support of three engineers full time for oversight, consultation and design tasks during trigger installation effort. / M&S BOE- / NA / Labor BOE- / D. Edmunds, Phillipe Laurens, Jamieson Olson.
- 98: WBS Definition- / This involves outfitting the 5 new L1 Cal racks with water cooling, air blowers, safety systems (including safety reviews), power supplies, voltage monitoring, monitoring and alarm software, AC and DC power. This work must be done before the racks are required in the test area in DAB1. / M&S BOE- / Racks and equipment to be installed as described above: $7500 per rack, R.Hance 3/12/2002 estimate / Labor BOE- / Detailed estimate by D. Edmunds of labor involved (see supporting documents). Assumes 6 months of preparatory work by an electrical engineer (plus the "cable czar" half time) and a physicist + 1 week of cabling, testing, etc. per rack for a technician, and part-time oversight by an electrical engineer.
- 99: WBS Definition- / This task provides for the installation of Cal Trig components (ADFs, TABs and GABs and inter-card cabling as they become available from the Upgrade Project) and ultimately the entire Cal Trig system for testing, and for development and debugging of control software, in the DAB1 area before the shutdown. The upgrade project and RunIIa will provide data collection software (SDAQ), downloading and controls, and online monitoring tools (EPICS) for use by this task. / M&S BOE- / NA / Labor BOE- / Two university physicists working full time are required for this task. Task duration extends until last hardware component of L1 Cal Trig is installed at the sidewalk test area.
- 100: WBS Definition- / M&S BOE- / Labor BOE-
- 101: WBS Definition- / Plan routing of BLS cables to ADF. This will involve verifying that the plan is feasible in the Dzero Moving Counting House. This item represents the UIC part of the effort. / M&S BOE- / NA / Labor BOE- / Advising by MSU engineer as needed, plus oversight by "cable czar" electrical engineer.
- 102: WBS definition - / This task to be done during 2004 shutdown. / Mechanical modifications to extend rack depth if necessary to accomodate cal-trk VME crate in MCH1. / M&S BOE - / $500 M&S assiciated with this task. / Labor BOE - / Run2a experience modifying racks in collision hall for Level 1 muon crates.
- 103: WBS Definition- / Install cal-trk crate and power supplies in moveable counting house in existing rack. / Labor BOE- / Run2a muon Level 1 experience with installation of similar VME crates and power supplies. Assumes two people at 50% FTE each for one week. / M&S BOE / NA
- 104: WBS definition - / Install a single crate and its power supply on the platorm (in existing "bare" rack) to contain the serial link splitters which are used as repeaters to drive the signals from the L1CTT to the cal-trk. Needs to be done when there is access to the collision hall, but can be done in advance of the end of run2a since it does not displace any existing equipment. / Labor BOE - / Experience with installation of splitter crates for run 2a, plus extra time allowed for installation of new electronics on the detector platform. / M&S BOE - / NA
- 105: WBS definition - / Install all necessary services (RMI, power, cooling water) in the rack on the platform that houses the L1CTM crate. Needs to be done when there is access to the collision hall, but can be done in advance of the end of run2a since it does not displace any existing equipment. / Labor BOE - / Experience with installation of rack services throughout D0. / M&S BOE - / $500 M&S associated with this task.
- 106: WBS Definition- / Run cables between the CTT and the cal-track match, and between cal L1 and cal-track match. CTT cable installation needs to be done when there is access to the collision hall, but can be done in advance of the end of run2a since it does not displace any existing equipment. Includes testing and labeling of cables. / Labor BOE- / Run2a muon Level 1 experience installing cables from muon front ends and CTT to the Level 1 muon triggers. Assumes two people at 50% FTE each. Effort added to test and label cables (cable czar).
- 107: WBS Definition- / Develop L2STT, Ratetool, Trigsimcert software / M&S BOE- / Labor BOE-
- 108: WBS Definition- / Milestone- Trigger Infrastructure tasks completed. Included are: completion of L1 Cal Trigger racks for MCH1; preliminary commissioning of all Cal Trig elements in test stand on the DAB1 sidewalk; the planning for the rerouting of the Cal BLS cables in MCH1; the iinstallation of the Cal-Trk VME crate and the Cal Track Match Crate and power supplies in MCH1; the CalTrackMatch splitter crate, rack, and rack services,on the platform; and install the MTCxx and MTCM electronics in the crate;
- 109: WBS Definition- / This summary element covers the Level 1 calorimeter trigger modifications. It includes development and procurement of ADC/digital filter boards (ADF), development and procurement of trigger-algorithm boards (TAB), the provision of output signals to facilitate a match between calorimeter towers and tracks, and procurement and improvements in associated readout crates, power supplies, cabling, and controls hardware. / Text9: This summary element covers the Level 1 calorimeter trigger modifications. It includes development and procurement of ADC/digital filter boards (ADF), development and procurement of trigger-algorithm boards (TAB), the provision of output signals to facil
- 110: WBS Definition- / Milestone- All L1 Cal components produced or procured. Full functionality of custom boards (ADF, TAB, GAB) bench tested at institutes where they were developed. Tests consist of using simulated inputs to verify that all the outputs of the board are as expected and that bit error rates are acceptable - corresponding to approximately 1 fatal error per day at nominal data volumes. Milestone is achieved when the number of boards required in the system (80 ADFs, 8 TABs and 1 GAB) have passed the bench tests above.
- 111: WBS Definition- / This summary task describes the installation of the new calorimeter trigger in the DZero moveable counting house.
- 112: WBS Definition- / This task provides for the support of an electrical engineer (Jamieson Olson) plus two computing professionals full time for oversight, consultation and testing/monitoring software tasks during trigger installation effort. / M&S BOE- / NA / Labor BOE- / Run IIa experience forms the basis of this estimate.
- 113: WBS Definition- / This task provides for the support of two university engineers (D. Edmunds, Phillipe Laurens) full time for oversight, consultation and testing/monitoring tasks during trigger installation effort. / M&S BOE- / NA / Labor BOE- / RunIIa forms the basis of this estimate.
- 114: WBS Definition- / This task completes the integration tests on the sidewalk of the completed L1Cal Trigger system. It extends from the installation of the last ADF up to the beginning of the shutdown. / M&S BOE- / NA / Labor BOE- / Estimated by people who built existing cal L1. Two shifs per day assumed.
- 115: WBS Definition- / Decable present BLS cables from Cal Trig Racks (plus remove rack to rack internal cables, cables in the tray above the racks, and cables from the racks to the cable tray behind the racks), then remove 13 current L1 Cal racks, air blowers and ducts, power boxes and cooling manifolds. Move the VESDA fire monitor to new location. / M&S BOE- / NA / Labor BOE- / Detailed estimate by D. Edmunds of labor involved (see supporting documents): 6 hours per rack for decabling, 6 hours to remove a rack, + 80 hours for air, power, etc. disconnection for an electrical tech = 236 hrs. Because of safety issues, work should be supervised at the 50% level by a mechanical engineer and an electrical engineer. Two shifts per day assumed. / Text9: remove the 10 electronics racks which contain the old L1 calorimeter trigger
- 116: WBS Definition- / Unbundle and reroute all 400 BLS cable ribbons so they will fit up to the new patch panels installed in MCH1. Test each cable after it is installed. / M&S BOE- / NA / Labor BOE- / Detailed estimate by D. Edmunds of labor involved (see supporting documents). Assume 3 hours per ribbon, jointly by an electrical and a mechanical tech. 600 hours total. Add supervision by electrical engineer cable czar at 50% level. Two shifts per day assumed. / Text9: redress the BLS cables to be in the correct sequence to plug into the new ADF cards
- 117: WBS Definition- / This task involves moving the five assembled Cal Trig racks into MCH-1. / M&S BOE- / NA / Labor BOE- / Detailed estimate by D. Edmunds of labor involved (see supporting documents). Assumes 2 technicians can move one rack into MCH1 and fasten it to its neighbor in one day, plus full time supervision by an engineer. Two shifts per day assumed. / Text9: install standard racks
- 118: WBS Definition- / Make power and water connections to new racks when they are in place. Involves modification of available wall power from 208 V to 120 V. / M&S BOE- / Depending on the final design of the Cal Trig system, it may be necessary to add power disconnect contactors, and water distribution headers to the existing systems in MCH1. $2500 is included for these modifications. / Labor BOE- / Detailed estimate by D. Edmunds of labor involved (see supporting documents). Assumes 80 hours each for a mechanical and electrical tech. Two shifts per day assumed. / Text9: connect power, cooling, rack monitoring, safety systems
- 119: WBS Definition- / Conect BLS cables from patch panels to new racks, and intermediate cables ADF to TABs. / M&S BOE- / NA / Labor BOE- / Taken from cabling of the L2muon trigger system. Multiplied by 4 due to increased cable count and complexity, 6 physicist weeks total. / Text9: install cards into crates and cable inputs and outputs
- 120: WBS Definition- / Verify the proper functioning (timing, verification of outputs and decisions) in the itegrated trigger system with pulser runs, cosmic rays, etc. Because all racks have been operated in the DAB1 test area, possible malfunction due to the relocation to the MCH1 einvironment is not likely. Operation with Cal data (cosmics, pulsers) may reveal problems that will require diagnosis and remediation. / M&S BOE- / NA / Labor BOE- / Estimated by people who built existing cal L1. / Text9: milestone
- 121: WBS Definition- / Milestone-The level 1 calorimeter trigger has been installed and technically commissioned, so that it is ready for beam in the detector.

| ID | WBS | Task | Type | Duration | Start | Finish | Predecessors | Total slack | Free slack | Constraint | Resources | Work | Cost | Text27 | Text28 | Text8 |
| --- | --- | --- | --- | --- | --- | --- | --- | --- | --- | --- | --- | --- | --- | --- | --- | --- |
| 122 | 1.5.5.3 | **Level 1 Calorimeter Track Matching** |  | 106d | 2005-05-16 | 2005-10-13 |  | 36d |  |  |  | 760h | 1,886 |  |  |  |
| 123 | 1.5.5.3.1 | L1 Cal/Track Match Production and Testing Completed | milestone | 0w | 2005-05-16 | 2005-05-16 |  | 87d | 0d | start no earlier than 2005-05-16 |  |  |  |  |  |  |
| 124 | 1.5.5.3.2 | **Installation And Technical Commissioning** |  | 20d | 2005-05-16 | 2005-06-13 |  | 87d |  |  |  | 240h | 1,886 |  |  |  |
| 125 | 1.5.5.3.2.1 | Hook up L1 CTM electronics |  | 4w | 2005-05-16 | 2005-06-13 | 123 | 87d | 0d |  | PhysicistF; SeniorElecEngF [25%]; Jamieson Olson [25%] | 240h | 1,886 |  |  |  |
| 126 | 1.5.5.3.2.2 | L1 Cal/Track Match Installed | milestone | 0w | 2005-06-13 | 2005-06-13 | 125 | 87d | 0d |  |  |  |  |  |  |  |
| 127 | 1.5.5.3.3 | **L1 Cal/Trk Match Technical Commissioning** |  | 86d | 2005-06-14 | 2005-10-13 |  | 36d |  |  |  | 520h |  |  |  |  |
| 128 | 1.5.5.3.3.1 | Debug timing and trigger signals from the TFW |  | 2w | 2005-06-14 | 2005-06-27 | 126 | 87d | 51d |  | PhysicistU [200%] | 160h |  | AZ |  |  |
| 129 | 1.5.5.3.3.2 | Debug input from all sources |  | 2w | 2005-09-09 | 2005-09-22 | 119, 128, 110, 139FS-1w | 36d | 0d |  | PhysicistU [200%] | 160h |  | AZ | DOE-base |  |
| 130 | 1.5.5.3.3.3 | Debug CTM decision to TFW |  | 1w | 2005-09-23 | 2005-09-29 | 129 | 36d | 0d |  | PhysicistU | 40h |  | AZ | DOE-base |  |
| 131 | 1.5.5.3.3.4 | Establish L2, L3 readout |  | 2w | 2005-09-30 | 2005-10-13 | 130 | 36d | 0d |  | PhysicistU [200%] | 160h |  | AZ | DOE-base |  |
| 132 | 1.5.5.3.3.5 | Level 1 Cal/Track Match Technical Commissioning Complete | milestone | 0w | 2005-10-13 | 2005-10-13 | 131 | 36d | 0d |  |  |  |  |  |  |  |
| 133 | 1.5.5.4 | **Level 1 Tracking** |  | 72d | 2005-07-05 | 2005-10-13 |  | 38d |  |  |  | 3280h | 18,860 |  |  | starting march 1st |
| 134 | 1.5.5.4.1 | L1 Central Track Trigger Production And Testing Complete | milestone | 0w | 2005-07-05 | 2005-07-05 |  | 38d | 2d | start no earlier than 2005-07-05 |  |  |  |  |  |  |
| 135 | 1.5.5.4.2 | **Installation And Technical Commissioning** |  | 50d | 2005-07-07 | 2005-09-15 |  | 36d |  |  |  | 3280h | 18,860 |  |  |  |
| 136 | 1.5.5.4.2.1 | **Fermilab Contribution** |  | 50d | 2005-07-07 | 2005-09-15 |  | 36d |  |  |  | 1920h | 18,860 |  |  |  |
| 137 | 1.5.5.4.2.1.1 | Install DFEA boards |  | 2w | 2005-07-07 | 2005-07-20 | 134, 57, 3 | 36d | 0d |  | PhysicistF [50%]; SeniorElecEngF; Stefan Grunendahl [50%]; Steve Linn [50%]; Stefano Rapisarda; PhysicistU [50%] | 320h | 3,772 | FNAL | OP |  |
| 138 | 1.5.5.4.2.1.2 | Debug all Inputs |  | 4w | 2005-07-21 | 2005-08-17 | 137, 3FF+2d | 36d | 0d |  | PhysicistF; SeniorElecEngF; Stefano Rapisarda; Stefan Grunendahl; Steve Linn; PhysicistU | 960h | 7,544 | FNAL | OP |  |
| 139 | 1.5.5.4.2.1.3 | Verify Outputs |  | 4w | 2005-08-18 | 2005-09-15 | 138 | 36d | 0d |  | PhysicistF; SeniorElecEngF; Stefan Grunendahl; Stefano Rapisarda | 640h | 7,544 | FNAL | OP |  |
| 140 | 1.5.5.4.2.2 | **Boston U Contribution** |  | 50d | 2005-07-07 | 2005-09-15 |  | 81d |  |  |  | 400h |  |  |  |  |
| 141 | 1.5.5.4.2.2.1 | Install DFEA boards |  | 2w | 2005-07-07 | 2005-07-20 | 134, 57, 3 | 121d |  |  | PhysicistU | 80h |  | BU | DOE-base |  |
| 142 | 1.5.5.4.2.2.2 | Debug all Inputs |  | 4w | 2005-07-21 | 2005-08-17 | 137 | 101d |  |  | PhysicistU | 160h |  | BU | DOE-base |  |
| 143 | 1.5.5.4.2.2.3 | Verify Outputs |  | 4w | 2005-08-18 | 2005-09-15 | 138 | 81d |  |  | PhysicistU | 160h |  | BU | DOE-base |  |
| 144 | 1.5.5.4.2.3 | **Notre Dame Contribution** |  | 50d | 2005-07-07 | 2005-09-15 |  | 81d |  |  |  | 400h |  |  |  |  |
| 145 | 1.5.5.4.2.3.1 | Install DFEA boards |  | 2w | 2005-07-07 | 2005-07-20 | 134, 57, 3 | 121d |  |  | PhysicistU | 80h |  | ND | EQ-DOE |  |
| 146 | 1.5.5.4.2.3.2 | Debug all Inputs |  | 4w | 2005-07-21 | 2005-08-17 | 137 | 101d |  |  | PhysicistU | 160h |  | ND | EQ-DOE |  |
| 147 | 1.5.5.4.2.3.3 | Verify Outputs |  | 4w | 2005-08-18 | 2005-09-15 | 138 | 81d |  |  | PhysicistU | 160h |  | ND | EQ-DOE |  |

Notes:
- 122: WBS Definition- / This summary element provides for improvements in the Run2a track-matching trigger. It includes development and procurement of slightly modified versions of existing Level 1 muon cards, and procurement of related cabling, connectors, readout crates, processors, and power supplies. / Text9: This summary element provides for improvements in the Run2a track-matching trigger. It includes development and procurement of slightly modified versions of existing Level 1 muon cards, and procurement of related cabling, connectors, readout crates, pro
- 123: WBS Definition- / Milestone-All production and testing for the cal/track match has been done.
- 124: WBS Definition- / This summary task describes the installation of the complete cal-track matching system in the experiment.
- 125: WBS Definition- / install MTCxx, MTFB, and MTCM in crate and connect cables and do final cable dressing. Work to be completed prior to RunIIb shutdown. / Labor BOE- / Experience installing Level 1 muon trigger cards in Run 2a. Assumes two physicists at 50% FTE each. Add electrical engineer at 25%.
- 128: WBS definition - / Verify that the cal-trk trigger is receiving proper timing (BOT) and trigger signals from the trigger framework. / M&S BOE - / No M&S associated with this task / Labor BOE - / Requires full electronics chain (trigger framework, serial command link hub, muon fanout card, muon readout card) to be available. In run 2a, this took approximately 4 months, but much more of the infrastructure will be in place and tested at the time of the Run IIb task: 1 month of physicist time.
- 129: WBS Definition- / Verify inputs from CTT, cal-L1 / * note - relies on CTT and cal-L1 being ready to send outputs -- need at least 1/8 of Cal L1. / M&S BOE- / NA / Labor BOE- / RunIIa muon Level 1 experience debugging inputs from muon front ends and CTT: 1 full time physicist for a month. / Text9: install cards in system and test interface with trigger framework
- 130: WBS Definition- / Verify decisions of cal-track match are correct at the trigger framework / M&S BOE- / NA / Labor BOE- / RunIIa experience verifying Level 1 muon trigger decisions: 1 week for a physicist. / Text9: install cards in system and test interface with trigger framework
- 131: WBS Definition- / Record data sent to L2 and L3 and verify format / M&S BOE- / NA / Labor BOE- / RunIIa experience establishing readout of L2 and L3 data from Level 1 muon trigger: 1 physicist full time for a month. / I / Text9: install cards in system and test interface with trigger framework
- 132: WBS Definition- / Milestone-The level 1 calorimeter track matching trigger has been technically commissioned. / n Run2a, the equivalent system tests for Level 1 muon trigger took six months with three physicists (full time). The cal-trk trigger is expected to go faster because it is approximately one sixth the size, and the L1 Muon trigger is by now well understood.
- 133: WBS Definition- / This summary element provides for improvements in the existing track trigger. It includes design and development of algorithms that utilize larger FPGAs, and development and procurement of new Digital Front-End (DFE) boards that utilize these FPGAs. / Text9: This summary element provides for improvements in the existing track trigger. It includes design and development of algorithms that utilize larger FPGAs, and development and procurement of new Digital Front-End (DFE) boards that utilize these FPGAs.
- 134: WBS Definition- / Milestone-central track trigger complete except for installation and commissioning. / Text9: milestone
- 135: WBS Definition- / This summary task provides for the shared installation effort of all the DFEA's for the new Central Track Trigger.
- 136: WBS Definition- / This summary task provides for the shared installation effort of all the DFEA's for the new Central Track Trigger.
- 137: WBS Definition- / Remove old crates (in rack PC03 on platform), install 2 new crates, hookup 320 input and 80 output cables, load DFEB boards in crates (40 boards total). / Labor BOE- / Steve Linn and Stefano Rapisarda (Eng) and Stefan Grunendahl -- 2 weeks effort. / M&S BOE- / NA
- 138: WBS Definition- / Verify inputs from AFE, SCL. (Caution if AFEII is in picture!). Need trigger framework/clock. / M&S BOE- / NA / Labor BOE- / Run2a CTT experience taking into account the fact that all DFEA have been previously operated in parallel test stand, performed by physicists. Engineers play consulting role. Time can readily extend to two months if AFEII iterations needed.
- 139: WBS Definition- / Verify ouputs to L1 Muon, L2, L3, using test vectors. Can use separate clock if AFE's not available. / Labor BOE- / Run2a CTT experience taking into account all DFEA previously operated in parallel test stand, performed by physicists. Consult with engineers.
- 140: WBS Definition- / This summary task provides for the shared installation effort of all the DFEA's for the new Central Track Trigger.
- 141: WBS Definition- / Remove old crates (in rack PC03 on platform), install 2 new crates, hookup 320 input and 80 output cables, load DFEB boards in crates (40 boards total). / Labor BOE- / Steve Linn and Stefano Rapisarda (Eng) and Stefan Grunendahl -- 2 weeks effort. / M&S BOE- / NA / WBS Definition- / Install new DFEA boards on the run 2a DFE motherboards. (Boards can be installed on Tev-off days during RunIIa -- final production of boards is scheduled to begin in March, 2005), but time is allowed after the beginning of the RunIIb shutdown to install all boards. / Labor BOE- / It will take about 16 man-days to install all 80 boards in the L1 CTT racks in the platform. / M&S BOE- / NA
- 142: WBS Definition- / Verify inputs from AFE, SCL. / M&S BOE- / NA / Labor BOE- / Run2a CTT experience taking into account the fact that all DFEA have been previously operated in parallel test stand, performed by physicists. Consult with engineers. / WBS Definition- / Verify inputs from AFE, SCL. / Labor BOE- / Run2a CTT experience, performed by physicists. Consult with engineers.
- 143: WBS Definition- / Verify ouputs to L1 Muon, L2, L3 using test vectors. / Labor BOE- / Run2a CTT experience taking into account all DFEA previously operated in parallel test stand, performed by physicists, performed by physicists. Consult with engineers.
- 144: WBS Definition- / This summary task provides for the shared installation effort of all the DFEA's for the new Central Track Trigger.
- 145: WBS Definition- / Remove old crates (in rack PC03 on platform), install 2 new crates, hookup 320 input and 80 output cables, load DFEB boards in crates (40 boards total). / Labor BOE- / Steve Linn and Stefano Rapisarda (Eng) and Stefan Grunendahl -- 2 weeks effort. / M&S BOE- / NA / WBS Definition- / Install new DFEA boards on the run 2a DFE motherboards. (Boards can be installed on Tev-off days during RunIIa -- final production of boards is scheduled to begin in March, 2005), but time is allowed after the beginning of the RunIIb shutdown to install all boards. / Labor BOE- / It will take about 16 man-days to install all 80 boards in the L1 CTT racks in the platform. / M&S BOE- / NA
- 146: WBS Definition- / Verify inputs from AFE, SCL. / M&S BOE- / NA / Labor BOE- / Run2a CTT experience taking into account the fact that all DFEA have been previously operated in parallel test stand, performed by physicists. Consult with engineers. Time can readily extend to two months if AFEII iterations needed.
- 147: WBS Definition- / Verify ouputs to L1 Muon, L2, L3 / Labor BOE- / Run2a CTT experience taking into account all DFEA previously operated in parallel test stand, performed by physicists, performed by physicists. Consult with engineers.

| ID | WBS | Task | Type | Duration | Start | Finish | Predecessors | Total slack | Free slack | Constraint | Resources | Work | Cost | Text27 | Text28 | Text9 | Text8 |
| --- | --- | --- | --- | --- | --- | --- | --- | --- | --- | --- | --- | --- | --- | --- | --- | --- | --- |
| 148 | 1.5.5.4.2.4 | **KU Contribution** |  | 50d | 2005-07-07 | 2005-09-15 |  | 81d |  |  |  | 560h |  |  |  |  |  |
| 149 | 1.5.5.4.2.4.1 | Install DFEA boards |  | 2w | 2005-07-07 | 2005-07-20 | 134, 57, 3 | 121d | 0d |  | PhysicistU | 80h |  | KU | NSF-base |  |  |
| 150 | 1.5.5.4.2.4.2 | Debug all Inputs |  | 4w | 2005-07-21 | 2005-08-17 | 137 | 101d |  |  | PhysicistU; SeniorElecEngU | 320h |  | KU | NSF-base |  |  |
| 151 | 1.5.5.4.2.4.3 | Verify Outputs |  | 4w | 2005-08-18 | 2005-09-15 | 138 | 61d | 0d |  | PhysicistU | 160h |  | KU | NSF-base |  |  |
| 152 | 1.5.5.4.2.4.4 | L1CTT Installaltion & Technical Commissioning Complete | milestone | 0w | 2005-09-15 | 2005-09-15 | 151 | 61d | 20d |  | PhysicistU |  |  | KU | NSF-base |  |  |
| 153 | 1.5.5.4.2.5 | Trigger Upgrade Ready for Resumption of Tevatron | milestone | 0w | 2005-07-20 | 2005-07-20 | 149 | 121d |  |  |  |  |  |  |  |  |  |
| 154 | 1.5.5.4.3 | Level 1 Tracking Installation Complete | milestone | 0w | 2005-10-13 | 2005-10-13 | 121, 132 | 36d | 0d |  |  |  |  |  |  |  |  |
| 155 | 1.5.5.5 | **Level 2 Beta Processors** |  | 125d | 2005-01-24 | 2005-07-20 |  | 121d |  |  |  | 430h |  |  |  |  |  |
| 156 | 1.5.5.5.1 | Level 2 Beta Production Complete | milestone | 0w | 2005-01-24 | 2005-01-24 |  | 166d | 0d | finish no earlier than 2005-01-24 |  |  |  |  |  |  |  |
| 157 | 1.5.5.5.2 | **Verify Assembled Processors** |  | 65d | 2005-01-25 | 2005-04-25 |  | 166d |  |  |  | 230h |  |  |  |  |  |
| 158 | 1.5.5.5.2.1 | Cut Code Release for new Hardware |  | 2w | 2005-01-25 | 2005-02-07 | 156 | 166d | 0d |  | PhysicistU | 80h |  | UVA | DOE-base | UVA |  |
| 159 | 1.5.5.5.2.2 | Online Code Support/Development |  | 7w | 2005-02-08 | 2005-03-28 | 158 | 166d | 0d |  | PhysicistU [25%] | 70h |  | UVA | DOE-base |  |  |
| 160 | 1.5.5.5.2.3 | Verify Processor Assemblies -- UVA |  | 2w | 2005-03-29 | 2005-04-11 | 159 | 166d | 0d |  | PhysicistU [50%] | 40h |  | UVA | DOE-base |  |  |
| 161 | 1.5.5.5.2.4 | Verify Processor Assemblies -- ORS |  | 2w | 2005-04-12 | 2005-04-25 | 160 | 166d | 45d |  | PhysicistU [50%] | 40h |  | ORS | InKind-Foreign |  |  |
| 162 | 1.5.5.5.3 | **Installation And Technical Commissioning** |  | 15d | 2005-06-29 | 2005-07-20 |  | 121d |  |  |  | 200h |  |  |  |  |  |
| 163 | 1.5.5.5.3.1 | Install boards in L2 Trigger |  | 1w | 2005-06-29 | 2005-07-06 | 161, 3 | 121d | 0d |  | PhysicistU | 40h |  | FNAL | OP |  | Experience w/ original Alpha and Beta processors |
| 164 | 1.5.5.5.3.2 | Technical commissioning-UVA |  | 2w | 2005-07-07 | 2005-07-20 | 163 | 121d | 0d |  | PhysicistU | 80h |  | UVA | DOE-base |  |  |
| 165 | 1.5.5.5.3.3 | Technical commissioning-ORS |  | 2w | 2005-07-07 | 2005-07-20 | 163 | 121d | 0d |  | PhysicistU [50%] | 40h |  | ORS | InKind-Foreign |  |  |
| 166 | 1.5.5.5.3.4 | Technical commissioning-FNAL |  | 2w | 2005-07-07 | 2005-07-20 | 163 | 121d | 0d |  | PhysicistF [50%] | 40h |  | FNAL | OP |  |  |
| 167 | 1.5.5.5.3.5 | Level 2 Upgrade Beta Installed & Commissioned | milestone | 0w | 2005-07-20 | 2005-07-20 | 166, 165, 164 | 121d |  |  |  |  |  |  |  |  |  |
| 168 | 1.5.5.6 | **L2 Silicon Track Trigger Upgrade** |  | 452d | 2004-01-05 | 2005-10-20 |  | 36d |  |  |  | 860h | 3,918.5 |  |  |  |  |
| 169 | 1.5.5.6.1 | L2 STT Hardware Production Complete | milestone | 0w | 2005-03-30 | 2005-03-30 |  | 154d | 63d | finish no earlier than 2005-03-30 |  |  |  |  |  |  |  |
| 170 | 1.5.5.6.2 | **L2 STT Installation** |  | 377d | 2004-01-05 | 2005-07-06 |  | 91d |  |  |  | 380h | 3,918.5 |  |  |  |  |
| 171 | 1.5.5.6.2.1 | STT Module Install |  | 1w | 2005-06-29 | 2005-07-06 | 169, 3 | 91d | 0d |  | PhysicistU | 40h |  | BU | DOE-base |  |  |
| 172 | 1.5.5.6.2.2 | VTM Install |  | 1w | 2005-06-29 | 2005-07-06 | 169, 3 | 91d | 0d |  | PhysicistU | 40h |  | BU | DOE-base |  |  |
| 173 | 1.5.5.6.2.3 | TFC Module Install |  | 1w | 2005-06-29 | 2005-07-06 | 169, 3 | 91d | 0d |  | PhysicistU | 40h |  | BU | DOE-base |  |  |
| 174 | 1.5.5.6.2.4 | Splitters Install |  | 2w | 2004-01-05 | 2004-01-16 | 7SS | 458d | 367d |  | PhysicistF; SeniorMechTechF | 160h | 2,298 | FNAL | OP |  |  |
| 175 | 1.5.5.6.2.5 | Fibers Install |  | 1w | 2005-06-29 | 2005-07-06 | 3 | 91d | 0d |  | PhysicistF; SeniorMechTechF; SeniorElecEngF [25%]; John Anderson [25%] | 100h | 1,620.5 | FNAL | OP |  |  |
| 176 | 1.5.5.6.3 | L2 STT Hardware Installed | milestone | 0w | 2005-07-06 | 2005-07-06 | 175, 173, 172, 171, 174 | 91d | 55d |  |  |  |  |  |  |  |  |

Notes:
- 148: WBS Definition- / This summary task provides for the shared installation effort of all the DFEA's for the new Central Track Trigger.
- 149: WBS Definition- / Remove old crates (in rack PC03 on platform), install 2 new crates, hookup 320 input and 80 output cables, load DFEB boards in crates (40 boards total). / Labor BOE- / Steve Linn and Stefano Rapisarda (Eng) and Stefan Grunendahl -- 2 weeks effort. / M&S BOE- / NA
- 150: WBS Definition- / Verify inputs from AFE, SCL. / M&S BOE- / NA / Labor BOE- / Run2a CTT experience taking into account the fact that all DFEA have been previously operated in parallel test stand, performed by physicists. Consult with engineers. Time can readily extend to two months if AFEII iterations needed.
- 151: WBS Definition- / Verify ouputs to L1 Muon, L2, L3 / Labor BOE- / Run2a CTT experience taking into account all DFEA previously operated in parallel test stand, performed by physicists, performed by physicists. Consult with engineers.
- 152: WBS Definition- / Milestone-The level 1 central track trigger has been technically commissioned.
- 153: WBS Definition- / Milestone- Run IIb trigger upgrades installed and ready for beam.
- 154: WBS Definition- / Milestone-This milestone corresponds to the completion of the installation and technical commissioning of the L1 track trigger system.
- 155: WBS Definition- / This summary task provides for the installation of the L2 Beta trigger system and its technical commissioning.
- 156: WBS Definition- / Milestone- All parts for upgrade Betas in hand and working.
- 157: WBS Definition- / This summary task verifies processors in L2 trigger or test crates.
- 158: WBS Definition- / Cut first code release for new hardware. Update any trial code to meet release criteria. / Labor BOE- / Experience w/ original Alpha and Beta processors: 1 physicist full time for 2 weeks. / M&S BOE- / NA
- 159: WBS Definition- / Tune online code: Develop any enhanced driver features over Run 2a, coordinate these with changes to high level trigger code. Assumes we propogate 2-3 changes at most through the online code. / Labor BOE- / Estimated need for physicist working 50% for duration of task. / M&S BOE- / NA
- 160: WBS Definition- / Test assembled processor boards in L2 trigger or test crates. Run through suite of I/O tests in test crate. / Labor BOE- / Experience w/ Run2a Alpha and Beta processors: physicist working 1/2 time / M&S BOE- / NA
- 161: WBS Definition- / Test assembled processor boards in L2 trigger or test crates. / Labor BOE- / Experience w/ Run2a Alpha and Beta processors - run through suite of i/o tests in test crate.
- 162: WBS Definition- / This summary task installs the components of the L2 beta trigger and tests their operation.
- 163: WBS Definition- / Install boards in L2 Trigger Crates. / Labor BOE- / Experience w/ Run2a Alpha and Beta processors: 1 physicist working 1 week.
- 164: WBS Definition- / Test boards in-situ after installation. / Labor BOE- / Experience w/ Run2a Alpha and Beta processors: 1 physicist for 2 weeks working 1/2 time. / M&S BOE- / NA
- 165: WBS Definition- / Test boards in-situ after installation. / Labor BOE- / Experience w/ Run2a Alpha and Beta processors: 1physicist working 2 weeks 1/2 time. / M&S BOE- / NA
- 166: WBS Definition- / Test boards in-situ after installation. / Labor BOE- / Estimated labor (1/4 time physicist) for swapping boards and/or recabling crates during in-situ tests.
- 167: WBS Definition- / MIlestone-New Beta processors installed and i/o functions tested in-situ.
- 168: WBS Definition- / This summary task element includes upgrades to the Run 2a silicon track trigger to adapt it to the increased number of inputs from the Run 2b silicon detector. It consists of the procurement of additional electronics boards of the Run 2a type, together with the development and production of a new board type (the Link Echo Board). Also included are firmware changes, procurement of additional, slightly modified backplanes, and additional cabling and connector hardware.
- 169: WBS dictionary- / Milestone-All hardware components are ready to be installed.
- 170: WBS Definition- / This summary taskcovers installation of the components of the STT.
- 171: WBS Definition- / Daughter board that processes raw data from SMT. Design as the same as for Run 2A. / Labor BOE- / Labor provided by physicists: 1 man-week. / M&S BOE- / NA
- 172: WBS Definition- / 9U board with 4 optical receivers and g-link serial link receivers that receive the raw data sent by SMT. They are used in D0 and CDF as part of the SVX DAQ system. / Labor BOE- / Labor provided by Physicists: 1 man week / M&S BOE- / NA
- 173: WBS Definition- / Daughter board that fits a trajectory to hits in SMT and CFT. Design is the same as for Run 2A. / Labor BOE- / Labor provided by Physicists: 1 man week / M&S BOE- / NA
- 174: WBS Definition- / Passive optical splitters to create data path into STT / Labor BOE- / Two shifts per day assumed. / M&S BOE- / Panel on wall -- $500
- 175: WBS Definition- / 148 Optical fibers from splitters to VRBs(74) and to STT(74). / Labor BOE- / Estimates based on RunIIa experience: 1 tech and 1 physicist working full time, plus cable czar oversight (25%). / M&S BOE- / NA. (Fibers in Uprade Project STT budget).
- 176: WBS Definition- / Milestone-All elements of the silicon track trigger have been installed.

| ID | WBS | Task | Type | Duration | Start | Finish | Predecessors | Total slack | Free slack | Resources | Work | Text8 | Text27 | Text28 | Text1 |
| --- | --- | --- | --- | --- | --- | --- | --- | --- | --- | --- | --- | --- | --- | --- | --- |
| 177 | 1.5.5.6.4 | **L2 STT Technical Commissioning** |  | 20d | 2005-09-23 | 2005-10-20 |  | 36d | 0d |  | 480h |  |  |  |  |
| 178 | 1.5.5.6.4.1 | Technical Commissioning, BU effort |  | 4w | 2005-09-23 | 2005-10-20 | 154FS-3w, 176 | 36d | 0d | PhysicistU | 160h | done by physicists | BU | DOE-base |  |
| 179 | 1.5.5.6.4.2 | Technical Commissioning, CU Effort |  | 4w | 2005-09-23 | 2005-10-20 | 154FS-3w, 176 | 36d | 0d | PhysicistU | 160h |  | CU | DOE-base |  |
| 180 | 1.5.5.6.4.3 | Technical Commissioning, SUNY Effort |  | 4w | 2005-09-23 | 2005-10-20 | 154FS-3w, 176 | 36d | 0d | PhysicistU | 160h |  | SUNYSB | DOE-base |  |
| 181 | 1.5.5.6.4.4 | L2 STT Technical Commissioning Complete | milestone | 0w | 2005-10-20 | 2005-10-20 | 178, 179, 180 | 36d | 0d |  |  |  |  |  |  |
| 182 | 1.5.5.7 | Trigger Upgrade Ready for Resumption of Tevatron | milestone | 0w | 2005-07-20 | 2005-07-20 | 106, 137, 42, 43 | 121d | 22d |  |  |  |  |  |  |
| 183 | 1.5.6 | Run IIb Detector Ready for Resumption of Tevatron | milestone | 0w | 2005-08-19 | 2005-08-19 | 182, 90 | 99d |  |  |  |  |  |  |  |
| 184 | 1.5.7 | **Layer Zero Physics Commissioning** |  | 85d | 2005-09-12 | 2006-01-20 |  | 0d |  |  | 1560h |  |  |  | 9/1 |
| 185 | 1.5.7.1 | Timing Studies |  | 1w | 2005-09-12 | 2005-09-16 | 94 | 0d |  | PhysicistF | 40h |  |  |  | 9/1 |
| 186 | 1.5.7.2 | Noise Studies |  | 4w | 2005-09-19 | 2005-10-14 | 185 | 0d |  | PhysicistU | 160h |  |  |  | 9/1 |
| 187 | 1.5.7.3 | Alignment |  | 4w | 2005-10-17 | 2005-11-11 | 186 | 0d |  | PhysicistF [200%] | 320h |  |  |  | 9/1 |
| 188 | 1.5.7.4 | Clustering Studies |  | 8w | 2005-11-14 | 2006-01-20 | 187 | 0d |  | PhysicistF; PhysicistU | 640h |  |  |  | 9/1 |
| 189 | 1.5.7.5 | Tracking Studies |  | 8w | 2005-11-14 | 2006-01-20 | 187 | 0d |  | PhysicistU | 320h |  |  |  | 9/1 |
| 190 | 1.5.7.6 | Physics Objects (Vee's, etc) |  | 2w | 2005-11-14 | 2005-11-29 | 187 | 30d |  | PhysicistU | 80h |  |  |  | 9/1 |
| 191 | 1.5.7.7 | Layer Zero Ready for RunIIb Physics | milestone | 0w | 2005-10-14 | 2005-10-14 | 186 | 60d | 22d |  |  |  |  |  | 9/1 |
| 192 | 1.5.8 | **L1 Cal Trig Physics Commissioning** |  | 70d | 2005-09-07 | 2005-12-15 |  | 18d |  |  | 3600h |  |  |  | 9/1 |
| 193 | 1.5.8.1 | Trigger Rate Studies |  | 8w | 2005-09-07 | 2005-11-01 | 120 | 18d | 0d | PhysicistU [200%] | 640h |  |  |  | 9/1 |
| 194 | 1.5.8.2 | Trigger Efficiency Studies |  | 8w | 2005-09-14 | 2005-11-08 | 193SS+1w | 43d | 5d | PhysicistU [200%] | 640h |  |  |  | 9/1 |
| 195 | 1.5.8.3 | Noise Studies |  | 8w | 2005-09-07 | 2005-11-01 | 120 | 48d | 10d | PhysicistU | 320h |  |  |  | 9/1 |
| 196 | 1.5.8.4 | Determine Threshold Reference Sets |  | 6w | 2005-10-05 | 2005-11-15 | 193SS+4w | 38d | 0d | PhysicistU; PhysicistF | 480h |  |  |  | 9/1 |
| 197 | 1.5.8.5 | Understand Missing Et |  | 8w | 2005-09-21 | 2005-11-15 | 193SS+2w | 38d | 0d | PhysicistU [200%] | 640h |  |  |  | 9/1 |
| 198 | 1.5.8.6 | Tune Digital Filter Coefficients |  | 6w | 2005-10-05 | 2005-11-15 | 193SS+4w | 38d | 0d | PhysicistU | 240h |  |  |  | 9/1 |
| 199 | 1.5.8.7 | Study Sliding Window Algorithms |  | 8w | 2005-10-19 | 2005-12-15 | 193SS+6w | 18d |  | PhysicistU [200%] | 640h |  |  |  | 9/1 |
| 200 | 1.5.8.8 | L1 Cal Trig Ready for RunIIb Physics | milestone | 0w | 2005-11-15 | 2005-11-15 | 198, 193, 194, 195, 196, 197 | 38d | 0d |  |  |  |  |  | 9/1 |

Notes:
- 177: WBS Definition- / This summary task provides for a full system test: send test data through all modules, verify output, interface with other systems, test downloading and monitoring (likely can use sequencers, 1553, to generate patters (slow burst rate only). Access to CH not needed.
- 178: WBS Definition- / System test; send test data through all modules, verify output, interface with other systems, test downloading and monitoring (likely can use sequencers, 1553, to generate patters (slow burst rate only). Access to CH not needed. / Labor BOE- / Done by physicists. / M&S BOE- / NA
- 179: WBS Definition- / System test. send test data through all modules, verify output, interface with other systems, test downloading and monitoring (likely can use sequencers, 1553, to generate patters (slow burst rate only). Access to CH not needed. / Labor BOE- / Done by physicists. / M&S BOE- / NA
- 180: WBS Definition- / System test. send test data through all modules, verify output, interface with other systems, test downloading and monitoring (likely can use sequencers, 1553, to generate patters (slow burst rate only). Access to CH not needed. / Labor BOE- / Done by physicists. / M&S BOE- / NA
- 181: WBS Definition- / Milestone-The technical commissioning of the L2 silicon track trigger is complete.
- 182: WBS Definition- / Milestone- Run IIb trigger upgrades installed and ready for beam.
- 183: WBS Definition / Milestone-Run IIb Detector is ready for the resumption of the Tevtron.
- 184: WBS Definition- / This summary task completes physics commissioning of the Layer Zero silicon for RunIIb physics resumption.
- 185: WBS Definition- / Time in L0 Silcon / Labor BOE- / Juste / M&S BOE- / NA
- 186: WBS Definition- / Analyse noise from L0 silicon / Labor BOE- / Kajfasz / M&S BOE- / NA
- 187: WBS Definition- / Align L0 silicon / Labor BOE- / Borissov, Lancaster / M&S BOE- / NA
- 188: WBS Definition- / Perform clustering studies with L0 added to existing silicon / Labor BOE- / Khanov, Kulik / M&S BOE- / NA
- 189: WBS Definition- / Perform tracking studies adding L0 silicon to existing silicon. / Labor BOE- / Zdrazil / M&S BOE- / NA
- 190: WBS Definition- / Analyze physics objects having track hits in L0 silicon. / Labor BOE- / M&S BOE- / NA
- 191: WBS Definition / Milestone- L0 Silicon is ready for RunIIb physics. Note clustering, tracking, physics objects needn't be completed.
- 192: WBS Definition- / This summary task completes physics commissioning of the L1 Cal Trig for RunIIb physics resumption.
- 193: WBS Definition- / Labor BOE- / M&S BOE- / NA
- 194: WBS Definition- / Labor BOE- / M&S BOE- / NA
- 195: WBS Definition- / Labor BOE- / M&S BOE- / NA
- 196: WBS Definition- / Labor BOE- / M&S BOE- / NA
- 197: WBS Definition- / Labor BOE- / M&S BOE- / NA
- 198: WBS Definition- / Labor BOE- / M&S BOE- / NA
- 199: WBS Definition- / Labor BOE- / M&S BOE- / NA
- 200: WBS Definition / Milestone- L1 Cal Trig is ready for RunIIb physics. Note sliding window studies needn't be completed.

| ID | WBS | Task | Type | Duration | Start | Finish | Predecessors | Total slack | Free slack | Constraint | Resources | Work | Text1 |
| --- | --- | --- | --- | --- | --- | --- | --- | --- | --- | --- | --- | --- | --- |
| 201 | 1.5.10 | **L1 TrackMatch Physics Commissioning** |  | 20d | 2005-10-14 | 2005-11-10 |  | 41d |  |  |  | 320h | 9/1 |
| 202 | 1.5.10.1 | Study L1 Cal Track/Match Triggers In Detail |  | 4w | 2005-10-14 | 2005-11-10 | 132, 121 | 41d | 0d |  | PhysicistU [200%] | 320h | 9/1 |
| 203 | 1.5.10.2 | L1 Cal Track Match ready for RunIIb Physics | milestone | 0w | 2005-11-10 | 2005-11-10 | 202 | 41d | 3d |  |  |  | 9/1 |
| 204 | 1.5.12 | **L1CTT Physics Commissioning** |  | 20d | 2005-10-14 | 2005-11-10 |  | 41d |  |  | PhysicistU [200%] | 640h | 9/1 |
| 205 | 1.5.12.1 | Study L1 Central Track Triggers In Detail |  | 4w | 2005-10-14 | 2005-11-10 | 132, 152, 121 | 41d | 0d |  | PhysicistU [200%] | 320h | 9/1 |
| 206 | 1.5.12.2 | L1 Central Track Trigger ready for RunIIb Physics | milestone | 0w | 2005-11-10 | 2005-11-10 | 205 | 41d | 3d |  |  |  | 9/1 |
| 207 | 1.5.14 | **L2 Beta Physics Commissioning** |  | 20d | 2005-10-21 | 2005-11-17 |  | 36d |  |  |  | 160h | 9/1 |
| 208 | 1.5.14.1 | Verify Function of New Features |  | 4w | 2005-10-21 | 2005-11-17 | 181 | 36d | 0d |  | PhysicistU | 160h | 9/1 |
| 209 | 1.5.14.2 | L2 Beta ready for RunIIb Physics | milestone | 0w | 2005-11-17 | 2005-11-17 | 208 | 36d | 0d |  |  |  | 9/1 |
| 210 | 1.5.16 | **L2STT Physics Commissioning** |  | 15d | 2005-10-21 | 2005-11-10 |  | 41d |  |  |  | 360h | 9/1 |
| 211 | 1.5.16.1 | Verify STT Track Fitting |  | 3w | 2005-10-21 | 2005-11-10 | 181 | 41d | 0d |  | PhysicistU [200%]; PhysicistF | 360h | 9/1 |
| 212 | 1.5.16.2 | L2 STT ready for RunIIb Physics | milestone | 0w | 2005-11-10 | 2005-11-10 | 211 | 41d | 3d |  |  |  | 9/1 |
| 213 | 1.5.18 | **Trigsim Technical Commissioning** |  | 288d | 2004-01-05 | 2005-03-01 |  | 220d |  |  |  | 4800h | 9/1 |
| 214 | 1.5.18.1 | Find and Fix Trigsim Bugs |  | 4w | 2005-01-04 | 2005-02-01 |  | 40d | 0d | start no earlier than 2005-01-01 | PhysicistF [300%]; PhysicistU [300%] | 960h | 9/1 |
| 215 | 1.5.18.2 | Check Outputs |  | 3w | 2005-01-11 | 2005-02-01 | 214SS+1w | 240d |  |  | PhysicistF [300%]; PhysicistU [300%] | 720h | 9/1 |
| 216 | 1.5.18.3 | Debug Trigsimcert |  | 3w | 2004-01-05 | 2004-01-26 |  | 493d |  |  | PhysicistF [300%]; PhysicistU [300%] | 720h | 9/1 |
| 217 | 1.5.18.4 | Debug Ratetool |  | 3w | 2004-01-05 | 2004-01-26 |  | 493d |  |  | PhysicistF [300%]; PhysicistU [300%] | 720h | 9/1 |
| 218 | 1.5.18.5 | Make Default Trigger List |  | 3w | 2005-01-11 | 2005-02-01 | 214SS+1w | 40d | 0d |  | PhysicistF [300%]; PhysicistU [300%] | 720h | 9/1 |
| 219 | 1.5.18.6 | Production Release Available | milestone | 0w | 2005-02-01 | 2005-02-01 | 218 | 40d | 0d |  |  |  | 9/1 |
| 220 | 1.5.18.7 | Certify Production Release |  | 4w | 2005-02-02 | 2005-03-01 | 219 | 40d | 0d |  | PhysicistF [300%]; PhysicistU [300%] | 960h | 9/1 |
| 221 | 1.5.18.8 | Trigsim Tools Certified and Released | milestone | 0w | 2005-03-01 | 2005-03-01 | 220 | 40d | 0d |  |  |  | 9/1 |
| 222 | 1.5.27 | **Develop RunIIb Trigger List** |  | 180d | 2005-03-02 | 2005-11-11 |  | 40d |  |  |  | 6840h | 9/1 |
| 223 | 1.5.27.1 | L1/L2 Integration |  | 18w | 2005-03-02 | 2005-07-07 | 221 | 40d | 0d |  | PhysicistF [300%]; PhysicistU [300%] | 4320h | 9/1 |
| 224 | 1.5.27.2 | L3 |  | 8w | 2005-07-08 | 2005-09-01 | 223 | 40d | 0d |  | PhysicistF [300%]; PhysicistU [300%] | 1920h | 9/1 |
| 225 | 1.5.27.3 | Database Entry & Verification |  | 4w | 2005-09-02 | 2005-09-30 | 224 | 40d | 0d |  | PhysicistF | 160h | 9/1 |
| 226 | 1.5.27.4 | Download Verification |  | 1w | 2005-10-03 | 2005-10-07 | 225 | 40d | 0d |  | PhysicistF | 40h | 9/1 |
| 227 | 1.5.27.5 | Test Trigger List with data-taking |  | 5w | 2005-10-10 | 2005-11-11 | 226 | 40d | 0d |  | PhysicistF; PhysicistU | 400h | 9/1 |
| 228 | 1.5.27.6 | Trigger List Ready for RunIIb Physics | milestone | 0w | 2005-11-11 | 2005-11-11 | 227 | 40d | 2d |  |  |  | 9/1 |
| 229 | 1.5.34 | D0 Ready for RunIIb Physics | milestone | 0w | 2005-11-17 | 2005-11-17 | 228, 212, 209, 206, 203, 200, 191 | 36d |  |  |  |  | 9/1 |

Notes:
- 201: WBS Definition- / This summary task completes physics commissioning of the L1Cal Track match for RunIIb physics resumption.
- 202: WBS Definition- / Study L1Cal only with L1Cal/TrkMatch Triggers in detail. / Labor BOE- / M&S BOE- / NA
- 203: WBS Definition / Milestone- L1 Cal Trig is ready for RunIIb physics. Note sliding window studies needn't be completed.
- 204: WBS Definition- / This summary task completes physics commissioning of the L1CTT for RunIIb physics resumption.
- 205: WBS Definition- / Study L1Central Track Triggers with L1CTT only Triggers in detail. / Labor BOE- / M&S BOE- / NA
- 206: WBS Definition / Milestone- L1 Cal Trig is ready for RunIIb physics. Note sliding window studies needn't be completed.
- 207: WBS Definition- / This summary task completes physics commissioning of the L2 Beta for RunIIb physics resumption.
- 208: WBS Definition- / Verify function of any new features: trigger bit expansion, etc. / Labor BOE- / M&S BOE- / NA
- 209: WBS Definition / Milestone- L1 Cal Trig is ready for RunIIb physics. Note sliding window studies needn't be completed.
- 210: WBS Definition- / This summary task completes physics commissioning of the L2STT for RunIIb physics resumption.
- 211: WBS Definition- / Verify function of track fitting code. / Labor BOE- / M&S BOE- / NA
- 212: WBS Definition / Milestone- L1 Cal Trig is ready for RunIIb physics. Note sliding window studies needn't be completed.
- 214: WBS Definition- / Debug Trigsim Code. / Labor BOE- / One expert per subsystem. / M&S BOE- / NA
- 215: WBS Definition- / Debug Trigsim Outputs. / Labor BOE- / One expert per subsystem. / M&S BOE- / NA
- 216: WBS Definition- / Debug Trigsim Code. / Labor BOE- / One expert per subsystem. / M&S BOE- / NA
- 217: WBS Definition- / Debug Ratetool Code. / Labor BOE- / One expert per subsystem. / M&S BOE- / NA
- 218: WBS Definition- / Make Default Trigger list. / Labor BOE- / One expert per subsystem. / M&S BOE- / NA
- 220: WBS Definition- / Certify database. / Labor BOE- / One expert per subsystem. / M&S BOE- / NA
- 222: WBS Definition- / Develop Trigger List(s) for various expected luminosities. / Labor BOE- / One expert per subsystem. / M&S BOE- / NA
- 223: WBS Definition- / Integrate L1/L2 trigger terms. / Labor BOE- / One expert per subsystem. / M&S BOE- / NA
- 224: WBS Definition- / Incorporate L3 triggers. / Labor BOE- / One expert per subsystem. / M&S BOE- / NA
- 225: WBS Definition- / Install trigger list in database and verify. / Labor BOE- / One expert per subsystem. / M&S BOE- / NA
- 226: WBS Definition- / Verify downloaded trigger list. / Labor BOE- / M&S BOE- / NA
- 227: WBS Definition- / Test trigger list in datataking. / Labor BOE- / M&S BOE- / NA
- 228: WBS Definition / Milestone- RUnIIb Trigger list is ready for high luminosity running of fully upgraded detector.
- 229: WBS Definition / Milestone- RUnIIb Upgrade of D0 Detector Complete and High Luminsoity Phyisics data is logging to tape via competent trigger list.
