# Trigger_July04_Dev_v1

Schedule from MS Project, 2001-11-01 to 2005-12-01, status date 2004-09-01, costs in $, A marks actual dates.
Aug 2004 Status - Final
Fermilab
Aug 2004 Status complete as per Darien Wood - 28 Sept 2004.
Aug 2004 Status - First pass.

## Calendars

- Standard: Mon-Fri 08:00-12:00, 13:00-17:00; Sat-Sun off. Exceptions (off unless hours are given): 2001-11-22 to 2001-11-23, 2001-12-24 to 2001-12-28, 2001-12-31 to 2002-01-01, 2002-05-27, 2002-07-04, 2002-09-02, 2002-11-28 to 2002-11-29, 2002-12-24 to 2002-12-27, 2002-12-30 to 2003-01-01, 2003-01-20, 2003-05-26, 2003-07-04, 2003-09-01, 2003-11-27 to 2003-11-28, 2003-12-24 to 2003-12-26, 2003-12-29 to 2004-01-01, 2004-01-19, 2004-05-31, 2004-07-02, 2004-09-06, 2004-11-25 to 2004-11-26, 2004-12-24, 2004-12-27 to 2004-12-31, 2005-01-03, 2005-01-17, 2005-05-30, 2005-07-04, 2005-09-05, 2005-11-24 to 2005-11-25.

## Resources

| Resource | Group | Rate | Cost per use | Notes |
| --- | --- | --- | --- | --- |
| MechEngF | F | 539914000 | 313 | Mechanical Engineer-Fermilab |
| MechEngU | U |  |  | Mechanical Engineer-Non-Fermilab (University) |
| ElecEngF | F | 55 |  | Electrical Engineer-Fermilab |
| ElecEngU | U |  |  | Electrical Engineer-Non-Fermilab (University) |
| MechTechF | F | 35 |  | Mechanical Tech-Fermilab |
| MechTechU | U |  |  | Mechanical Tech-Non-Fermilab (University) |
| ElecTechF | F | 39 |  | Electrical Tech-Fermilab |
| ElecTechU | U |  |  | Electrical Tech-Non-Fermilab (University) |
| PhysicistF | F |  |  | Physicist-Fermilab - $1998/wk, but zeroed out |
| PhysicistU | U |  |  | Physicist-Non-Fermilab (University) $1998/wk, but zeroed out |
| CompProfF | F | 47 |  | Computing Professional-Fermilab |
| CompProfU | U |  |  | Computing Professional-Non-Fermilab (University) |
| StudentU | U |  |  |  |
| PostdocU | U |  |  |  |
| MandS |  | 1 |  |  |
| AdminAsstF | F | 28.5 |  |  |
| InKind |  | 1 |  |  |
| MandSPass |  | 1 |  |  |
| MandSExempt |  | 1 |  |  |
| ElecEngU1 |  |  |  |  |
| ElecEngU2 |  |  |  |  |
| ElecEngU3 |  |  |  |  |
| CompProU1 |  |  |  |  |
| MechTechU1 |  |  |  |  |

## Schedule

| ID | WBS | Task | Type | Duration | Start | Finish | Predecessors | Complete | Remaining | Baseline start | Baseline finish | Baseline duration | Total slack | Free slack | Constraint | Resources | Work | Actual work | Cost | Baseline cost | Actual cost | Text27 | Text26 | Text28 | Text24 | Text23 | Text29 | Text30 |
| --- | --- | --- | --- | --- | --- | --- | --- | --- | --- | --- | --- | --- | --- | --- | --- | --- | --- | --- | --- | --- | --- | --- | --- | --- | --- | --- | --- | --- |
| 1 | 1.2 | **Run IIb Trigger Upgrade** |  | 1013d | 2001-11-01 A | 2005-12-01 |  | 64% | 361.34d | 2001-11-01 | 2006-01-10 | 1034d | 0d |  |  |  | 108643h | 67175.5h | 3,590,438.68 | 2,880,987.7 | 2,044,319.86 |  |  |  |  |  |  |  |
| 2 | 1.2.1 | **Level 1 Calorimeter Trigger** |  | 978d | 2002-01-02 A | 2005-12-01 |  | 75% | 242.81d | 2002-01-02 | 2006-01-05 | 996d | 0d |  |  |  | 36133.3h | 22489.9h | 1,766,389.81 | 1,403,354.25 | 1,344,396.03 |  |  |  |  |  |  |  |
| 3 | 1.2.1.1 | **ADC/Digital Filter (ADF)** |  | 978d | 2002-01-02 A | 2005-12-01 |  | 68% | 315.31d | 2002-01-02 | 2005-07-12 | 879d | 0d |  |  |  | 22371.8h | 11300.8h | 1,107,037.79 | 759,245.12 | 780,810.39 |  |  |  |  |  |  |  |
| 4 | 1.2.1.1.1 | **Saclay Tasks** |  | 572d | 2002-01-02 A | 2004-04-16 A |  | 100% |  | 2002-01-02 | 2004-12-17 | 742d |  |  |  |  | 6227.2h | 6227.2h | 433,791.15 | 475,027.15 | 433,791.15 | SAC |  |  |  |  |  |  |
| 5 | 1.2.1.1.1.1 | Design prototype ADF |  | 53w | 2002-01-02 A | 2003-01-24 A |  | 100% |  | 2002-01-02 | 2002-12-12 | 48.4w |  |  | start no earlier than 2002-01-02 | ElecEngU; InKind | 2120h | 2120h | 189,655.6 | 189,655.6 | 189,655.6 | SAC | Percent Complete | INK-FOREIGN |  |  |  |  |
| 6 | 1.2.1.1.1.2 | Layout prototype ADF |  | 17w | 2003-01-27 A | 2003-05-23 A | 5 | 100% |  | 2002-11-13 | 2003-02-04 | 10w |  |  |  | ElecTechU; InKind | 680h | 680h | 15,110.4 | 15,110.4 | 15,110.4 | SAC | Percent Complete | INK-FOREIGN |  |  |  |  |
| 7 | 1.2.1.1.1.3 | Fabricate/Assemble Prototype ADF |  | 5.2w | 2003-05-27 A | 2003-07-01 A | 6 | 100% |  | 2003-02-05 | 2003-04-15 | 10w |  |  |  | ElecTechU [50%]; InKind | 104h | 104h | 60,055.2 | 60,055.2 | 60,055.2 | SAC | Percent Complete | INK-FOREIGN |  |  |  |  |
| 8 | 1.2.1.1.1.4 | Bench Test Prototype ADF |  | 13.6w | 2003-07-15 A | 2003-10-17 A | 7 | 100% |  | 2003-07-15 | 2003-09-09 | 8w |  |  | start no earlier than 2003-07-15 | PhysicistU [30%]; ElecEngU [20%]; ElecTechU [20%]; InKind | 380.8h | 380.8h | 20,632.24 | 20,632.24 | 20,632.24 | SAC | Percent Complete | INK-FOREIGN | Trig-082803-1 |  |  |  |
| 9 | 1.2.1.1.1.5 | Prototype L1 Calorimeter Trigger ADF Shipped To Fermilab | milestone | 0w | 2003-10-07 A | 2003-10-07 A | 8 | 100% |  | 2003-09-09 | 2003-09-09 | 0w |  |  |  |  |  |  |  |  |  |  |  |  | Trig-082803-1 |  |  |  |
| 10 | 1.2.1.1.1.6 | Design analog splitter |  | 4w | 2002-03-01 A | 2002-03-28 A |  | 100% |  | 2002-03-01 | 2002-03-28 | 4w |  |  |  | ElecEngU; InKind | 160h | 160h | 16,494.4 | 16,494.4 | 16,494.4 | SAC | Percent Complete | INK-FOREIGN |  |  |  |  |
| 11 | 1.2.1.1.1.7 | Layout and fabricate analog splitter |  | 8w | 2002-07-01 A | 2002-08-26 A | 10 | 100% |  | 2002-07-01 | 2002-08-26 | 8w |  |  | start no earlier than 2002-07-01 | ElecTechU [50%]; InKind [915020%] | 160h | 160h | 9,150.2 | 9,150.2 | 9,150.2 | SAC | Percent Complete | INK-FOREIGN |  |  |  |  |
| 12 | 1.2.1.1.1.8 | Bench test analog splitter |  | 9.2w | 2002-11-04 A | 2003-01-17 A | 11FS+1w | 100% |  | 2002-09-04 | 2002-09-17 | 2w |  |  | start no earlier than 2002-11-04 | ElecTechU [50%]; InKind [188880%] | 116h | 116h | 1,888.8 | 1,888.8 | 1,888.8 | SAC | Percent Complete | INK-FOREIGN |  |  |  |  |
| 13 | 1.2.1.1.1.9 | Design SCL interface |  | 46.8w | 2002-07-15 A | 2003-06-23 A |  | 100% |  | 2002-07-15 | 2002-09-24 | 10.2w |  |  | start no earlier than 2002-07-15 | ElecEngU [30%]; InKind | 561.6h | 561.6h | 41,236 | 41,236 | 41,236 | SAC | Percent Complete | INK-FOREIGN |  |  |  |  |
| 14 | 1.2.1.1.1.10 | Layout and fabricate SCL interface |  | 8.6w | 2003-06-24 A | 2003-08-22 A | 13 | 100% |  | 2003-06-24 | 2003-08-19 | 8w |  |  | start no earlier than 2003-03-14 | ElecTechU [50%]; InKind | 172h | 172h | 11,199.2 | 11,199.2 | 11,199.2 | SAC | Percent Complete | INK-FOREIGN | Trig-082803-2 |  |  |  |
| 15 | 1.2.1.1.1.11 | Bench test SCL interface |  | 7.8w | 2003-08-25 A | 2003-10-17 A | 14 | 100% |  | 2003-08-20 | 2003-09-17 | 4w |  |  |  | ElecTechU [50%]; InKind [377760%] | 156h | 156h | 3,777.6 | 3,777.6 | 3,777.6 | SAC | Percent Complete | INK-FOREIGN | Trig-082803-2 |  |  |  |
| 16 | 1.2.1.1.1.12 | ADF Prototype in-situ tests |  | 9.4w | 2003-10-15 A | 2003-12-22 A | 9FS+1w, 12 | 100% |  | 2003-09-24 | 2004-01-27 | 16w |  |  |  | PhysicistU; ElecEngU [20%]; InKind | 451.2h | 451.2h | 13,193.43 | 13,193.43 | 13,193.43 | SAC | Percent Complete | INK-FOREIGN | Trig-082803-1 |  |  |  |
| 17 | 1.2.1.1.1.13 | Final ADF design - Production readiness review |  | 0.2w | 2003-12-09 A | 2003-12-09 A | 16FS-2w | 100% |  | 2004-01-13 | 2004-03-23 | 10w |  |  |  | ElecEngU | 8h | 8h |  | 41,236 |  | SAC | Percent Complete | INK-FOREIGN | Trig-082803-1 |  |  |  |
| 18 | 1.2.1.1.1.14 | Bench test 10% ADF |  | 0.2w | 2004-02-27 A | 2004-02-27 A |  | 100% |  | 2004-08-18 | 2004-10-27 | 10w |  |  | start no earlier than 2004-08-18 | ElecTechU; ElecEngU [10%]; PhysicistU [30%]; InKind | 11.2h | 11.2h | 18,409.28 | 18,409.28 | 18,409.28 | SAC | Percent Complete | INK-FOREIGN |  |  |  |  |
| 19 | 1.2.1.1.1.15 | Digital filter FPGA programming |  | 54.4w | 2003-01-27 A | 2004-02-27 A | 5 | 100% |  | 2002-12-13 | 2004-12-17 | 100w |  |  |  | PhysicistU [30%]; ElecEngU [10%]; InKind | 870.4h | 870.4h | 32,988.8 | 32,988.8 | 32,988.8 | SAC | Percent Complete | INK-FOREIGN |  |  |  |  |
| 20 | 1.2.1.1.1.16 | ADF offline software and analysis |  | 13.8w | 2004-01-12 A | 2004-04-16 A |  | 100% |  | 2003-08-12 | 2004-03-23 | 30w |  |  |  | PhysicistU [50%] | 276h | 276h |  |  |  | SAC | Percent Complete | INK-FOREIGN | Trig-082803-1 |  |  |  |
| 21 | 1.2.1.1.2 | **MSU Tasks** |  | 539d | 2003-10-01 A | 2005-12-01 |  | 40% | 322.76d | 2003-09-10 | 2005-07-12 | 496d | 0d |  |  |  | 16144.6h | 5073.6h | 673,246.64 | 284,217.97 | 347,019.24 |  |  |  | Trig-082803-1 |  |  |  |
| 22 | 1.2.1.1.2.1 | Develop in-situ exercizing/debugging software |  | 9w | 2003-10-20 A | 2003-12-23 A | 8 | 100% |  | 2003-09-10 | 2004-02-10 | 20w |  |  |  | ElecEngU [50%]; PhysicistU [50%]; InKind | 360h | 360h | 18,555.75 | 41,234.93 | 18,555.75 | MSU | Percent Complete | INK-OTHER | Trig-082803-1 |  |  |  |
| 23 | 1.2.1.1.2.6 | Control/FW for prototype test 1 |  | 11.6w | 2003-10-01 A | 2003-12-23 A |  | 100% |  | 2003-10-01 | 2003-12-23 | 11.6w |  |  | start no earlier than 2003-10-01 | ElecEngU2 | 464h | 464h |  |  |  | MSU |  | INK-OTHER |  |  |  |  |
| 24 | 1.2.1.1.2.7 | Control/FW for prototype test 2 |  | 40w | 2004-01-02 A | 2004-10-13 | 23 | 85% | 6w | 2004-01-02 | 2004-08-03 | 30w | 51d | 0d |  | PhysicistU [50%]; ElecEngU [95%]; CompProfU [15%]; MandSPass | 2203.6h | 1819.6h | 48,601.49 | 48,601.49 | 48,601.49 | MSU |  | EQU |  | CC | 1.2.1.1.2.7 | 1.2.1.1.2.7 |
| 25 | 1.2.1.1.2.8 | Control/FW for integration testing |  | 46w | 2004-10-14 | 2005-09-19 | 24 |  |  | 2004-08-04 | 2005-09-19 | 56w | 51d |  |  | PhysicistU; ElecEngU; CompProfU [25%]; MandSPass | 4140h |  | 106,248.8 | 106,248.8 |  | MSU |  | EQU |  |  | 1.2.1.1.2.8 | 1.2.1.1.2.8 |

Notes:
- 1: WBS Definition- / The Level 1 trigger upgrade is designed to allow us to maintain the peak output rate of 5 kHz at the higher luminosities of Run 2b. This will be accomplished by upgrades to three systems - the Level 1 calorimeter trigger, a calorimeter cluster track match at Level 1, and the Level 1 central track trigger. Procurement of additional Level 2 beta processors, silicon track trigger electronics boards, associated hardware, and firmware support is also included in the trigger upgrade project, as is the simulation effort. This summary WBS element includes all the effort required to develop, build, test, install, and initially commission these trigger elements.
- 2: WBS Definition- / This summary element covers the Level 1 calorimeter trigger modifications. It includes development and procurement of ADC/digital filter boards (ADF), development and procurement of trigger-algorithm boards (TAB), the provision of output signals to facilitate a match between calorimeter towers and tracks, and procurement and improvements in associated readout crates, power supplies, cabling, and controls hardware. / Text9: This summary element covers the Level 1 calorimeter trigger modifications. It includes development and procurement of ADC/digital filter boards (ADF), development and procurement of trigger-algorithm boards (TAB), the provision of output signals to facil
- 3: WBS Definition- / This summary element covers the design, fabrication and testing of the ADC+Digital filter cards which receive, digitize, and filter the calorimter tower signals / Risk Mitigation (cost)- / Risk of escalation in parts cost due to unforeseen design changes is mitigated by the relatively large contingency assigned to the procurement of components and fabrication/assembly given the advanced state of the design (prototype design nearly finished). Cost risk from extra labor needed to complete the project is reduced because of the large fraction of the labor that is covered by in-kind contributions from Saclay. Extra Saclay personnel can be diverted to the project should the need arise. / Text9: This summary element covers the design, fabrication and testing of the ADC+Digital filter cards which receive, digitize, and filter the calorimter tower signals
- 5: WBS Definition- / Design a 16- or 32-channel prototype ADC/digital filter card with all input, output and control connections. / M&S BOE- / 1840 h of Saclay engineer at $4122.95/w = $189,655.60 / Labor BOE- / Based on effort expended on the project so far. Note that the design of the ADF prototype is almost entirely complete. / Text9: Design a full 32-channel prototype ADC/digital filter card with all input, output and control connections
- 6: WBS Definition- / Layout prototype ADC boards / M&S BOE- / 320 h of Saclay engineer at $1888.80/w = $15,110.40 / Labor BOE- / Estimate from lead engineer based on the current design of the ADF. Agrees well with the time needed to lay out boards of similar complexity in the STT system (4 weeks for the Fiber Road Card - FRC).
- 7: WBS Definition- / Fabricate 5 prototype cards. / M&S BOE- / $52,500 for equipment (assumes prototypes are ~10x the cost of the production versions) plus / 160 h Saclay technician at $1888.80/w = $7,555.20 / ----- / total = $60,055.20 / Labor BOE- / Based on the Fab/Assembly time for the STT FRC (4 weeks). Multiplied by a factor of two to take into account increased board complexity. / Text9: fabricate 5 prototype cards
- 8: WBS Definition- / Test on test stand with simulated input signals. / M&S BOE- / $5,000 for test equipment (see cost book for details) plus / 104 h Saclay engineer at $4122.95/w = $10,719.66 plus / 104 h Saclay technician at $1888.80/w = $4,910.88 / ----- / total = $20,630.54 / Text9: test on test stand with simulated input signals
- 9: WBS Definition- / milestone: at least one prototype shipped to Fermilab for in-situ tests
- 10: WBS Definition- / This element is an active device that takes as input a number of differential analog signals coming from the BLS cards, and produces two identical copies of these signals. One copy feeds the trigger system in place (CTFE board) while the second copy is to be connected to the prototype ADF. The board accomodates 8 channels, i.e. 4 trigger towers. All channels are identical and comprises 3 fully-differential amplifiers and passive components. The complexity of the board is rather low. / M&S BOE- / 160 h Saclay engineer at $4122.95/w = $16,491.79 / Labor BOE- / Design finished.
- 11: WBS Definition- / Layout and fabrication of Splitter cards. / M&S BOE- / $1595 for components and fab costs (see cost book for details) / 160 h Saclay technician at $1888.80/w = $7,555.20 / ----- / total = $9,150.20 / Labor BOE- / Estimate from lead engineer based on completed design of the splitter card.
- 12: WBS Definition- / Test of Splitter cards to verify basic functionality and to ensure that split signals are not degraded. Tests on a per channel basis include measurements of: gain vs frequency, dynamic range and temporal response under the expected input pulse shape. / M&S BOE- / 40 h Saclay technician at $1888.80/w = $1,888.80 / Labor BOE- / Estimate of lead engineer based on his experience with similar, simple boards.
- 13: WBS Definition- / This element is in charge of distributing timing signals to the ADF system and provides a path to distibute fast synchronous signals within the ADF system. The board includes a SCL mezzanine receiver card and is linked to each ADF crate via a medium speed cable (~64 Mbit/s). A single FPGA and additional logic (e.g. digital delay lines) are used on that board; No slow control interface is needed because all parameters are static. This board is of moderate complexity. / M&S BOE- / 400 h Saclay engineer at $4122.95/w = $41,229.48 / Labor BOE- / Estimate of lead engineer based on discussions with the people who designed the SCL.
- 14: WBS Definition- / Layout and fabrication of SCL interface cards. / M&S BOE- / $3644 for components and fab costs (see cost book for details) / 160 h Saclay technician at $1888.80/w = $7,555.20 / ----- / total = $11,199.20 / Labor BOE- / A similar amount of effort is assumed for this task as for the analog splitter. The small increase in board complexity is not expected to significantly increase fabrication/assembly turnaround time.
- 15: WBS Definition- / Test of SCL interface cards to verify basic functionality. Tests include the validation of the bi-directional link between the board and each ADF crate, and the correct distribution of timing and control signals via the SCL when the board is in-situ. Test with SCL signals is part of Prototype integration task. / M&S BOE- / 80 h Saclay technician at $1888.80/w = $3,777.60 / Labor BOE- / Estimate of lead engineer based on his experience with similar, simple boards.
- 16: WBS Definition- / Perform parasitic tests with split-off signals from the run2a calorimeter trigger. Test perfomance of digital filter on different trigger towers in the calorimeter. Tests include the recording of pulse shapes on several channels, the validation of the digital filter algorithm with real input signals, the cross-check with calorimeter precision data recorded by D0 DAQ. / M&S BOE - / 128 h of Saclay engineering at $4123.49/w = $13,193.43 / Labor BOE - / Estimate based on experience of lead engineer with digital filters and on experience understanding Run IIa L1Cal signals.
- 17: WBS Definition- / Update prototype design to address any shortcomings found in testing / M&S BOE- / 400 hours of engineering at $4122.95/w = $41,229.48 / Labor BOE- / 1/4 of the time foreseen for the design of the board; only small fixes expected to be done. / As of the end of Feb 04, the Saclay contribution to this task is ended due to Saclay's withdrawal from the Project. The design is being taken over by MSU and new tasks have been added to the schedule to reflect their contribution. The $41,236 has been removed from this task so the In Kind contribution is now zero. / Text9: update prototype design to address any shortcomings found in testing
- 18: WBS Definition- / Test first 10% of boards before approving full production run. Same tests as 1.2.1.1.13; additional tests with several ADF boards feeding a TAB. / M&S BOE - / 320 h of university technician time @ $1888.80/w = $15,110.40 plus / 32 h of university engineering time @ $4123.49/w = $3298.79 / ---------- / total = $18,409.19 / Labor BOE- / 1/2 the effort required for prototype testing (1.2.1.1.13). / As of the end of Feb 04, the Saclay contribution to this task is ended due to Saclay's withdrawal from the Project. The design is being taken over by MSU and new tasks have been added to the schedule to reflect their contribution. / Text9: test first 10% of boards before approving the full production run
- 19: WBS Definition- / Develop digital filter algorithms based on simulations and results of ADF prototype. / M&S BOE - / 320 h of Saclay engineering time at $4122.95/w = $32,983.58 / Labor BOE- / Based on actual time taken for the completion and implementation of the prototype algorithm (8-tap FIR + 3 point peak detector + final Et look-up table). / As of the end of Feb 04, the Saclay contribution to this task is ended due to Saclay's withdrawal from the Project. The design is being taken over by MSU and new tasks have been added to the schedule to reflect their contribution. / Text9: develop digital filter algorithms based on simulations and results of ADF test card
- 20: WBS definition - / Write software for the offline analysis of the ADF data acquired in the in-situ test. These results are used to optimize the digital filter design. / Labor BOE - / 50% of a physicists is needed for the duration of the task. Preparation must start 8 weeks before the in-situ test begin, and continue six weeks after the test are complete in order to analyze the data taken. / In-Kind costs were removed for this task on 16 April 2004 and the task was closed out due to Saclay's withdrawal from the Project.
- 22: WBS Definition- / Develop special in situ and diagnostic software that cycles the system at design speed and verifies that the hardware gets the right answer. This software is used to download FPGA configuration, load programmable parameters, read-back captured data (e.g. input and output of the digital filter), and perform various tests (e.g. feed output link with a pseudo-random pattern to verify output link independently of digital filter). / M&S BOE - / 400 hours of engineering at $4123.49/w = $41234.93 / Labor BOE- / Experience with similar software from existing L1cal

| ID | WBS | Task | Type | Duration | Start | Finish | Predecessors | Complete | Remaining | Baseline start | Baseline finish | Baseline duration | Total slack | Free slack | Constraint | Resources | Work | Actual work | Cost | Baseline cost | Actual cost | Text23 | Text27 | Text28 | Text29 | Text30 | Text26 | Text24 |
| --- | --- | --- | --- | --- | --- | --- | --- | --- | --- | --- | --- | --- | --- | --- | --- | --- | --- | --- | --- | --- | --- | --- | --- | --- | --- | --- | --- | --- |
| 26 | 1.2.1.1.2.3 | **ADF Prototype v.2** |  | 290d | 2004-01-05 A | 2005-03-03 |  | 66% | 97.3d | 2004-01-05 | 2004-07-21 | 140d | 190d |  |  |  | 2869h | 1614h | 119,320.2 |  | 85,575 |  |  |  |  |  |  |  |
| 27 | 1.2.1.1.2.3.1 | Layout ADF v.2 prototype |  | 37w | 2004-01-05 A | 2004-09-23 |  | 95% | 1.85w | 2004-01-05 | 2004-03-29 | 12w | 0d |  | start no earlier than 2004-01-05 | ElecEngU [150%]; MandSPass | 1725h | 1614h | 85,575 |  | 85,575 | CC | MSU | EQU | 1.2.1.1.2.3 | 1.2.1.1.2.3.1 |  |  |
| 28 | 1.2.1.1.2.3.2 | Fabricate ADF v.2 prototype |  | 4w | 2004-09-24 | 2004-10-21 | 27 |  |  | 2004-03-30 | 2004-04-19 | 3w | 0d |  |  | MandS [350000%] |  |  | 3,500 |  |  |  | MSU | EQU | 1.2.1.1.2.3 | 1.2.1.1.2.3.2 |  |  |
| 29 | 1.2.1.1.2.3.3 | Assemble ADF v.2 prototype |  | 2w | 2004-10-22 | 2004-11-04 | 28 |  |  | 2004-04-20 | 2004-05-10 | 3w | 0d |  |  | PhysicistU [50%]; ElecEngU [80%]; MandSPass [365120%] | 104h |  | 3,651.2 |  |  |  | MSU | EQU | 1.2.1.1.2.3 | 1.2.1.1.2.3.3 |  |  |
| 30 | 1.2.1.1.2.3.4 | Three ADF Cards Received By MSU | milestone | 0w | 2004-11-04 | 2004-11-04 | 29 |  |  | 2004-05-10 | 2004-05-10 | 0w | 0d |  |  |  |  |  |  |  |  |  |  |  |  |  |  |  |
| 31 | 1.2.1.1.2.3.5 | Two ADF Cards Received By Saclay | milestone | 0w | 2004-11-04 | 2004-11-04 | 29 |  |  | 2004-05-10 | 2004-05-10 | 0w | 265d |  |  |  |  |  |  |  |  |  |  |  |  |  |  |  |
| 32 | 1.2.1.1.2.3.6 | Perform bench tests at MSU |  | 6w | 2004-11-05 | 2004-12-20 | 30 |  |  | 2004-05-11 | 2004-06-15 | 5w | 0d |  |  | PhysicistU; ElecEngU [130%]; MechTechU [50%]; MandSPass | 672h |  | 17,199.6 |  |  |  | MSU | EQU | 1.2.1.1.2.3 | 1.2.1.1.2.3.6 |  |  |
| 33 | 1.2.1.1.2.3.7 | Perform tests at Fermilab |  | 4w | 2004-12-21 | 2005-01-27 | 32 |  |  | 2004-06-16 | 2004-07-14 | 4w | 0d |  |  | PhysicistU; ElecEngU [130%]; MandSPass [939440%] | 368h |  | 9,394.4 |  |  |  | MSU | EQU | 1.2.1.1.2.3 | 1.2.1.1.2.3.7 |  |  |
| 34 | 1.2.1.1.2.3.8 | Production Design Approved | milestone | 0w | 2005-01-27 | 2005-01-27 | 33 |  |  | 2004-07-14 | 2004-07-14 | 0w | 25d |  |  |  |  |  |  |  |  |  |  |  |  |  |  |  |
| 35 | 1.2.1.1.2.3.9 | Production readiness review |  | 0.2w | 2004-02-27 A | 2004-02-27 A |  | 100% |  | 2004-07-15 | 2004-07-21 | 1w |  |  |  |  |  |  |  |  |  |  | MSU |  |  |  |  |  |
| 36 | 1.2.1.1.2.3.10 | Release ADF For Production | milestone | 0w | 2005-03-03 | 2005-03-03 | 128, 34 |  |  | 2004-07-21 | 2004-07-21 | 0w | 0d |  |  |  |  |  |  |  |  |  |  |  |  |  |  |  |
| 37 | 1.2.1.1.2.2 | **ADF Production** |  | 441d | 2004-02-27 A | 2005-12-01 |  | 21% | 349.62d | 2004-03-11 | 2005-07-12 | 334d | 0d |  |  |  | 6108h | 816h | 380,520.4 | 242,983.04 | 194,287 |  | MSU |  |  |  |  |  |
| 38 | 1.2.1.1.2.2.1 | Procure ADF components |  | 16w | 2004-06-23 A | 2004-10-14 | 42SS | 30% | 11.2w | 2004-03-11 | 2004-06-07 | 12.4w | 280d |  |  | MandSPass; ElecEngU [20%] | 128h | 38.4h | 121,825.6 | 118,646.8 | 121,825.6 | CC | MSU | EQU | 1.2.1.1.2.2 | 1.2.1.1.2.2.1 | Percent Complete |  |
| 39 | 1.2.1.1.2.2.2 | Fabricate, assemble 10% ADF |  | 1d | 2004-02-27 A | 2004-03-01 A |  | 100% |  | 2004-06-08 | 2004-08-17 | 10w |  |  | start no earlier than 2004-06-24 |  |  |  |  | 12,759.2 |  |  | MSU | EQU | 1.2.1.1.2.2 | 1.2.1.1.2.2.2 | Percent Complete |  |
| 40 | 1.2.1.1.2.2.3 | Fabricate production ADF |  | 8w | 2005-03-04 | 2005-04-28 | 36 |  |  | 2004-10-28 | 2005-06-27 | 32.4w | 0d |  |  | MandSPass |  |  | 46,836 | 51,746.88 |  |  | MSU | EQU | 1.2.1.1.2.2 | 1.2.1.1.2.2.3 | Percent Complete |  |
| 41 | 1.2.1.1.2.2.4 | Bench test production ADF |  | 18w | 2005-03-18 | 2005-07-25 | 40SS+2w, 43 |  |  | 2004-11-11 | 2005-07-12 | 32.4w | 0d |  |  | PhysicistU [30%]; MandSPass; ElecEngU [120%]; MechTechU [35%] | 1332h |  | 40,244.4 | 59,830.16 |  |  | MSU | EQU | 1.2.1.1.2.2 | 1.2.1.1.2.2.4 | Percent Complete |  |
| 42 | 1.2.1.1.2.2.6 | Procure 10% ADF components |  | 16w | 2004-06-23 A | 2004-10-14 | 27FS-13w | 60% | 6.4w | 2004-03-30 | 2004-06-15 | 11w | 280d | 0d |  | PhysicistU [20%]; ElecEngU [20%]; MandSPass | 256h | 153.6h | 16,473 | 16,473 | 16,473 |  | MSU | EQU | 1.2.1.1.2.2 | 1.2.1.1.2.2.6 | Percent Complete |  |
| 43 | 1.2.1.1.2.2.7 | Specify/construct production test bench |  | 39w | 2004-04-01 A | 2005-01-14 |  | 33% | 26w | 2004-04-01 | 2005-01-14 | 39w | 43d |  | start no earlier than 2004-04-01 | ElecEngU [70%]; MechTechU [50%]; MandSPass | 1872h | 624h | 55,988.4 | 55,988.4 | 55,988.4 |  | MSU | EQU | 1.2.1.1.2.2 | 1.2.1.1.2.2.7 |  |  |
| 44 | 1.2.1.1.2.2.8 | Field test production ADF's |  | 18w | 2005-03-18 | 2005-07-25 | 41SS |  |  | 2005-01-18 | 2005-05-23 | 18w | 0d |  | start no earlier than 2004-04-01 | ElecEngU [85%]; MechTechU [15%]; MandSPass | 720h |  | 29,925 | 29,925 |  |  | MSU | EQU | 1.2.1.1.2.2 | 1.2.1.1.2.2.8 |  |  |
| 45 | 1.2.1.1.2.2.9 | Field test full complement of ADF's |  | 18w | 2005-07-26 | 2005-12-01 | 44 |  |  | 2005-05-24 | 2005-09-29 | 18w | 0d |  | start no earlier than 2004-04-01 | MechTechU [50%]; ElecEngU [200%]; MandSPass | 1800h |  | 69,228 | 69,228 |  |  | MSU | EQU | 1.2.1.1.2.2 | 1.2.1.1.2.2.9 |  |  |
| 46 | 1.2.1.1.3 | L1 Calorimeter Trigger ADF Production Complete And Tested | milestone | 0w | 2005-07-25 | 2005-07-25 | 41 |  |  | 2005-07-12 | 2005-07-12 | 0w | 90d | 0d |  |  |  |  |  |  |  |  |  |  |  |  |  |  |
| 47 | 1.2.1.2 | **ADF Crates** |  | 371d | 2003-05-01 A | 2004-10-22 |  | 78% | 80.22d | 2002-10-14 | 2004-04-06 | 351d | 274d |  |  |  | 1061.12h | 1009.92h | 118,420.44 | 122,499.48 | 118,420.44 |  |  |  |  |  |  | Trig-082803-1 |
| 48 | 1.2.1.2.1 | **Prototypes** |  | 204d | 2003-05-01 A | 2004-02-27 A |  | 100% |  | 2002-10-14 | 2004-02-24 | 316d |  |  |  |  | 989.12h | 989.12h | 65,966.24 | 65,966.24 | 65,966.24 |  | SAC |  |  |  |  |  |
| 49 | 1.2.1.2.1.1 | Design transition backplane |  | 3.4w | 2003-05-01 A | 2003-05-23 A |  | 100% |  | 2002-10-14 | 2002-12-02 | 6.8w |  |  | start no earlier than 2003-05-01 | ElecEngU; InKind | 136h | 136h | 24,741.6 | 24,741.6 | 24,741.6 |  | SAC | INK-FOREIGN |  |  | Percent Complete |  |
| 50 | 1.2.1.2.1.2 | Layout and fabricate transition backplane |  | 8w | 2003-05-27 A | 2003-07-22 A | 49 | 100% |  | 2002-12-03 | 2003-02-14 | 9.2w |  |  | start no earlier than 2002-12-02 | ElecTechU [50%]; InKind [755520%] | 160h | 160h | 7,555.2 | 7,555.2 | 7,555.2 |  | SAC | INK-FOREIGN |  |  | Percent Complete |  |
| 51 | 1.2.1.2.1.3 | Fabricate/Assemble prototype crate |  | 9.2w | 2003-07-23 A | 2003-09-25 A | 50 | 100% |  | 2003-07-23 | 2003-09-17 | 8w |  |  |  | ElecTechU [50%]; InKind [755520%] | 184h | 184h | 7,555.2 | 7,555.2 | 7,555.2 |  | SAC | INK-FOREIGN |  |  | Percent Complete | Trig-082803-3 |
| 52 | 1.2.1.2.1.4 | Test prototype ADF in prototype crate |  | 20w | 2003-09-26 A | 2004-02-26 A | 51, 7 | 100% |  | 2003-09-18 | 2003-11-12 | 8w |  |  |  | PhysicistU [30%]; ElecEngU [20%]; ElecTechU [20%]; InKind [961984%] | 501.12h | 501.12h | 9,619.84 | 9,619.84 | 9,619.84 |  | SAC | INK-FOREIGN |  |  | Percent Complete | Trig-082803-3 |
| 53 | 1.2.1.2.1.5 | L1 Calorimeter Trigger ADF+Crate Prototype Complete | milestone | 0w | 2004-02-26 A | 2004-02-26 A | 8, 52 | 100% |  | 2003-11-12 | 2003-11-12 | 0w |  |  |  |  |  |  |  |  |  |  |  |  |  |  |  | Trig-082803-3 |
| 54 | 1.2.1.2.1.6 | Final backplane design |  | 0.2w | 2004-02-27 A | 2004-02-27 A | 52, 16 | 100% |  | 2004-01-28 | 2004-02-24 | 4w |  |  |  | ElecEngU; InKind | 8h | 8h | 16,494.4 | 16,494.4 | 16,494.4 |  | SAC | INK-FOREIGN |  |  | Percent Complete | Trig-082803-1 |

Notes:
- 27: This includes a design phase of 10 weeks followed by a layout phase of 9 weeks.
- 28: This fabrication task will be sent out for 5 units at a cost of $500 each plus a tooling charge of $1,000. Total cost is approximately $3,500.
- 35: This review is a duplicate of a later review. This is closed and the resources/effort will be reflected in the other review (1.2.1.10.5 - Pre-Production Integration).
- 38: WBS Definition- / Procure remaining 90% of the components for production version of ADF (ADC's, FPGA's, etc.) / M&S BOE - / $103,070 in equipment ( see back up material) plus / Labor = $18,531.60 / ---------- / total = $121,601.60 / Labor BOE- / Average amount of time needed for procurement at Fermilab, based on experience of M. Johnson.
- 39: WBS Definition- / Preproduction run / M&S BOE - / equipment $5204 plus / 160 hours of university technician time to follow the production at $1888.80/w = $7555.20 / ------------ / total = $12,759.20 / This task was closed out and added back in under a different WBS number. This action was necessary to correct an inadvertent deletion of this task from an earlier schedule (sometime between Sept and Dec 2003). COBRA still recognized the missing WBS and was giving incorrect cost totals on the CPR. Action taken by T.J. to correct the Feb 04 schedule loaded into COBRA. / Text9: preproduction run
- 40: WBS Definition- / Fabricate remaining 90% of production ADF boards. / M&S BOE - / $46,836 in equipment, plus / 104 h of univeristy technician time to follow production @ $1888.8/w = $4910.88 / ------ / total = $51,746.88
- 41: WBS Definition- / Same tests as for 1.2.1.1.17, but for final production boards. / M&S BOE - / 1040 h of univeristy technician time at $1888.8/w = $49108.80 plus / 104 h of university engineer time at $4123.49/w = $10721.08 / ---------- / total = $59,829.88 / Labor BOE- / Further streamlining of testing assumed. At this stage all flaws in the design should be ironed out. Testing should be mainly to catch fabrication faults. / Text9: test stand verification of board functionality
- 42: WBS Definition- / Procure 10% of the components for production version of ADF (ADC's, FPGA's, etc.) / M&S BOE - / $11,453 in equipment ( see back up material) plus / Labor = $4866.40 / ---------- / total = $16,319.40 / Labor BOE- / Average amount of time needed for procurement at Fermilab, based on experience of M. Johnson.
- 46: WBS Definition- / milestone: All ADF cards ready for installation and commissioning
- 47: WBS Definition- / Design 6u VME crates with a (probably) custom J2 backplane / Text9: Design 6u VME crates with a custom J2 backplane
- 49: WBS Definition- / Design custom backplane for ADF crates. This element is used to bring 640 differential analog signals to the 20 ADF boards that are housed in each ADF crate. The passive custom backplane comprises 320 8-point connectors on the BLS cable side, and 20 96 or 160-point connectors on the VME backplane side. Trivial design from electronics point of view; minor mechanical issues; controlled impedance lines needed for the PCB. / 4-11-03 This transition backplane is morphing into a cable harness / M&S BOE- / 240 h of Saclay engineering time at $4122.95/w = $24,737.69 / Labor BOE- / Estimate from lead engineer based on scope of backplane.
- 50: WBS Definition- / Layout and fabrication of transition backplanes. / M&S BOE- / $0 for components and fab costs (reuse material at lab) / 160 h Saclay technician at $1888.80/w = $7,555.20 / ----- / total = $7,555.20 / Labor BOE- / Estimate from lead engineer based on complexity of design.
- 51: WBS Definition- / Assemble prototype ADF crate from material at lab. / M&S BOE- / $0 for components and fab costs (reuse material at lab) / 160 h Saclay technician at $1888.80/w = $7,555.20 / ----- / total = $7,555.20 / Labor BOE- / Based on time required to fabricate/assemble custom backplane for STT system (~1 month). / Text9: assemble crate with standard J1 and custom J2 prototype
- 52: WBS Definition- / Test prototype ADF cards in prototype crate. Feed ADF prototyte board with analog signals via prototype backplane. Measure signal degradation (expected to be negligible). / M&S BOE- / 64 h Saclay engineer at $4122.95/w = $6,596.72 plus / 64 h Saclay technician at $1888.80/w = $3,022.08 / ----- / total = $9,618.80 / Labor BOE- / Estimate from lead engineer. Testing time comparable to that of testing analog splitter cards. / Text9: test control card in test crate along with prototype ADF cards
- 53: WBS Definition- / milestone / Text9: milestone
- 54: WBS Definition- / Update prototype design to address any shortcomings found in testing. / M&S BOE- / 160 hours of engineering at $4122.95/w = $16,491.79 / Labor BOE- / Estimate from lead engineer. Taken to be same as time for initial design (1.2.1.2.1). / Text9: update prototype design to address any shortcomings found in testing

| ID | WBS | Task | Type | Duration | Start | Finish | Predecessors | Complete | Remaining | Baseline start | Baseline finish | Baseline duration | Total slack | Free slack | Constraint | Resources | Work | Actual work | Cost | Baseline cost | Actual cost | Text24 | Text27 | Text26 | Text28 | Text29 | Text30 | Text23 |
| --- | --- | --- | --- | --- | --- | --- | --- | --- | --- | --- | --- | --- | --- | --- | --- | --- | --- | --- | --- | --- | --- | --- | --- | --- | --- | --- | --- | --- |
| 55 | 1.2.1.2.2 | **Production** |  | 168d | 2004-02-27 A | 2004-10-22 |  | 30% | 116.87d | 2004-02-25 | 2004-04-06 | 30d | 274d |  |  |  | 72h | 20.8h | 52,454.2 | 56,533.24 | 52,454.2 | Trig-082803-1 | MSU |  |  |  |  |  |
| 56 | 1.2.1.2.2.1 | Procure crate components |  | 0.2w | 2004-02-27 A | 2004-02-27 A | 54 | 100% |  | 2004-02-25 | 2004-03-30 | 5w |  |  |  |  |  |  |  | 51,144.44 |  | Trig-082803-1 | MSU | Percent Complete | EQU | 1.2.1.2.2 | 1.2.1.2.2.1 |  |
| 57 | 1.2.1.2.2.2 | Assemble ADF crates |  | 0.2w | 2004-02-27 A | 2004-02-27 A | 56 | 100% |  | 2004-03-31 | 2004-04-06 | 1w |  |  |  |  |  |  |  | 5,388.8 |  | Trig-082803-1 | MSU | Percent Complete | EQU | 1.2.1.2.2 | 1.2.1.2.2.2 |  |
| 58 | 1.2.1.2.2.3 | ADF crate specification |  | 2w | 2004-06-17 A | 2004-06-30 A |  | 100% |  | 2004-05-17 | 2004-05-28 | 2w |  |  | start no earlier than 2004-06-17 | MandSPass [45640%]; ElecEngU [10%] | 8h | 8h | 456.4 | 456.4 | 456.4 |  | MSU |  | EQU | 1.2.1.2.2 | 1.2.1.2.2.3 | CC |
| 59 | 1.2.1.2.2.4 | Procure ADF crates |  | 16w | 2004-07-01 A | 2004-10-22 | 58 | 20% | 12.8w | 2004-06-01 | 2004-06-28 | 4w | 274d |  |  | ElecEngU [10%]; MandSPass | 64h | 12.8h | 51,997.8 | 51,997.8 | 51,997.8 |  | MSU |  | EQU | 1.2.1.2.2 | 1.2.1.2.2.4 |  |
| 60 | 1.2.1.3 | **Trigger Algorithm Board** |  | 775d | 2002-02-01 A | 2005-03-16 |  | 92% | 65.78d | 2002-02-01 | 2005-08-22 | 886d | 181d |  |  |  | 3149.68h | 2962.08h | 272,997.22 | 272,997.22 | 252,776.1 |  |  |  |  |  |  |  |
| 61 | 1.2.1.3.1 | **Prototypes** |  | 560d | 2002-02-01 A | 2004-04-30 A |  | 100% |  | 2002-02-01 | 2004-03-03 | 518d |  |  |  |  | 2743.28h | 2743.28h | 157,814.9 | 157,814.9 | 157,814.9 |  | CU |  |  |  |  |  |
| 62 | 1.2.1.3.1.1 | Choose L1 Calorimeter Trigger Baseline Jet Algorithm | milestone | 0w | 2002-08-08 A | 2002-08-08 A | 502SS+38w | 100% |  | 2002-08-08 | 2002-08-08 | 0w |  |  | start no earlier than 2002-02-01 |  |  |  |  |  |  |  |  |  |  |  |  |  |
| 63 | 1.2.1.3.1.2 | Design prototype Trigger Algorithm Board (TAB) |  | 49w | 2002-02-01 A | 2003-01-28 A |  | 100% |  | 2002-02-01 | 2002-10-11 | 35.6w |  |  | start no earlier than 2002-02-01 | ElecEngU [75%]; InKind | 1453.68h | 1453.68h | 94,972.2 | 94,972.2 | 94,972.2 |  | CU | Percent Complete | INK-OTHER |  |  |  |
| 64 | 1.2.1.3.1.3 | Layout prototype TAB |  | 36.6w | 2002-08-09 A | 2003-05-07 A | 62 | 100% |  | 2002-08-09 | 2002-10-11 | 9w |  |  |  | ElecEngU [15%]; InKind | 219.6h | 219.6h | 14,897.6 | 14,897.6 | 14,897.6 |  | CU | Percent Complete | INK-OTHER |  |  |  |
| 65 | 1.2.1.3.1.4 | Procure prototype TAB parts |  | 33.6w | 2002-08-23 A | 2003-04-30 A | 64SS+2w | 100% |  | 2002-08-23 | 2002-11-06 | 10.6w |  |  |  | ElecTechU [5%]; InKind | 67.2h | 67.2h | 17,931.2 | 17,931.2 | 17,931.2 |  | CU | Percent Complete | INK-OTHER |  |  |  |
| 66 | 1.2.1.3.1.5 | Fabricate/Assemble Prototype TAB |  | 6.6w | 2003-05-08 A | 2003-06-24 A | 65FS-4w, 64 | 100% |  | 2002-11-07 | 2003-01-29 | 10w |  |  |  | ElecTechU [10%]; InKind | 26.4h | 26.4h | 11,706.56 | 11,706.56 | 11,706.56 |  | CU | Percent Complete | INK-OTHER |  |  |  |
| 67 | 1.2.1.3.1.6 | Develop TAB/GAB test software |  | 73.4w | 2002-11-04 A | 2004-04-30 A |  | 100% |  | 2002-11-04 | 2004-03-03 | 65w |  |  | finish no earlier than 2004-06-01 | PostdocU [10%]; StudentU [10%] | 587.2h | 587.2h |  |  |  |  | CU | Percent Complete | INK-OTHER |  |  |  |
| 68 | 1.2.1.3.1.7 | Test prototype TAB |  | 9.4w | 2003-06-25 A | 2003-08-29 A | 66 | 100% |  | 2003-06-25 | 2003-08-20 | 8w |  |  |  | PhysicistU [20%]; ElecEngU [20%]; ElecTechU [5%]; StudentU [50%]; InKind | 357.2h | 357.2h | 15,327.72 | 15,327.72 | 15,327.72 | Trig-082803-4 | CU | Percent Complete | INK-OTHER |  |  |  |
| 69 | 1.2.1.3.1.8 | L1 Calorimeter Trigger TAB Prototype Complete | milestone | 0w | 2003-08-29 A | 2003-08-29 A | 68 | 100% |  | 2003-08-20 | 2003-08-20 | 0w |  |  |  |  |  |  |  |  |  | Trig-082803-4 |  |  |  |  |  |  |
| 70 | 1.2.1.3.1.9 | Pre-production TAB design |  | 4w | 2004-03-29 A | 2004-04-23 A | 119 | 100% |  | 2004-01-27 | 2004-03-01 | 5w |  |  |  | ElecEngU [20%]; InKind [297962%] | 32h | 32h | 2,979.62 | 2,979.62 | 2,979.62 |  | CU | Percent Complete | INK-OTHER |  |  |  |
| 71 | 1.2.1.3.2 | **Production** |  | 162d | 2004-04-22 A | 2004-12-10 |  | 75% | 39.77d | 2004-03-02 | 2005-05-05 | 295d | 241d |  |  |  | 216h | 172.4h | 103,683.92 | 103,683.92 | 86,977.36 |  | CU |  |  |  |  |  |
| 72 | 1.2.1.3.2.1 | Procure TAB parts |  | 29w | 2004-04-26 A | 2004-11-17 | 70 | 90% | 2.9w | 2004-03-02 | 2004-05-26 | 12.4w | 256d |  |  | ElecTechU [10%]; MandSPass | 116h | 104.4h | 60,373.2 | 60,373.2 | 60,373.2 |  | CU | Percent Complete | EQU | 1.2.1.3.2 | 1.2.1.3.2.1 | CC |
| 73 | 1.2.1.3.2.2 | Layout pre-production TAB |  | 2d | 2004-04-22 A | 2004-04-23 A | 70 | 100% |  | 2004-03-02 | 2004-04-22 | 7.6w |  |  |  | ElecEngU [50%]; MandSPass | 8h | 8h | 11,173.2 | 11,173.2 | 11,173.2 |  | CU | Percent Complete | EQU | 1.2.1.3.2 | 1.2.1.3.2.2 |  |
| 74 | 1.2.1.3.2.3 | Fabricate/Assemple pre-production TAB |  | 5w | 2004-04-26 A | 2004-05-28 A | 73 | 100% |  | 2004-04-23 | 2004-07-05 | 10w |  |  |  | ElecTechU [10%]; MandSPass | 20h | 20h | 11,706.56 | 11,706.56 | 11,706.56 |  | CU | Percent Complete | EQU | 1.2.1.3.2 | 1.2.1.3.2.3 | CC |
| 75 | 1.2.1.3.2.4 | Final design and layout changes to TAB |  | 2w | 2004-06-01 A | 2004-06-14 A | 74 | 100% |  | 2005-02-09 | 2005-02-24 | 2.4w |  |  |  | ElecEngU [50%]; MandSPass [372440%] | 40h | 40h | 3,724.4 | 3,724.4 | 3,724.4 |  | CU | Percent Complete | EQU | 1.2.1.3.2 | 1.2.1.3.2.4 |  |
| 76 | 1.2.1.3.2.6 | Start Production TAB Fabrication | milestone | 0w | 2004-06-15 A | 2004-06-15 A | 77SS | 100% |  | 2005-02-25 | 2005-02-25 | 0w? |  |  |  |  |  |  |  |  |  |  |  |  |  |  |  |  |
| 77 | 1.2.1.3.2.5 | Fabricate production TAB |  | 8w | 2004-10-14 | 2004-12-10 | 93 |  |  | 2005-02-25 | 2005-05-05 | 10w | 141d | 0d |  | ElecTechU [10%]; MandSPass | 32h |  | 16,706.56 | 16,706.56 |  |  | CU | Percent Complete | EQU | 1.2.1.3.2 | 1.2.1.3.2.5 |  |
| 78 | 1.2.1.3.3 | **Bench Testing** |  | 195d | 2004-06-01 A | 2005-03-16 | 76 | 6% | 182.81d | 2004-07-06 | 2005-08-22 | 282d | 141d |  |  |  | 190.4h | 46.4h | 11,498.4 | 11,498.4 | 7,983.84 |  | CU |  |  |  |  |  |
| 79 | 1.2.1.3.3.1 | Bench test pre-production TAB |  | 0.8w | 2004-06-01 A | 2004-06-04 A | 74 | 100% |  | 2004-07-06 | 2004-08-26 | 7.6w |  |  |  | PhysicistU [30%]; StudentU [75%]; ElecEngU [30%]; ElecTechU [10%]; InKind [798384%] | 46.4h | 46.4h | 7,983.84 | 7,983.84 | 7,983.84 |  | CU | Percent Complete | INK-OTHER |  |  |  |
| 80 | 1.2.1.3.3.2 | Bench test production TAB |  | 12w | 2004-12-13 | 2005-03-16 | 77 |  |  | 2005-05-06 | 2005-08-22 | 15w | 141d | 0d |  | StudentU [20%]; ElecEngU [5%]; ElecTechU [5%]; InKind [351456%] | 144h |  | 3,514.56 | 3,514.56 |  |  | CU | Percent Complete | INK-OTHER |  |  |  |

Notes:
- 56: WBS Definition- / Procure backplanes, power supplies, and mechanical parts. / M&S BOE - / Equipment at $50,200. / 20 hours of university electrical technican to research and place orders, @ $1888.80/w =$944.40 / ----- / total = $51,144.40 / Labor BOE- / Estimate from lead engineer / Text9: procure backplanes, power supplies, and mechanical parts
- 57: WBS Definition- / Assemble all production crates / M&S BOE - / backplane fabrication & assembly = $3,500, / plus 40 h of university electrical tech @ 1888.80/w = $1888.80 / ----------------- / total = $5,388.80 / Labor BOE- / Similar to 1.2.1.2.3.
- 58: This job is specifying the ADF crates.
- 59: WBS Definition- / Procure 5 crates with integrated power supplies. / M&S BOE - / Equipment at $50,200. / Labor = $1,769.80 / ----- / total = $51,969.80 / Labor BOE- / Estimate from lead engineer / Updated on 19 April by T.J. Sarlina based on new information from Darien Wood.
- 60: WBS Definition- / This summary element covers the algorithm board which receives the filtered tower transverse energies from the ADF boards and finds jet, EM and tau clusters. / Risk Mitigation (cost)- / Risk of escalation in parts cost due to unforeseen design changes is mitigated by the relatively large contingency assigned to the procurement of components and fabrication/assembly given the advanced state of the design (prototype layout started). Cost risk from extra labor needed to complete the project is reduced because of the large fraction of the labor that is covered by in-kind contributions from Columbia/Nevis. Extra Nevis personnel can be diverted to the project should the need arise. / Text9: This summary element covers the algorithm board which receives the filtered tower transverse energies from the ADF boards, and finds jet and EM clusters
- 62: WBS Definition- / Milestone: Establish baseline jet cluster algorithm that will be used to specify the prototype TAB. / Text9: design a full prototype first-tier algorithm board with all input, output and control connections
- 63: WBS Definition- / Design a full prototype trigger algorithm board with all input, output and control connections. / M&S BOE- / 1020 h of Columbia engineering at $3724.40/w = $94,972.20 / Labor BOE- / Estimated from progress so far. / Text9: design a full prototype first-tier algorithm board with all input, output and control connections
- 64: WBS Definition- / Layout of prototype TAB proceeds in parallel with design because of large number of signals to be routed. / M&S BOE - / 160 hours of Columbia engineering at $3724.40/w = $14,897.60 / Labor BOE- / Based on layout time for Run 2a Silicon Track Trigger (STT) Fiber Road Card (FRC) - 4 weeks. Multiplied by a factor of 2 to account for increased board complexity.
- 65: WBS Definition- / Procure all parts for prototype of TAB cards. / M&S BOE- / $15798 for equipment. / Details of the components going into this cost estimate are available in the supporting material folder. / plus 40 hours of university techncian to carry out procurement at $2133.33/w = $2133.33 / ----- / total = $17,931.33 / Labor BOE- / Average amount of effort needed for procurement at Fermilab, based on experience of M. Johnson. Time required based on experience with long lead-time electronics purchases.
- 66: WBS Definition- / Fabricate two prototype cards. / M&S BOE - / 10,000 for fabrificaion and assembly, plus / 32 hours of university technician at $2133.33/w = $1,706.66 / -------- / total = $11706.66 / Labor BOE- / Based on Fab/Assembly time for STT FRC - 4 weeks. Multiplied by a factor of 2 to account for increased board complexity. / Text9: fabricate two proptotype cards
- 67: WBS Definition- / Write software necessary for testing the prototype and production TAB and GAB cards. / M&S BOE- / n/a / Labor BOE- / Based on the amount of effort required to write similar software for the STT FRCs, cards which have a similar number of functions to be tested.
- 68: WBS Definition- / Test in test stand to verify that simulated inputs produce correct outputs for all of TAB functions: EM, jet, tau cluster finding, partial global sums, Cal-Trk match output, L2/L3 output. / M&S BOE - / 144 hours of Columbia engineer at $3724.40/w = $13407.84 plus / 36 hours of Columbia technician at $2133.33/w = $1920.00 / ---------- / total = $15,327.84 / Labor BOE- / Based on the amount of effort required to test the STT FRC and BC cards before they could be submitted for production. The complexity of the TAB is similar to that of the FRC and BC taken together. / Text9: test in test stand with simulated inputs
- 69: WBS Definition- / Milestone: TAB prototype complete and passes bench tests: produces all the correct outputs for known inputs or failures understood. / Text9: milestone
- 70: WBS Definition- / Update prototype design to address any shortcomings found in testing. This process will occur largely in parallel with the TAB prototype testing. / M&S BOE - / 32 hours of Columbia engineer at $3274.40/w = $2,979.52 / Labor BOE- / Estimated from time required to implement final changes to FRC design after testing. / Text9: update prototype design to address any shortcomings found in testing
- 72: WBS Definition- / Procure all parts for production of TAB cards. / M&S BOE- / Details of the components going into this cost estimate are available in the supporting material folder. / Equipment = $58,240, plus / 40 hours of electrical technician at $2133.33/w = $2133.33 / --------------- / total = $60,373.33 / Labor BOE- / Average amount of effort needed for procurement at Fermilab, based on experience of M. Johnson. Time required based on experience with long lead-time electronics purchases.
- 73: WBS Definition- / Lay out final design for TAB cards. / M&S BOE - / 120 hours of Columbia engineer at $3724.40/w = $11,173.20 / Labor BOE- / Based on layout time for final STT FRC - 3 weeks. Multiplied by a factor of 2 to account for increased board complexity.
- 74: WBS Definition- / Fabricate and assemble 2 TABs with final design. / M&S BOE - / $10,000 in equipment, plus / 32 hours of university electrical tech at $2133.33/w = $1,706.66 / ----- / total = $11,706.66 / Labor BOE- / Based on Fab/Assembly time for STT FRC - 4 weeks. Multiplied by a factor of 2 to account for increased board complexity. / This task was closed as of 28 May 2004, per Darien Wood, during the May 04 statussing. The 2nd TAB fulfills this role. TJS
- 75: WBS Definition- / Final changes to TAB design and layout based on pre-prod tests. Much of this will happen as the testing proceeds. / M&S BOE - / 40 hours of Columbia engineer at $3724.40/w = $3,724.40 / Labor BOE- / Based on changes necessary at the last stage of the STT FRC production. Multiplied by a factor of 2 to take into account increased board complexity.
- 77: WBS Definition- / Fabricate and assemble production TAB / M&S BOE - / equipment = $15,000 / plus 32 hours of university technician at $2133.33/w = $1,706.66 / --------------- / total = $16,706.66
- 79: WBS Definition- / Repeat prototype bench tests for pre-production boards. / M&S BOE - / 72 hours of Columbia electrical engineer at $3724.40/w = $6,703.92, plus / 24 hour of Columbia electrical tech at $2133.33/w = $1,280.00 / ---------- / total = $7,983.92 / Labor BOE- / Based on test time for first production STT FRC. Multiplied by a factor of 2 to account for increased board complexity.
- 80: WBS Definition- / Test full functionality of production boards at Nevis labs. Using simulated inputs, verify that all outputs of the board are as expected and that bit error rate in outputs acceptable -corresponding to approximately 1 fatal error per day at the nominal data volume. / M&S BOE - / 24 hours of Columbia electrical engineer at $3724.40/w = $2,234.64 plus / 24 hours of Columbia technician at $2133.33/w = $1,280.00 / ---------- / total = $3,514.64 / Labor BOE- / Based on experience in testing final STT FRCs. Assume 1 week continuous tests per board (10 boards) + 2 weeks general tests and setup

| ID | WBS | Task | Type | Duration | Start | Finish | Predecessors | Complete | Remaining | Baseline start | Baseline finish | Baseline duration | Total slack | Free slack | Constraint | Resources | Work | Actual work | Cost | Baseline cost | Actual cost | Text24 | Text27 | Text26 | Text28 | Text23 | Text29 | Text30 |
| --- | --- | --- | --- | --- | --- | --- | --- | --- | --- | --- | --- | --- | --- | --- | --- | --- | --- | --- | --- | --- | --- | --- | --- | --- | --- | --- | --- | --- |
| 81 | 1.2.1.4 | **Global Algorithm Board (GAB)** |  | 651d | 2002-07-29 A | 2005-03-16 |  | 88% | 80.38d | 2002-07-29 | 2006-01-05 | 850d | 181d |  |  |  | 2020.8h | 1653.6h | 136,288.77 | 116,963.68 | 121,984 |  |  |  |  |  |  |  |
| 82 | 1.2.1.4.1 | **Prototype** |  | 454d | 2002-07-29 A | 2004-05-26 A |  | 100% |  | 2002-07-29 | 2003-11-10 | 292d |  |  |  |  | 1601.68h | 1601.68h | 105,251.04 | 89,691.28 | 105,251.04 | Trig-041303-1,Trig-082803-5 | CU |  |  |  |  |  |
| 83 | 1.2.1.4.1.1 | Design prototype GAB |  | 45.8w | 2002-07-29 A | 2003-06-30 A |  | 100% |  | 2002-07-29 | 2002-12-11 | 19w |  |  | start no earlier than 2002-07-29 | ElecEngU [36%]; InKind | 450.89h | 450.89h | 49,609.01 | 59,590.4 | 49,609.01 | Trig-041303-1 | CU | Percent Complete | INK-OTHER |  |  |  |
| 84 | 1.2.1.4.1.2 | Layout prototype GAB |  | 18.4w | 2003-07-21 A | 2003-11-26 A | 83 | 100% |  | 2003-07-21 | 2003-08-15 | 4w |  |  | start no earlier than 2003-07-21 | ElecEngU [50%]; InKind [744329%] | 368h | 368h | 7,443.29 | 7,448.8 | 7,443.29 | Trig-082803-5 | CU | Percent Complete | INK-OTHER |  |  |  |
| 85 | 1.2.1.4.1.3 | Procure prototype GAB parts |  | 37w | 2002-08-23 A | 2003-05-23 A | 84SS+2w | 100% |  | 2003-01-06 | 2003-04-02 | 12.4w |  |  |  | ElecTechU [4%]; InKind | 59.2h | 59.2h | 10,486.66 | 9,633.2 | 10,486.66 | Trig-041303-1 | CU | Percent Complete | INK-OTHER |  |  |  |
| 86 | 1.2.1.4.1.4 | Fabricate/Assemble Prototype GAB |  | 9w | 2003-12-01 A | 2004-02-11 A | 85, 84 | 100% |  | 2003-08-18 | 2003-09-15 | 4w |  |  |  | ElecTechU [5%]; InKind [535328%] | 8.78h | 8.78h | 5,353.28 | 5,353.28 | 5,353.28 | Trig-082803-5 | CU | Percent Complete | INK-OTHER |  |  |  |
| 87 | 1.2.1.4.1.5 | Test Prototype GAB |  | 15w | 2004-02-12 A | 2004-05-26 A | 86, 68FF | 100% |  | 2003-09-16 | 2003-11-10 | 8w |  |  |  | PhysicistU [10%]; ElecEngU [10%]; ElecTechU [5%]; StudentU [25%]; InKind [383285%] | 300h | 300h | 3,832.85 | 3,832.85 | 3,832.85 | Trig-041303-1,Trig-082803-5 | CU | Percent Complete | INK-OTHER |  |  |  |
| 88 | 1.2.1.4.1.6 | L1 Calorimeter Trigger GAB Prototype Complete | milestone | 0w | 2004-05-26 A | 2004-05-26 A | 87 | 100% |  | 2004-05-03 | 2004-05-03 | 0w |  |  |  |  |  |  |  |  |  | Trig-082803-5 |  |  |  |  |  |  |
| 89 | 1.2.1.4.1.7 | Design/layout prototype VME/SCL interface |  | 7w | 2003-02-24 A | 2003-04-11 A |  | 100% |  | 2003-02-24 | 2003-04-11 | 7w |  |  | start no earlier than 2003-02-24 | InKind; ElecEngU [75%] | 210h | 210h | 19,553.1 | 19,553.1 | 19,553.1 | Trig-041303-1 | CU | Percent Complete | INK-OTHER |  |  |  |
| 90 | 1.2.1.4.1.8 | Fabricate/assemble prototype VME/SCL interface |  | 4.2w | 2003-04-14 A | 2003-05-12 A | 89 | 100% |  | 2003-04-14 | 2003-05-12 | 4.2w |  |  |  | InKind [514000%]; ElecTechU [10%] | 16.8h | 16.8h | 5,140 | 5,140 | 5,140 | Trig-041303-1 | CU | Percent Complete | INK-OTHER |  |  |  |
| 91 | 1.2.1.4.1.9 | Test prototype VME/SCL interface |  | 9.4w | 2003-05-22 A | 2003-07-29 A | 90, 68FF | 100% |  | 2003-05-22 | 2003-07-29 | 9.4w |  |  |  | InKind [383285%]; ElecEngU [10%]; ElecTechU [5%]; StudentU [25%]; PhysicistU [10%] | 188h | 188h | 3,832.85 | 3,832.85 | 3,832.85 | Trig-041303-1 | CU | Percent Complete | INK-OTHER |  |  |  |
| 92 | 1.2.1.4.2 | **Production** |  | 202d | 2004-05-20 A | 2005-03-16 |  | 35% | 131.89d | 2004-01-27 | 2006-01-05 | 483d | 181d |  |  |  | 419.12h | 51.92h | 31,037.73 | 27,272.4 | 16,732.96 | Trig-041303-1 | CU |  |  |  |  |  |
| 93 | 1.2.1.4.2.1 | Final GAB design - Production readiness review |  | 1w | 2004-10-07 | 2004-10-13 | 119 |  |  | 2004-01-27 | 2004-03-01 | 5w | 141d | 0d | start no earlier than 2004-10-07 | ElecEngU [20%]; MandSPass [297952%] | 8h |  | 2,979.52 | 2,979.52 |  |  | CU | Percent Complete | EQU | CC | 1.2.1.4.2 | 1.2.1.4.2.1 |
| 94 | 1.2.1.4.2.2 | Procure GAB parts |  | 12w | 2004-08-30 A | 2004-11-22 | 93 | 90% | 1.2w | 2004-03-02 | 2004-05-26 | 12.4w | 183d | 2d |  | ElecTechU [10%]; MandSPass [713320%] | 48h | 43.2h | 7,133.2 | 7,133.2 | 7,133.2 |  | CU | Percent Complete | EQU | CC | 1.2.1.4.2 | 1.2.1.4.2.2 |
| 95 | 1.2.1.4.2.3 | Layout final GAB |  | 6w | 2004-10-14 | 2004-11-24 | 93 |  |  | 2004-03-02 | 2004-04-22 | 7.6w | 181d | 0d |  | ElecEngU [12%]; MandSPass [268157%] | 28.8h |  | 2,681.57 | 4,469.28 |  | Trig-041303-1 | CU | Percent Complete | EQU | CC | 1.2.1.4.2 | 1.2.1.4.2.3 |
| 96 | 1.2.1.4.2.4 | Fabricate production GAB |  | 8w | 2004-11-29 | 2005-02-02 | 94, 95 |  |  | 2005-08-23 | 2005-11-01 | 10w | 181d | 0d |  | ElecTechU [5%]; MandSPass [385333%] | 16h |  | 3,853.33 | 4,706.56 |  | Trig-041303-1 | CU | Percent Complete | EQU |  | 1.2.1.4.2 | 1.2.1.4.2.4 |
| 97 | 1.2.1.4.2.5 | Bench test production GAB |  | 6w | 2005-02-03 | 2005-03-16 | 96 |  |  | 2005-11-02 | 2006-01-05 | 7.6w | 181d | 0d |  | PhysicistU [30%]; StudentU [75%]; ElecEngU [18%]; ElecTechU [6%]; MandSPass [479035%] | 309.6h |  | 4,790.35 | 7,983.84 |  | Trig-041303-1 | CU | Percent Complete | EQU |  | 1.2.1.4.2 | 1.2.1.4.2.5 |
| 98 | 1.2.1.4.2.6 | Final design/layout changes to production VME/SCL interface |  | 0.4w | 2004-05-20 A | 2004-05-21 A | 87FS-1w | 100% |  | 2004-03-04 | 2004-03-31 | 4w |  |  |  | MandSPass [297952%]; ElecEngU [20%] | 3.2h | 3.2h | 2,979.52 | 2,979.52 | 2,979.52 | Trig-041303-1 | CU | Percent Complete | EQU | CC | 1.2.1.4.2 | 1.2.1.4.2.6 |
| 99 | 1.2.1.4.2.7 | Fabricate/assemble production VME/SCL interface |  | 0.4w | 2004-05-24 A | 2004-05-25 A | 98 | 100% |  | 2004-04-01 | 2004-04-28 | 4w |  |  |  | MandSPass [342667%]; ElecTechU [5%] | 0.8h | 0.8h | 3,426.67 | 3,426.67 | 3,426.67 | Trig-041303-1 | CU | Percent Complete | EQU | CC | 1.2.1.4.2 | 1.2.1.4.2.7 |
| 100 | 1.2.1.4.2.8 | Bench test production VME/SCL interface |  | 0.2w | 2004-05-26 A | 2004-05-26 A | 99 | 100% |  | 2004-04-29 | 2004-05-26 | 4w |  |  |  | MandSPass [319357%]; ElecEngU [18%]; ElecTechU [6%]; StudentU [25%]; PhysicistU [10%] | 4.72h | 4.72h | 3,193.57 | 3,193.57 | 3,193.57 | Trig-041303-1 | CU | Percent Complete | EQU | CC | 1.2.1.4.2 | 1.2.1.4.2.8 |
| 101 | 1.2.1.5 | **Cables** |  | 632d | 2002-09-09 A | 2005-03-30 |  | 44% | 351.11d | 2002-09-09 | 2005-08-31 | 740d | 171d |  |  |  | 112.8h | 72.8h | 32,387.78 | 32,387.78 | 12,473.68 |  |  |  |  |  |  |  |
| 102 | 1.2.1.5.1 | Design and Fabricate system to test ADF to TAB cables |  | 6w | 2002-09-09 A | 2002-10-18 A |  | 100% |  | 2002-09-09 | 2002-10-21 | 6.2w |  |  | start no earlier than 2002-09-09 | ElecTechU [10%]; InKind; ElecEngU [30%] | 16.8h | 16.8h | 10,983.92 | 10,983.92 | 10,983.92 |  | CU | Percent Complete | INK-OTHER |  |  |  |
| 103 | 1.2.1.5.2 | Test ADF to TAB cables |  | 2w | 2002-10-21 A | 2002-11-01 A | 102 | 100% |  | 2002-10-22 | 2002-11-06 | 2.4w |  |  |  | ElecEngU [20%]; StudentU [50%]; InKind [148976%] | 56h | 56h | 1,489.76 | 1,489.76 | 1,489.76 |  | CU | Percent Complete | INK-OTHER |  |  |  |
| 104 | 1.2.1.5.3 | Procure ADF to TAB cables |  | 10w | 2005-01-20 | 2005-03-30 | 80SS+4w |  |  | 2005-06-06 | 2005-08-31 | 12.4w | 171d |  | start no earlier than 2002-10-01 | ElecTechU [10%]; MandSPass | 40h |  | 19,914.1 | 19,914.1 |  |  | CU | Percent Complete | EQU |  | 1.2.1.5.3 | 1.2.1.5.3 |

Notes:
- 81: WBS Definition- / This summary element covers the Global Algorithm Board which receives cluster information from the TAB's, performs final counts jets, EM and tau clusters above specified thresholds, calculates global sums (Et and missing Et) from TAB sums and exports trigger decisions to the TFW. The GAB also provides an interface and fanout for timing and control signal from the trigger framework for the TABs. / Text9: This summary element covers the Global algorithm board which receives cluster information from the TAB's, counts jets and EM clusters above specified thresholds, calculates global sum (HT and missing ET), and exports trigger decisions to the TFW
- 83: WBS Definition- / Design a full prototype of the GAB. / M&S BOE - / 640 hours of Columbia engineer at $3724.40/w = $59,590.40 / Labor BOE- / Estimated from time required to design prototype STT FRC and BC. These boards have similar functionality to that required for the GAB. / Text9: design a full prototype of the GAB
- 84: WBS Definition- / Lay out prototype design for GAB. / M&S BOE - / 80 hours of Columbia engineer at $3724.40/w = $7,448.80 / Labor BOE- / Based on layout time for STT FRC - 4 weeks.
- 85: WBS Definition- / Procure all parts for prototype of GAB cards. / M&S BOE- / Costs for the prototype GAB are based on STT FRC cost including motherboard, BC and Link Transmitter Board. FRC costs have been multiplied by a factor of 3 to take into account the small quantity purchases required here. These components cover the basic functionality required of the GAB. Details of the components going into this cost estimate are available in the supporting material folder. Contingency is assigned based on the conceptual nature of the current GAB design. / Equipment cost = $7500, plus / 40 hours of a university technican at $2133.33/w = $2133.33 / ----- / total = $9,633.33 / Labor BOE- / Average amount of effort needed for procurement at Fermilab, based on experience of M. Johnson. Time required based on experience with long lead-time electronics purchases.
- 86: WBS Definition- / Fabricate one prototype card. / M&S BOE - / equipment = $4,500, plus / 16 hours of university electrical techician at $2133.33/w = $853.33 / --------------- / total = $5,353.33 / Labor BOE- / Based on Fab/Assembly time for STT FRC - 4 weeks. / Text9: fabriate one prototype card
- 87: WBS Definition- / Test prototype GAB by sending control signals to prototype TAB, receiving cluster information from TAB and producing the correct TFW output. Task is only complete when full TAB functionality has also been tested. / M&S BOE - / 64 hours of Columbia engineer at $3724.40/w = $5,959.04 / plus 32 hours of Columbia electrical tech at $2133.33/w = $1,706.66 / ---------- / total = $7,665.70 / Labor BOE- / Based on the amount of effort required to integrate the STT FRC and BC cards. Multiplied by a factor of 2 to account for increased complexity. / Text9: test prototype GAB with inputs from prototype TAB cards
- 88: WBS Definition- / Milestone. GAB prototype complete and passes bench tests: produces all the correct outputs for known inputs or failures understood.
- 93: WBS Definition- / Update prototype design to address any shortcomings found in testing. / M&S BOE- / 32 hours of Columbia engineer at $3724.40/w = $2,979,52 / Labor BOE- / Estimated from time required to implement final changes to FRC design after testing. / Text9: update prototype design to address any shortcomings found in testing
- 94: WBS Definition- / Procure all parts for production of GAB cards. / M&S BOE- / Costs for the prototype GAB are based on STT FRC cost including motherboard, BC and Link Transmitter Board. These components cover the basic functionality required of the GAB. Details of the components going into this cost estimate are available in the supporting material / folder. Contingency is assigned based on the conceptual nature of the current GAB design. / Parts for 2 boards = $5,000 plus / 40 hour of university eletrical technician @ $2133.33/w = $2133.33 / ------------ / total $7,133.33 / Labor BOE- / Average amount of effort needed for procurement at Fermilab, based on experience of M. Johnson. Time required based on experience with long lead-time electronics purchases. / Text9: correct and shortcomings found in prototype testing
- 95: WBS Definition- / Lay out final design for TAB cards. / M&S BOE - / 48 hours of Columbia engnineer at $3724.40/w = $4,469.28 / Labor BOE- / Based on layout time for final STT FRC - 3 weeks. Schedule extended to 6 weeks to take into account parallel work on TAB.
- 96: WBS Definition- / Fabricate and assemble production GAB. / M&S BOE - / Fabricate/Assemble 2 boards = $3,000, plus / 32 hours of university tecnician $2133.33/w = $1706.66 / ------------------ / total = $4,706.66 / Labor BOE- / Based on Fab/Assembly time for STT FRC - 4 weeks. Multiplied by a factor of 2 to account for increased board complexity.
- 97: WBS Definition- / Test full functionality of production boards at Nevis labs with pre-production TABs. Using simulated inputs, verify that all outputs of the board are as expected and that bit error rate in outputs acceptable - corresponding to approximately 1 fatal error per day at the nominal data volume. / M&S BOE - / 72 h of Columbia electrical engineer at $3724.40/w = $6703.92 plus / 24 hours of Columbia technician at $2133.33/w = $1280.00 / ---------- / total = $7,983.92 / Labor BOE- / Based on test time for first production STT FRC and BC. Multiplied by a factor of 2 to account for increased system complexity.
- 101: WBS Definition- / Cal trigger cables
- 102: WBS Definition- / Design and fabricate test cards (receiver and transmitter) plus sample cables to test cable and Channel Link chip characteristics using HP signal generator. / M&S BOE- / Cost based on similar test systems made at Nevis for cable tests. / Equipment = $3000 plus / 72 hours of Columbia engineer at 3724.40/w = 6703.92 / 24 hours of Columbia technician at $2133.33/w = $1280.00 / ---------- / total = $10,983.92 / Labor BOE- / Duration based on average amount of time for similar test systems made at Nevis.
- 103: WBS Definition- / Test ADF to TAB cable properties using signal generator at Nevis. Cables must exhibit acceptable signal degradation (no bit-errors) when run at the rate foreseen in the L1Cal (384 MHz). / M&S BOE - / 16 hours of Columbia engineer at $3724.40/w = $1,489.76 / Labor BOE- / Based on the amount of effort required for similar cable tests at Nevis.
- 104: WBS Definition- / Purchase all cables + spares required for the L1 Cal system. / M&S BOE- / Cable cost estimate taken from quote from Tyco electronics. / 240 cables + 30 spares are required at 250*$62.76/cable + 20*105.67 = $17,780.90 plus / 40 hours of Columbia technician at $2133.33/w = $2,133.33 / ---------- / total = $19,914.23 / Labor BOE- / Duration based on average amount of time for cable procurement. Labor based on average effort for purchases at Fermilab.

| ID | WBS | Task | Type | Duration | Start | Finish | Predecessors | Complete | Remaining | Baseline start | Baseline finish | Baseline duration | Total slack | Free slack | Constraint | Resources | Work | Actual work | Cost | Baseline cost | Actual cost | Text27 | Text26 | Text28 | Text29 | Text30 | Text24 |
| --- | --- | --- | --- | --- | --- | --- | --- | --- | --- | --- | --- | --- | --- | --- | --- | --- | --- | --- | --- | --- | --- | --- | --- | --- | --- | --- | --- |
| 105 | 1.2.1.6 | **TAB Crates and Services** |  | 627d | 2002-10-28 A | 2005-05-11 |  | 49% | 318.81d | 2002-08-23 | 2005-10-13 | 780d | 141d |  |  |  | 196h | 100h | 35,429.12 | 35,429.12 | 17,959.44 |  |  |  |  |  |  |
| 106 | 1.2.1.6.1 | **Prototype** |  | 101d | 2002-10-28 A | 2003-03-31 A |  | 100% |  | 2002-08-23 | 2003-01-09 | 90d |  |  |  |  | 85.6h | 85.6h | 16,469.68 | 16,469.68 | 16,469.68 | CU |  |  |  |  |  |
| 107 | 1.2.1.6.1.1 | Procure TAB crate for prototype TAB/GAB |  | 11.2w | 2002-10-28 A | 2003-01-27 A | 66FF-2w | 100% |  | 2002-08-23 | 2003-01-09 | 18w |  |  |  | ElecTechU [10%]; InKind | 44.8h | 44.8h | 11,513.12 | 11,513.12 | 11,513.12 | CU | Percent Complete | INK-OTHER |  |  |  |
| 108 | 1.2.1.6.1.2 | Procure VME CPU for prototype TAB/GAB |  | 10.2w | 2003-01-17 A | 2003-03-31 A | 66FF-6w | 100% |  | 2002-10-16 | 2002-12-20 | 9.2w |  |  |  | ElecTechU [10%]; InKind [495656%] | 40.8h | 40.8h | 4,956.56 | 4,956.56 | 4,956.56 | CU | Percent Complete | INK-OTHER |  |  |  |
| 109 | 1.2.1.6.2 | **Production** |  | 264d | 2004-04-20 A | 2005-05-11 |  | 7% | 245.58d | 2004-04-16 | 2005-10-13 | 374d | 141d |  |  |  | 110.4h | 14.4h | 18,959.44 | 18,959.44 | 1,489.76 | CU |  |  |  |  |  |
| 110 | 1.2.1.6.2.1 | Specify TAB crate/power/cooling |  | 1.8w | 2004-04-20 A | 2004-04-30 A |  | 100% |  | 2004-04-16 | 2004-05-03 | 2.4w |  |  | finish no earlier than 2004-05-03 | ElecEngU [20%]; MandSPass [148976%] | 14.4h | 14.4h | 1,489.76 | 1,489.76 | 1,489.76 | CU | Percent Complete | EQU | 1.2.1.6.2 | 1.2.1.6.2.1 |  |
| 111 | 1.2.1.6.2.2 | Procure TAB crate |  | 16w | 2005-01-20 | 2005-05-11 | 80SS+4w |  |  | 2005-06-06 | 2005-10-13 | 18.4w | 141d |  |  | ElecTechU [10%]; MandSPass | 64h |  | 12,513.12 | 12,513.12 |  | CU | Percent Complete | EQU | 1.2.1.6.2 | 1.2.1.6.2.2 |  |
| 112 | 1.2.1.6.2.3 | Procure TAB VME CPU |  | 8w | 2005-01-20 | 2005-03-16 | 80SS+4w |  |  | 2005-06-06 | 2005-08-09 | 9.2w | 181d |  |  | ElecTechU [10%]; MandSPass [495656%] | 32h |  | 4,956.56 | 4,956.56 |  | CU | Percent Complete | EQU | 1.2.1.6.2 | 1.2.1.6.2.3 |  |
| 113 | 1.2.1.7 | L1 Calorimeter Trigger TAB/GAB Prototyping Complete | milestone | 0w | 2004-05-26 A | 2004-05-26 A | 68, 87 | 100% |  | 2004-05-03 | 2004-05-03 | 0w |  |  |  |  |  |  |  |  |  |  |  |  |  |  | Trig-082803-5 |
| 114 | 1.2.1.8 | L1 Calorimeter Trigger TAB/GAB Production and Testing Complete | milestone | 0w | 2005-03-16 | 2005-03-16 | 97, 80 |  |  | 2006-01-05 | 2006-01-05 | 0w | 181d | 91d |  |  |  |  |  |  |  |  |  |  |  |  |  |
| 115 | 1.2.1.9 | **Prototype Integration** |  | 227d | 2003-07-01 A | 2004-05-28 A |  | 100% |  | 2003-07-01 | 2004-01-26 | 278d |  |  |  |  | 4037.12h | 4037.12h | 39,971.98 | 45,047.18 | 39,971.98 |  |  |  |  |  | Trig-082803-6 |
| 116 | 1.2.1.9.1 | Develop in-situ exercizing/debugging software |  | 45.4w | 2003-07-01 A | 2004-05-28 A |  | 100% |  | 2003-07-01 | 2003-11-19 | 20w |  |  | start no earlier than 2003-07-01 | ElecEngU [30%]; PhysicistU [50%]; InKind | 1452.8h | 1452.8h | 16,494.4 | 16,494.4 | 16,494.4 | MSU | Percent Complete | INK-OTHER |  |  | Trig-082803-6 |
| 117 | 1.2.1.9.2 | Prototype integration test ADF+TAB:Columbia |  | 11.4w | 2003-07-30 A | 2003-10-17 A | 8FF+2w, 68FF+2w, 91 | 100% |  | 2003-09-30 | 2003-11-03 | 5w |  |  |  | PhysicistU [10%]; ElecEngU [20%]; StudentU [50%]; InKind [297952%] | 364.8h | 364.8h | 2,979.52 | 2,979.52 | 2,979.52 | CU | Percent Complete | INK-OTHER |  |  |  |
| 118 | 1.2.1.9.3 | Prototype integration test ADF+TAB:Saclay |  | 11.4w | 2003-07-30 A | 2003-10-17 A | 117SS | 100% |  | 2003-09-30 | 2003-11-03 | 5w |  |  |  | PhysicistU [10%]; ElecEngU [20%]; StudentU [50%]; InKind [329888%] | 364.8h | 364.8h | 3,298.88 | 3,298.88 | 3,298.88 | SAC | Percent Complete | INK-FOREIGN |  |  |  |
| 119 | 1.2.1.9.4 | Prototype integration test ADF+TAB+GAB+TFW: MSU |  | 24.8w | 2003-10-20 A | 2004-04-22 A | 117 | 100% |  | 2003-11-04 | 2004-01-26 | 10w |  |  |  | PhysicistU [30%]; ElecEngU [12%]; InKind [659758%] | 416.64h | 416.64h | 6,597.58 | 6,597.58 | 6,597.58 | MSU | Percent Complete | INK-OTHER |  |  |  |
| 120 | 1.2.1.9.5 | Prototype integration test ADF+TAB+GAB+TFW: Columbia |  | 24.8w | 2003-10-20 A | 2004-04-22 A | 119SS | 100% |  | 2003-11-04 | 2004-01-26 | 10w |  |  |  | PhysicistU [10%]; ElecEngU [12%]; StudentU [50%]; InKind [595904%] | 714.24h | 714.24h | 5,959.04 | 5,959.04 | 5,959.04 | CU | Percent Complete | INK-OTHER |  |  |  |
| 121 | 1.2.1.9.6 | Prototype integration test ADF+TAB+GAB+TFW: Saclay |  | 21w | 2003-10-20 A | 2004-03-26 A |  | 100% |  | 2003-11-04 | 2004-01-26 | 10w |  |  |  | PhysicistU [10%]; ElecEngU [12%]; StudentU [50%] | 604.8h | 604.8h |  | 6,597.76 |  | SAC | Percent Complete | INK-FOREIGN |  |  |  |
| 122 | 1.2.1.9.7 | Prototype integration test ADF+TAB+GAB+TFW: Fermilab |  | 24.8w | 2003-10-20 A | 2004-04-22 A | 119SS | 100% |  | 2003-11-04 | 2004-01-26 | 10w |  |  |  | ElecTechF [12%] | 119.04h | 119.04h | 4,642.56 | 3,120 | 4,642.56 | FNAL | Percent Complete | EQU | 1.2.1.9.7 | 1.2.1.9.7 |  |
| 123 | 1.2.1.10 | **Pre-Production Integration** |  | 218d | 2004-04-15 A | 2005-03-03 |  | 1% | 214.93d | 2004-09-01 | 2005-02-08 | 104d | 190d |  |  |  | 636h | 4h | 23,856.71 | 18,784.67 |  |  |  |  |  |  |  |
| 124 | 1.2.1.10.1 | Pre-production integration test ADF+TAB+TFW: MSU |  | 4w | 2005-01-28 | 2005-02-24 | 74, 87, 100FS-3w, 33 |  |  | 2004-09-01 | 2004-10-06 | 5w | 0d |  |  | PhysicistU; ElecEngU [130%]; MandSPass | 368h |  | 12,693.19 | 3,298.79 |  | MSU | Percent Complete | EQU | 1.2.1.10.1 | 1.2.1.10.1 |  |
| 125 | 1.2.1.10.2 | Pre-production integration test ADF+TAB+TFW: Columbia |  | 4w | 2005-01-28 | 2005-02-24 | 124SS |  |  | 2004-09-01 | 2004-10-06 | 5w | 195d |  |  | ElecEngU [20%]; PhysicistU [30%]; MandSPass [297952%] | 80h |  | 2,979.52 | 2,979.52 |  | CU | Percent Complete | EQU | 1.2.1.10.2 | 1.2.1.10.2 |  |
| 126 | 1.2.1.10.3 | Pre-production integration test ADF+TAB+TFW: Saclay |  | 1d | 2004-04-15 A | 2004-04-15 A |  | 100% |  | 2004-09-01 | 2004-10-06 | 5w |  |  | start no earlier than 2004-09-01 | ElecEngU [20%]; PhysicistU [30%] | 4h | 4h |  | 3,298.36 |  | SAC | Percent Complete | INK-FOREIGN |  |  |  |
| 127 | 1.2.1.10.4 | Pre-production integration test ADF+TAB+TFW: Fermilab |  | 4w | 2005-01-28 | 2005-02-24 | 124SS |  |  | 2004-09-01 | 2004-10-06 | 5w | 195d |  |  | ElecTechF [60%] | 96h |  | 3,744 | 4,680 |  | FNAL | Percent Complete | EQU | 1.2.1.10.4 | 1.2.1.10.4 |  |
| 128 | 1.2.1.10.5 | Production readiness review |  | 1w | 2005-02-25 | 2005-03-03 | 124 |  |  | 2005-02-01 | 2005-02-08 | 1.2w | 0d |  |  | ElecEngU; PhysicistU; MandSPass [400000%] | 80h |  | 4,000 | 4,000 |  | CU | Percent Complete | EQU | 1.2.1.10.5 | 1.2.1.10.5 |  |
| 129 | 1.2.1.10.6 | Production readiness review |  | 1w | 2005-02-25 | 2005-03-03 | 128SS |  |  | 2005-02-01 | 2005-02-08 | 1.2w | 190d |  |  | ElecEngF [20%] | 8h |  | 440 | 528 |  | FNAL | Percent Complete | EQU | 1.2.1.10.6 | 1.2.1.10.6 |  |

Notes:
- 105: WBS Definition-
- 107: WBS Definition- / Procure one 9U VME crate + VIPA backplane for use in testing prototype TABs and GABs at Nevis. / M&S BOE- / Cost ($8,100) based on similar crate+backplane purchased for STT system. Crate (sub-rack) cost was $4690 while VIPA backplane was $3375. Power supply will be taken from Nevis labs stock. / Equipment = $8100 plus / 64 hours of Columbia technician at $2133.33/w = $3413.33 / ---------- / total = $11,513.33 / Labor BOE- / Duration based on amount of time required to purchase similar crates for the STT project. Labor based on average effort for purchases at Fermilab.
- 108: WBS Definition- / Procure one VME CPU for use in testing prototype TABs and GABs at Nevis. / M&S BOE- / Cost based on similar CPU purchased for STT system. / Equipment = $3250 plus / 32 hours of university technician at $2133.33/w = $1706.66 / ---------- / total = $4,956.66 / Labor BOE- / Duration based on amount of time required to purchase CPUs for the STT project. Labor based on average effort for purchases at Fermilab.
- 110: WBS Definition- / Produce final specification for power, cooling and related services for TAB/GAB crate to be used at Fermilab. / M&S BOE- / Time estimate takes into account two iterations with Fermilab engineers on these spec's. Cost is based on 16 hours of university engineer at $3891.30/w = $1,556.52
- 111: WBS Definition- / Procure one 9U VME crate + VIPA backplane for use in final system at Fermilab. / M&S BOE- / Cost based on similar crate+backplane purchased for STT system. Crate (sub-rack) cost was $4690 while VIPA backplane was $3410. Power supply and cooling estimated to cost $1000 based on similar components in L1muon system. / Equipment = $9100 plus / 64 hours of electrical tech at $2133.33/w = $3413.33 / ------ / total = 12,513.33 / Labor BOE- / Duration based on amount of time required to purchase similar crates for the STT project. Labor based on average effort for purchases at Fermilab.
- 112: WBS Definition- / Procure one VME CPU for use in TAB/GAB crate at Fermilab. / M&S BOE- / Cost based on similar CPU purchased for STT system ($3250) / Equipment = $3250 plus / 32 hour of university technical at $2133.33/w = $1706.66 / -------------- / total = $4,956.66 / Labor BOE- / Duration based on amount of time required to purchase CPUs for the STT project. Labor based on average effort for purchases at Fermilab.
- 113: WBS Definition- / Milestone. Achieved when 8 production TABs and 1 production GAB pass all benchmark tests. / Text9: milestone
- 114: WBS Definition- / Milestone. Achieved when 8 production TABs and 1 production GAB pass all benchmark tests. / Text9: milestone
- 115: WBS Definition- / This summary task describes the first stage of a series of tests which combine different boards and eventually the DZero trigger framework (TFW) to ensure that they all work together properly. / Risk Mitigation (schedule)- / The impact of integration taking longer than expected is reduced by putting this task as early in the project as possible. Additionally, prototype integration tests are planned to mimic as closely as possible data taking in the D0 environment, including the use of real data from the BLS (via splitter cards) and real timing signals from the Trigger Framework.
- 116: WBS Definition- / Develop special in situ test and diagnostic software that cycles the system at design speed and verifies that the hardware gets the right answer. / M&S BOE- / 400 hours of university engineer at $4123.49/w = $41,234.93 / Labor BOE- / Based on similar software development for existing L1Cal.
- 117: Definition- / Test prototype TAB with signals from prototype ADF. Test is complete when signals from all 32 channels from two or more ADFs are received at a TAB with no data correuption. This item represents the Columbia part of the effort. / M&S BOE - / 32 hours Columbia engineer at $3724.40/w = $2,979.52 / Labor BOE- / Based on the amount of effort required to STT FRC to the STT STC and TFC. These transmissions also involved LVDS technology. An extra 2 weeks is assigned above the STT time because of the higher transmission frequency in the L1 Cal system. / Text9: test prototype TAB in test stand with input signals from prototype ADF
- 118: WBS Definition- / Same as above, but for Saclay effort required. / M&S BOE - / 32 hours Saclay engineer at $4122.95/w = $3,298.36 / Labor BOE- / Same as above. / Text9: test prototype TAB in test stand with input signals from prototype ADF
- 119: WBS Definition- / Test all prototype elements of L1Cal with timing signals sent from the TFW. Multiple test data events should be sent through the ADF-TAB-GAB chain using timing derived from the SCL. GAB output should be as expected for ADF test input and should be correctly received at the TFW. This item represents the MSU part of the effort. / M&S BOE- / 64 h of MSU engineer at $4123.49/w = $6597.58 / Labor BOE- / Based on the amount of interaction with TFW experts during the STT integration. This effort has been scaled up by approximately a factor of 4 to take into account the more complicated interface between the L1Cal and TFW. 64 h of fermilab technician is used for this task. / Text9: test prototype TAB, GAB and ADF with control signals from the real Dzero trigger framework
- 120: WBS Definition- / Same as above, but for Columbia effort required. / M&S BOE - / 64 h of Columbia engineer at $3724.40/w = $5,959.04 / Labor BOE- / Based on experience integrating the STT FRC and TFC. Three periods of integration work of 1 week at Fermilab are assumed separated by 2-week intervals for modifications to the boards/firmware at Nevis and Saclay. Contingency is assigned to take into account the possible need for an extra round of changes to the boards at the universities. / Text9: test prototype TAB, GAB and ADF with control signals from the real Dzero trigger framework
- 121: WBS Definition- / Same as above, but for Saclay effort required. / M&S BOE - / 64 h of Saclay engineer at $4122.95/w = $6,596.72 / Labor BOE- / Same as above. / In-Kind costs were removed for this task on 16 April 2004 and the task was closed out due to Saclay's withdrawal from the Project. / Text9: test prototype TAB, GAB and ADF with control signals from the real Dzero trigger framework
- 122: WBS Definition- / Same as above, but for Saclay effort required. / M&S BOE - / n/a / Labor BOE- / 64 hours for fermilab electrical tech time
- 123: WBS Definition- / This summary task describes the second stage of a series of tests which combine different boards and eventually the DZero trigger framework (TFW) to ensure that they all work together properly. / Risk Mitigation (schedule)- / Impact on the schedule of mis-estimates of the time required to complete this task is minimized by performing as much of the integration as possible with prototype boards (1.2.1.9).
- 124: WBS Definition- / Same as for 1.2.1.9.2, but for first round of production boards. / M&S BOE - / 41 h of MSU engineer at $4123.49/w = $4,226.58 / New estimate = $12,405.19 / Labor BOE- / Estimated to be half of the prototype integration time. 32 h of fermilab technician included. / Updated 19 April 2004 by T.J. Sarlina with information from Darien Wood. / Text9: repeat framework integration test with production versions of ADF, TAB, GAB
- 125: WBS Definition- / Same as above, but for Columbia effort / M&S BOE - / 42 h of Columbia engineer at $3724.40/w = $3,910.62 / Labor BOE- / Estimated to be half of the prototype integration time. Contingency is assigned to take into account the possible need for an extra round of changes to the boards at the universities. 32 h of fermilab technician included. / Text9: repeat framework integration test with production versions of ADF, TAB, GAB
- 126: WBS Definition- / Same as above, but for Saclay effort / M&S BOE- / 32 h of Saclay engineer at $4122.95/w = $3298.36 / Labor BOE- / Same as above. / In-Kind costs were removed for this task on 16 April 2004 and the task was closed out due to Saclay's withdrawal from the Project. / Text9: repeat framework integration test with production versions of ADF, TAB, GAB
- 127: WBS Definition- / Same as above, but for Fermilab effort / M&S BOE- / n/a / Labor BOE- / 96 hours of fermilab electrical tech time
- 128: WBS Definition- / Review to determine readiness of L1Cal system to go into production. / M&S BOE- / 40 h of university engineer at $100/h = $4000 / Labor BOE-
- 129: WBS Definition- / Review to determine readiness of L1Cal system to go into production- Fermilab part / M&S BOE- / n/a / Labor BOE- / 1 day of a fermilab electrical engineer

| ID | WBS | Task | Type | Duration | Start | Finish | Predecessors | Complete | Remaining | Baseline start | Baseline finish | Baseline duration | Total slack | Free slack | Constraint | Resources | Work | Actual work | Cost | Baseline cost | Actual cost | Text27 | Text26 | Text28 | Text24 | Text29 | Text30 | Text23 |
| --- | --- | --- | --- | --- | --- | --- | --- | --- | --- | --- | --- | --- | --- | --- | --- | --- | --- | --- | --- | --- | --- | --- | --- | --- | --- | --- | --- | --- |
| 130 | 1.2.1.11 | **L1 Cal Online Software** |  | 475d | 2003-04-15 A | 2005-03-15 |  | 53% | 223.41d | 2003-01-06 | 2005-07-07 | 625d | 182d |  |  |  | 2548h | 1349.6h |  |  |  | NEU |  |  |  |  |  |  |
| 131 | 1.2.1.11.1 | ADF online software |  | 95w | 2003-04-15 A | 2005-03-15 |  | 68% | 30w | 2003-01-06 | 2005-07-07 | 125w | 182d |  | start no earlier than 2003-04-15 | PostdocU [25%]; PhysicistU [10%] | 1330h | 910h |  |  |  | NEU | Percent Complete | INK-OTHER |  |  |  |  |
| 132 | 1.2.1.11.2 | TAB/GAB online software |  | 87w | 2003-06-11 A | 2005-03-15 |  | 36% | 55.6w | 2003-01-06 | 2005-07-07 | 125w | 182d |  | start no earlier than 2003-06-11 | PostdocU [25%]; PhysicistU [10%] | 1218h | 439.6h |  |  |  | NEU | Percent Complete | INK-OTHER |  |  |  |  |
| 133 | 1.2.1.12 | L1 Calorimeter Trigger Production And Testing Complete | milestone | 0w | 2005-07-25 | 2005-07-25 | 46, 114 |  |  | 2006-01-05 | 2006-01-05 | 0w | 90d | 6d |  |  |  |  |  |  |  |  |  |  |  |  |  |  |
| 134 | 1.2.2 | **Level 1 Calorimeter Track Matching** |  | 726d | 2002-08-01 A | 2005-07-06 |  | 62% | 272.83d | 2002-08-01 | 2004-09-23 | 534d | 103d |  |  |  | 17247.1h | 13836.2h | 248,754.86 | 254,355.8 | 185,826 |  |  |  |  |  |  |  |
| 135 | 1.2.2.1 | **D0 Reviews** |  | 37d | 2003-06-12 A | 2003-08-05 A |  | 100% |  | 2003-06-12 | 2003-08-05 | 93d |  |  |  |  | 48h | 48h | 2,440 | 2,528 | 2,440 |  |  |  | Trig-082803-7 |  |  |  |
| 136 | 1.2.2.1.1 | D0 Internal Design Review Complete | milestone | 0w | 2003-06-12 A | 2003-06-12 A |  | 100% |  | 2003-01-23 | 2003-01-23 | 0w |  |  | start no earlier than 2003-06-16 |  |  |  |  |  |  |  |  |  |  |  |  |  |
| 137 | 1.2.2.1.2 | D0 Production Readiness Review |  | 1w | 2003-07-30 A | 2003-08-05 A |  | 100% |  | 2003-07-30 | 2003-08-05 | 1w |  |  | start no earlier than 2003-07-30 | ElecEngU [50%]; PhysicistU [50%]; MandSPass [200000%] | 40h | 40h | 2,000 | 2,000 | 2,000 | AZ | Percent Complete | EQU | Trig-082803-7 | 1.2.2.1.2 | 1.2.2.1.2 |  |
| 138 | 1.2.2.1.3 | D0 Production Readiness Review |  | 1w | 2003-07-30 A | 2003-08-05 A | 137SS | 100% |  | 2003-07-30 | 2003-08-05 | 1w |  |  |  | ElecEngF [20%] | 8h | 8h | 440 | 528 | 440 | FNAL | Percent Complete | EQU | Trig-082803-7 | 1.2.2.1.3 | 1.2.2.1.3 |  |
| 139 | 1.2.2.2 | L1 Trigger Cal-Trk Match R&D MOU (UAZ) Complete | milestone | 0w | 2003-03-14 A | 2003-03-14 A |  | 100% |  | 2002-11-01 | 2002-11-01 | 0w |  |  | start no earlier than 2003-03-14 |  |  |  |  |  |  |  |  |  |  |  |  |  |
| 140 | 1.2.2.3 | L1 Trigger Cal-Trk Match Equipment MOU (UAZ) Complete | milestone | 0w | 2003-03-14 A | 2003-03-14 A |  | 100% |  | 2003-01-21 | 2003-01-21 | 0w |  |  | start no earlier than 2003-03-14 |  |  |  |  |  |  |  |  |  |  |  |  |  |
| 141 | 1.2.2.4 | **SLDB** |  | 270d | 2003-03-14 A | 2004-04-13 A |  | 100% |  | 2003-01-21 | 2003-12-04 | 218d |  |  |  |  | 397.6h | 397.6h | 43,742.6 | 43,742.6 | 43,742.6 | AZ |  |  | Trig-082803-8 |  |  |  |
| 142 | 1.2.2.4.1 | Procure SLDB parts |  | 19w | 2003-03-14 A | 2003-07-28 A | 140 | 100% |  | 2003-01-21 | 2003-03-25 | 9.2w |  |  |  | ElecEngU [5%]; MandSPass | 38h | 38h | 29,153.22 | 29,153.22 | 29,153.22 | AZ | Percent Complete | EQU |  | 1.2.2.4 | 1.2.2.4.1 |  |
| 143 | 1.2.2.4.2 | Fabricate and assemble SLDBs |  | 33w | 2003-06-16 A | 2004-02-17 A | 142FF+4w | 100% |  | 2003-06-16 | 2003-10-07 | 16w |  |  |  | ElecEngU [3%]; MandSPass | 39.6h | 39.6h | 11,419.14 | 11,419.14 | 11,419.14 | AZ | Percent Complete | EQU | Trig-082803-8 | 1.2.2.4 | 1.2.2.4.2 |  |
| 144 | 1.2.2.4.3 | Test SLDBs |  | 8w | 2004-02-18 A | 2004-04-13 A | 143 | 100% |  | 2003-10-08 | 2003-12-04 | 8w |  |  |  | ElecTechU [60%]; ElecEngU [20%]; PhysicistU [20%]; MandSPass [317024%] | 320h | 320h | 3,170.24 | 3,170.24 | 3,170.24 | AZ | Percent Complete | EQU | Trig-082803-8 | 1.2.2.4 | 1.2.2.4.3 |  |
| 145 | 1.2.2.5 | **MTCxx** |  | 541d | 2003-03-14 A | 2005-05-16 |  | 71% | 157.02d | 2003-03-14 | 2004-09-23 | 420d | 138d |  |  |  | 6478.4h | 5486.4h | 54,708 | 50,580.9 | 36,097.14 | AZ |  |  | Trig-082803-9 |  |  |  |
| 146 | 1.2.2.5.1 | (Small) design changes to MTCxx |  | 41w | 2003-03-14 A | 2004-01-12 A | 140 | 100% |  | 2003-03-14 | 2003-09-09 | 25w |  |  | start no earlier than 2002-09-03 | ElecEngU [257%]; MandSPass [229632%] | 4214h | 4214h | 2,296.32 | 2,296.32 | 2,296.32 | AZ | Percent Complete | EQU | Trig-082803-9 | 1.2.2.5 | 1.2.2.5.1 |  |
| 147 | 1.2.2.5.2 | Procure MTCxx parts |  | 16w | 2003-06-09 A | 2003-09-30 A | 146, 139 | 100% |  | 2003-06-09 | 2003-09-02 | 12w |  |  |  | ElecEngU [10%]; MandSPass | 64h | 64h | 23,325.38 | 23,325.38 | 23,325.38 | AZ | Percent Complete | EQU | Trig-082803-9 | 1.2.2.5 | 1.2.2.5.2 |  |
| 148 | 1.2.2.5.3 | Fabricate and assemble preproduction MTCxx |  | 11.2w | 2004-01-13 A | 2004-03-31 A | 147, 146 | 100% |  | 2003-09-03 | 2003-10-14 | 6w |  |  |  | ElecEngU [5%]; MandSPass [400504%] | 22.4h | 22.4h | 4,005.04 | 4,005.04 | 4,005.04 | AZ | Percent Complete | EQU | Trig-082803-9 | 1.2.2.5 | 1.2.2.5.3 |  |
| 149 | 1.2.2.5.4 | Fabrication and Assembly of L1 Trigger Cal-Trk Match Preproduction MTCxx Complete | milestone | 0w | 2004-03-31 A | 2004-03-31 A | 148 | 100% |  | 2003-10-14 | 2003-10-14 | 0w |  |  |  |  |  |  |  |  |  |  |  |  | Trig-082803-9 |  |  |  |
| 150 | 1.2.2.5.5 | Test preproduction MTCxx |  | 25w | 2004-04-01 A | 2004-09-27 | 149 | 90% | 2.5w | 2004-04-01 | 2004-08-20 | 20w | 143d | 0d |  | ElecTechU [80%]; ElecEngU [30%]; PhysicistU [20%]; MandS [532224%] | 1300h | 1170h | 5,322.24 | 5,322.24 | 5,322.24 | AZ | Percent Complete | EQU | Trig-082803-9 | 1.2.2.5 | 1.2.2.5.5 | CC |
| 151 | 1.2.2.5.6 | Final design changes to MTCxx |  | 5w | 2004-08-23 A | 2004-09-27 | 150FS-5w | 20% | 4w | 2004-08-23 | 2004-09-27 | 5w | 138d | 0d |  | ElecEngU [40%]; MandSPass [114816%] | 80h | 16h | 1,148.16 | 1,148.16 | 1,148.16 | AZ | Percent Complete | EQU | Trig-082803-9 | 1.2.2.5 | 1.2.2.5.6 |  |
| 152 | 1.2.2.5.7 | Fabricate and assemble MTCxx's |  | 15w | 2004-09-28 | 2005-01-24 | 151, 137 |  |  | 2004-09-28 | 2005-01-24 | 15w | 138d | 0d |  | ElecEngU [5%]; MandSPass [850072%] | 30h |  | 8,500.72 | 8,500.72 |  | AZ | Percent Complete | EQU |  | 1.2.2.5 | 1.2.2.5.7 |  |
| 153 | 1.2.2.5.8 | Fabrication and Assembly of L1 Trigger Cal-Trk Match MTCxx's Complete | milestone | 0w | 2005-01-24 | 2005-01-24 | 152 |  |  | 2005-01-24 | 2005-01-24 | 0w | 138d | 0d |  |  |  |  |  |  |  |  |  |  |  |  |  |  |
| 154 | 1.2.2.5.9 | Test MTCxx's |  | 16w | 2005-01-25 | 2005-05-16 | 153 |  |  | 2005-01-25 | 2005-05-16 | 16w | 138d | 0d |  | ElecEngU [20%]; ElecTechU [80%]; PhysicistF [20%]; MandSPass | 768h |  | 10,110.14 | 10,110.14 |  | AZ | Percent Complete | EQU |  | 1.2.2.5 | 1.2.2.5.9 |  |

Notes:
- 130: WBS Definition- / Develop software for controls, downloading, online diagnostics of L1 Cal system. This includes downloading information from the hardware database, setting up monitoring via the EPICs system, establishing a secondary data acquisition system for recording events without the level 3 system.
- 131: WBS Definition - / Write/modify the particular code and data structures that are necessary to operate and monitor the ADF system in the Dzero online environment. This includes downloading information from the hardware database, setting up monitoring via the EPICs system, establishing a secondary data acquisition system for recording events without the level 3 system. / Labor BOE- / Based on similar tasks for the run2a muon system, which required 50% of a post doc plus 10% of a professor for two years. Since much of the infrastucture is already in place, and similar efforts with the TAB system can be done in conjunction, only 25% of a postdoc is expected to be requires, assuming that another 25% of the same person is spent on TAB online software.
- 132: WBS Definition- / Write/modify the particular code and data structures that are necessary to operate and monitor the TAB/GAB system in the Dzero online environment. This includes downloading information from the hardware database, setting up monitoring via the EPICs system, establishing a secondary data acquisition system for recording events without the level 3 system. / Labor BOE- / Based on similar tasks for the run2a muon system, which required 50% of a post doc plus 10% of a professor for two years. Since much of the infrastucture is already in place, and similar efforts with the ADF system can be done in conjunction, only 25% of a postdoc is expected to be requires, assuming that another 25% of the same person is spent on ADF online software.
- 133: WBS Definition- / Milestone: All L1 Cal components produced or procured. Full functionality of custom boards (ADF, TAB, GAB) bench tested at institutes where they were developed. Tests consist of using simulated inputs to verify that all the outputs of the board are as expected and that bit error rates are acceptable - corresponding to approximately 1 fatal error per day at nominal data volumes. Milestone is achieved when the number of boards required in the system (80 ADFs, 8 TABs and 1 GAB) have passed the bench tests above.
- 134: WBS Definition- / This summary element provides for improvements in the Run2a track-matching trigger. It includes development and procurement of slightly modified versions of existing Level 1 muon cards, and procurement of related cabling, connectors, readout crates, processors, and power supplies. / Text9: This summary element provides for improvements in the Run2a track-matching trigger. It includes development and procurement of slightly modified versions of existing Level 1 muon cards, and procurement of related cabling, connectors, readout crates, pro
- 135: WBS Definition- / milestone: a review by D0 electronics experts (inside and outside of the project) ensures that the design is sound and meets all of the specifications for operation in the D0 trigger and data acquisition systems.
- 136: WBS Definition / D0 internal design review with Fermilab, L1CTT, and L1Cal engineers
- 137: WBS Definition / D0 production readiness review before start of MTCxx, MTCM, and MTFB production / M&S BOE- / 20 h of university engineer at $100/h = $2000 / Labor BOE- / n/a
- 138: WBS Definition / D0 production readiness review before start of MTCxx, MTCM, and MTFB production - Fermilab part / M&S BOE- / n/a / Labor BOE- / 1 day of fermilab engineer included.
- 139: WBS Definition- / milestone: R&D MOU with University of Arizona is signed
- 140: WBS Definition- / milestone: Equipment MOU with University of Arizona is signed.
- 141: WBS Definition- / This summary task covers the fabrication of the Serial Link Daughter Boards that are needed to transmit and receive signals between the L1CTT, L1Cal, and the L1 Cal-Trk Trigger / Text9: This summary task covers the fabrication of the Serial Link Daughter Boards that are needed for this subsystem to receive TFW signals over the Serial Command Link
- 142: WBS Definition / Procure the parts needed for all of the serial link daughter boards / M&S Labor BOE / Same engineer as in run2a will be responsible for procurement / and has all records of prices and vendors / M&S labor = 32 hours of EEU = $382.72 / M&S labor pays 20% of EEU salary + ere + overhead, university 80% / M&S Equipment BOE / 17*8+1=137 transmitter boards @ $103.4 = $14165.8 / 17*11 = 187 receiver boards @ $78.1 = $14604.7 / total $28770.50 / unit costs based on actual costs of SLDB parts in run2a * 1.1 / (see BOE binder for detailed breakdown). / M&S total = $29153.22
- 143: WBS Definition / fabricate and assemble the serial link daughter boards that are needed for the / cal-track matching system / M&S Labor BOE / Same engineer as in run2a will be responsible for tracking the fabrication / and assembly. / M&S labor = 26.4h of an EEU = $315.74 / M&S labor pays only 20% of EEU salary + ere + overhead, university 80% / M&S Equipment BOE- / 137 transmitter boards @ $33 = $4521 / 187 receiver boards @ $35.2 = $6582.4 / ------------------ / Total $11103.4 / unit costs based on actual costs of SLDB fabrication and assemply in run2a / (see BOE binder for PO) / M&S total = $11419.14 / Text9: fabricate the serial link daughter boards that are needed for the cal-track matching system
- 144: WBS Definition- / Test the serial link daughter boards with stand-alone serial link tester. / M&S Labor BOE- / From run2a, approximately 10 min/board was required for good boards = 55 hours for 324 boards. Additional 200 hours are allowed for debugging and repair of faulty boards. / M&S labor = 64h of EEU and 192h of ETU = $3170.24 / M&S labor pays 20% of EEU salary + ere + overhead, university 80% / M&S labor pays full ETU salary + ere + overhead / M&S Equipment BOE- / no M&S equipment / M&S total = $3170.24 / Text9: fabricate the serial link daughter boards that are needed for the cal-track matching system
- 145: WBS Definition- / This summary task describes the design, fabrication, and testing of the MTCxx cards which receive inputs from the level 1 tracking and calorimeter systems and determine matches.
- 146: WBS Definition- / modify existing MTCxx design (which does muon-track matcing in run 2a) for the "no MTCM mode" to reduce trigger latency and add 1-2 additional receivers / M&S Labor BOE / Time estimate based the labor required for the design changes between the prototype and production versions of the Run2a MTCxx. The same engineer will be doing the design changes. / M&S labor = 192h of EEU = $2296.32 / M&S labor pays 20% of EEU salary + ere + overhead, university 80% / M&S Equipment BOE / no M&S associated with this task / M&S total = $2296.32 / Text9: modify existing MTCxx design for cal matching application
- 147: WBS Definition- / procure the parts to build all MTCxx cards needed by the cal-track matching system, including prototypes and spares. / M&S Labor BOE- / Same engineer as in run2a will be responsible for procurement and has all records of prices and vendors. / M&S labor = 48h of EEU = $574.08 / M&S labor pays 20% of EEU salary + ere + overhead, university 80% / M&S Equipment BOE / The cost is based on parts cost for the actual Run 2a MTCxx x 1.1. / See BOE binder for detailed itemization of costs. / 13 cards @ $1750.1 = $22751.3 / M&S total = $23325.38
- 148: WBS Definition- / Fabricate and assemble two prototype MTCxx boards / M&S Labor BOE- / Same engineer as in run2a will be responsible for tracking the fabrication and assembly. / M&S labor = 24h = $287.04 / M&S labor pays 20% of EEU salary + ere + overhead, university 80% / M&S Equipment BOE- / 2 boards @ $1859 = $3718 / M&S total = $4005.04 / Unit costs based on small-quantity fabrication. See quotes and PO in BOE binder. Fabrication costs are based on an average of 2 quotes
- 149: WBS Definition- / milestone: track prototyping status of MTCxx card
- 150: WBS Definition / Test functionality of prototype MTCxx card on existing Level-1 muon test stand. / M&S Labor BOE- / Based on the time required to test the pre-production MTCxx card in run 2a / M&S labor = 96h of EEU and 256h of ETU = $4354.56 / M&S labor pays 20% of EEU salary + ere + overhead, university 80% / M&S labor pays full ETU salary + ere + overhead / M&S Equipment BOE- / n/a / M&S total = $4354.56
- 151: WBS Definition- / Update MTCxx design for problems identified in the prototype testing / M&S Labor BOE- / Time estimate based the labor required for the design changes between the prototype and production versions of the Run2a MTCxx, scaled down to one third. The same engineer will be doing the design changes / M&S labor = 96h of EEU = $1148.16 / M&S labor pays 20% of EEU salary + ere + overhead, university 80% / M&S Equipment BOE- / No M&S equipment associated with this task / M&S total = $1148.16
- 152: WBS Definition- / Fabricate 11 MTCxx boards, including 2 spares. / M&S Labor BOE- / Same engineer as in run2a will be responsible for tracking the fabrication and assembly. / M&S labor = 32h of EEU = $382.72 / M&S labor pays 20% of EEU salary + ere + overhead, university 80% / M&S Equipment BOE / 11 cards @ $738 = $8118 / Unit costs based on actual costs of MTCxx fabrication and assemply in run2a. See quotes and PO's in BOE binder. Fabrication costs are based on an average of 2 quotes / M&S total = $8500.72 / Text9: fabricate n boards, includeing m spares
- 153: WBS Definition- / milestone: to track production status of MTCxx cards
- 154: WBS Definition- / Test functionality of MTCxx cards on the Level1 muon test stand. / M&S Labor BOE- / Based on Run2a MTCxx rate of 2 days/board (full time) for testing and quick fixes, plus 8 weeks (part time) for fixing more complex problems. / M&S labor = 112h of EEU and 448h of ETU = $6950.72 / M&S labor pays only 20% of EEU salary + ere + overhead, university 80% / M&S labor pays full ETU salary + ere + overhead / M&S Equipment BOE- / There are no M&S equipment costs associated with this task / M&S total = $6950.72 / Text9: fabricate n boards, includeing m spares

| ID | WBS | Task | Type | Duration | Start | Finish | Predecessors | Complete | Remaining | Baseline start | Baseline finish | Baseline duration | Total slack | Free slack | Constraint | Resources | Work | Actual work | Cost | Baseline cost | Actual cost | Text24 | Text27 | Text9 | Text26 | Text28 | Text29 | Text30 | Text23 |
| --- | --- | --- | --- | --- | --- | --- | --- | --- | --- | --- | --- | --- | --- | --- | --- | --- | --- | --- | --- | --- | --- | --- | --- | --- | --- | --- | --- | --- | --- |
| 155 | 1.2.2.6 | **MTCM** |  | 312d | 2003-10-20 A | 2005-01-28 |  | 74% | 80.52d | 2003-10-20 | 2004-07-13 | 241d | 214d |  |  |  | 504h | 312h | 17,729.76 | 16,007.52 | 14,285.28 | Trig-082803-9 | AZ |  |  |  |  |  |  |
| 156 | 1.2.2.6.1 | (Small) design changes to MTCM |  | 30w | 2003-10-20 A | 2004-05-28 A | 140 | 100% |  | 2003-10-20 | 2004-05-28 | 30w |  |  | start no earlier than 2003-10-20 | ElecEngU [22%]; MandSPass [114816%] | 264h | 264h | 1,148.16 | 1,148.16 | 1,148.16 | Trig-082803-9 | AZ | modify existing MTCM design for cal matching application | Percent Complete | EQU | 1.2.2.6 | 1.2.2.6.1 |  |
| 157 | 1.2.2.6.2 | Procure MTCM parts |  | 8w | 2004-04-05 A | 2004-05-28 A | 156FS-8w | 100% |  | 2004-04-05 | 2004-05-28 | 8w |  |  |  | ElecEngU [10%]; MandSPass [862608%] | 32h | 32h | 8,626.08 | 8,626.08 | 8,626.08 | Trig-082803-9 | AZ |  | Percent Complete | EQU | 1.2.2.6 | 1.2.2.6.2 |  |
| 158 | 1.2.2.6.3 | Fabricate and assemble MTCMs |  | 8w | 2004-06-01 A | 2004-07-27 A | 157, 137 | 100% |  | 2004-06-01 | 2004-07-27 | 8w |  |  |  | ElecEngU [5%]; MandSPass [451104%] | 16h | 16h | 4,511.04 | 4,511.04 | 4,511.04 | Trig-082803-9 | AZ | fabricate n boards, includeing m spares | Percent Complete | EQU | 1.2.2.6 | 1.2.2.6.3 |  |
| 159 | 1.2.2.6.4 | Fabrication and Assembly of L1 Trigger Cal-Trk Match MTCM's Complete | milestone | 0w | 2004-07-27 A | 2004-07-27 A | 158 | 100% |  | 2004-07-27 | 2004-07-27 | 0w |  |  |  |  |  |  |  |  |  | Trig-082803-9 |  |  |  |  |  |  |  |
| 160 | 1.2.2.6.5 | Test MTCMs |  | 16w | 2004-09-27 | 2005-01-28 | 159FS+8.4w |  |  | 2004-07-28 | 2005-01-26 | 24w | 214d |  |  | ElecEngU [30%]; MandSPass [344448%] | 192h |  | 3,444.48 | 3,444.48 |  | Trig-082803-9 | AZ | fabricate n boards, includeing m spares | Percent Complete | EQU | 1.2.2.6 | 1.2.2.6.5 |  |
| 161 | 1.2.2.7 | **MT Flavor Board** |  | 691d | 2002-08-01 A | 2005-05-16 |  | 81% | 133.28d | 2002-08-01 | 2004-02-10 | 353d | 138d |  |  |  | 8212.41h | 7283.21h | 35,301.45 | 32,513.93 | 23,180.37 | Trig-082803-10 |  |  |  |  |  |  |  |
| 162 | 1.2.2.7.1 | Design prototype cal-trk algorithm |  | 31.4w | 2002-08-01 A | 2003-03-24 A |  | 100% |  | 2002-08-01 | 2003-01-15 | 22w |  |  | start no earlier than 2002-08-01 | PhysicistU [25%] | 314h | 314h |  |  |  |  | AZ |  | Percent Complete | INK-OTHER |  |  |  |
| 163 | 1.2.2.7.2 | **Prototype** |  | 482d | 2002-10-17 A | 2004-09-27 |  | 96% | 17.02d | 2002-10-17 | 2003-09-09 | 184d | 293d |  |  |  | 7300h | 6962.8h | 14,557.28 | 14,557.28 | 14,557.28 | Trig-082803-10 | AZ |  |  |  |  |  |  |
| 164 | 1.2.2.7.2.1 | Design prototype MTFB |  | 13.4w | 2002-10-17 A | 2003-01-31 A | 136SS-12w | 100% |  | 2002-10-17 | 2003-03-07 | 18.4w |  |  |  | ElecEngU [30%]; PhysicistU [20%]; ElecTechU [50%]; MandS [630432%] | 536h | 536h | 6,304.32 | 6,304.32 | 6,304.32 |  | AZ | design new flavor board for cal-track matching | Percent Complete | R&D |  |  |  |
| 165 | 1.2.2.7.2.2 | Procure prototype MTFB parts |  | 4w | 2003-06-02 A | 2003-06-27 A | 164, 139, 162 | 100% |  | 2003-03-10 | 2003-04-09 | 4.6w |  |  | start no earlier than 2003-06-02 | ElecEngU [5%]; MandS [163568%] | 8h | 8h | 1,635.68 | 1,635.68 | 1,635.68 |  | AZ |  | Percent Complete | R&D |  |  |  |
| 166 | 1.2.2.7.2.3 | Fabricate and assemble prototype MTFB |  | 6w | 2003-06-30 A | 2003-08-11 A | 165, 136 | 100% |  | 2003-06-30 | 2003-08-11 | 6w |  |  |  | ElecEngU [5%]; MandS [463136%] | 12h | 12h | 4,631.36 | 4,631.36 | 4,631.36 | Trig-082803-10 | AZ | fabricate n boards, includeing m spares | Percent Complete | R&D |  |  |  |
| 167 | 1.2.2.7.2.4 | Fabrication and Assembly of L1 Trigger Cal-Trk Match Prototype MTFB Complete | milestone | 0w | 2003-08-11 A | 2003-08-11 A | 166 | 100% |  | 2003-08-11 | 2003-08-11 | 0w |  |  |  |  |  |  |  |  |  | Trig-082803-10 |  |  |  |  |  |  |  |
| 168 | 1.2.2.7.2.5 | Test prototype MTFB |  | 56.2w | 2003-08-12 A | 2004-09-27 | 167 | 95% | 2.81w | 2003-08-12 | 2004-08-05 | 49w | 293d |  |  | ElecEngU; PhysicistU; ElecTechU; MandS [198592%] | 6744h | 6406.8h | 1,985.92 | 1,985.92 | 1,985.92 | Trig-082803-10 | AZ | design new flavor board for cal-track matching | Percent Complete | R&D |  |  |  |
| 169 | 1.2.2.7.3 | **Production** |  | 211d | 2004-07-09 A | 2005-05-16 |  | 14% | 180.86d | 2003-09-10 | 2004-02-10 | 100d | 138d |  |  |  | 598.41h | 6.41h | 20,744.17 | 17,956.65 | 8,623.09 | Trig-082803-10 | AZ |  |  |  |  |  |  |
| 170 | 1.2.2.7.3.1 | Procure MTFB parts |  | 4w | 2004-07-09 A | 2004-08-05 A | 167, 168FF | 100% |  | 2004-07-09 | 2004-08-05 | 4w |  |  |  | ElecEngU [4%]; MandSPass [862309%] | 6.41h | 6.41h | 8,623.09 | 8,623.09 | 8,623.09 | Trig-082803-10 | AZ |  | Percent Complete | EQU | 1.2.2.7.3.1 | 1.2.2.7.3.1 |  |
| 171 | 1.2.2.7.3.2 | Fabricate and assemble MTFB |  | 8w | 2004-09-27 | 2004-11-19 | 170FS+7w, 137 |  |  | 2004-08-06 | 2004-10-01 | 8w | 174d | 0d |  | ElecEngU [5%]; MandSPass [654604%] | 16h |  | 6,546.04 | 6,546.04 |  | Trig-082803-10 | AZ | fabricate n boards, includeing m spares | Percent Complete | EQU | 1.2.2.7.3.2 | 1.2.2.7.3.2 | CC |
| 172 | 1.2.2.7.3.3 | Fabrication and Assembly of L1 Trigger Cal-Trk Match MTFB's Complete | milestone | 0w | 2004-11-19 | 2004-11-19 | 171 |  |  | 2004-10-01 | 2004-10-01 | 0w | 174d | 36d |  |  |  |  |  |  |  | Trig-082803-10 |  |  |  |  |  |  |  |
| 173 | 1.2.2.7.3.4 | Test MTFB |  | 16w | 2005-01-25 | 2005-05-16 | 172, 152 |  |  | 2005-01-25 | 2005-05-16 | 16w | 138d | 0d |  | ElecTechU [60%]; ElecEngU [10%]; PhysicistU [20%]; MandSPass [557504%] | 576h |  | 5,575.04 | 5,575.04 |  | Trig-082803-10 | AZ | fabricate n boards, includeing m spares | Percent Complete | EQU | 1.2.2.7.3.4 | 1.2.2.7.3.4 |  |
| 174 | 1.2.2.8 | **Infrastructure** |  | 576d | 2003-03-14 A | 2005-07-06 |  | 38% | 358.1d | 2003-03-20 | 2004-05-19 | 302d | 103d |  |  |  | 1606.72h | 308.96h | 94,833.05 | 108,982.85 | 66,080.61 | Trig-082803-7 |  |  |  |  |  |  |  |
| 175 | 1.2.2.8.1 | **University of Arizona Tasks** |  | 576d | 2003-03-14 A | 2005-07-06 |  | 43% | 330.89d | 2003-03-20 | 2004-05-19 | 302d | 103d |  |  |  | 1111.52h | 197.12h | 75,520.25 | 74,818.85 | 61,718.85 | Trig-082803-7 | AZ |  |  |  |  |  |  |
| 176 | 1.2.2.8.1.1 | Procure cables and connectors |  | 16w | 2003-06-30 A | 2003-10-21 A | 140 | 100% |  | 2003-06-30 | 2003-10-21 | 16w |  |  | start no earlier than 2003-06-30 | ElecEngU [3%]; MandSPass | 19.2h | 19.2h | 16,639.36 | 16,639.36 | 16,639.36 | Trig-082803-7 | AZ |  | Percent Complete | EQU | 1.2.2.8.1 | 1.2.2.8.1.1 |  |
| 177 | 1.2.2.8.1.2 | Assemble cables |  | 26w | 2004-08-30 A | 2005-03-14 | 176 | 20% | 20.8w | 2004-05-24 | 2004-11-24 | 26w | 183d | 0d | start no earlier than 2004-08-30 | PhysicistU [25%]; ElecTechU [20%]; MandSPass [130260%] | 468h | 93.6h | 1,302.6 | 1,302.6 | 1,302.6 | Trig-082803-7 | AZ |  | Percent Complete | EQU | 1.2.2.8.1 | 1.2.2.8.1.2 |  |
| 178 | 1.2.2.8.1.3 | Procure VME crates |  | 14w | 2003-06-23 A | 2003-09-30 A | 140 | 100% |  | 2003-06-23 | 2004-01-05 | 26w |  |  | start no earlier than 2003-06-23 | ElecTechU [3%]; MandSPass [897315%] | 16.8h | 16.8h | 8,973.15 | 8,973.15 | 8,973.15 | Trig-082803-7 | AZ |  | Percent Complete | EQU | 1.2.2.8.1 | 1.2.2.8.1.3 |  |
| 179 | 1.2.2.8.1.4 | Procure VME processors |  | 26w | 2003-03-14 A | 2003-09-16 A | 140 | 100% |  | 2003-03-20 | 2003-10-20 | 30w |  |  |  | ElecEngU [1%]; MandSPass [849238%] | 10.4h | 10.4h | 8,492.38 | 8,492.38 | 8,492.38 |  | AZ |  | Percent Complete | EQU | 1.2.2.8.1 | 1.2.2.8.1.4 |  |
| 180 | 1.2.2.8.1.5 | Procure power supplies |  | 12.8w | 2003-07-01 A | 2003-09-30 A | 140, 136 | 100% |  | 2003-07-01 | 2003-11-05 | 18w |  |  | start no earlier than 2003-07-01 | ElecEngU [1%]; MandSPass | 5.12h | 5.12h | 13,689.58 | 13,689.58 | 13,689.58 | Trig-082803-7 | AZ |  | Percent Complete | EQU | 1.2.2.8.1 | 1.2.2.8.1.5 |  |
| 181 | 1.2.2.8.1.6 | Assemble and test power supplies |  | 40w | 2004-05-28 A | 2005-03-22 | 180 | 25% | 30w | 2004-01-20 | 2004-10-28 | 40w | 177d | 0d | start no earlier than 2004-06-01 | PhysicistU [10%]; MandSPass [430438%]; ElecEngU [1%] | 176h | 44h | 4,304.38 | 4,304.38 | 4,304.38 | Trig-082803-7 | AZ |  | Percent Complete | EQU | 1.2.2.8.1 | 1.2.2.8.1.6 |  |
| 182 | 1.2.2.8.1.7 | Procure MSPLIT crates, backplanes, and power supplies |  | 28w | 2004-06-01 A | 2004-12-17 | 137 | 10% | 25.2w | 2004-01-15 | 2004-08-02 | 28w | 236d |  | start no earlier than 2004-06-01 | ElecTechU [5%]; MandSPass [80960%] | 56h | 5.6h | 809.6 | 809.6 | 809.6 | Trig-082803-7 | AZ |  | Percent Complete | EQU | 1.2.2.8.1 | 1.2.2.8.1.7 |  |
| 183 | 1.2.2.8.1.8 | Procure MSPLIT card parts |  | 12w | 2004-08-16 A | 2004-11-08 | 137 | 10% | 10.8w | 2004-01-15 | 2004-08-02 | 28w | 103d | 0d | start no earlier than 2004-08-16 | ElecEngU [5%]; MandSPass [750780%] | 24h | 2.4h | 7,507.8 | 7,507.8 | 7,507.8 | Trig-082803-7 | AZ |  | Percent Complete | EQU | 1.2.2.8.1 | 1.2.2.8.1.8 |  |
| 184 | 1.2.2.8.1.9 | Fabricate and assemble MSPLIT cards |  | 24w | 2004-11-09 | 2005-05-09 | 183 |  |  | 2004-08-03 | 2005-02-01 | 24w | 103d | 0d |  | ElecEngU [5%]; ElecTechU [20%]; MandSPass | 240h |  | 12,808.44 | 12,808.44 |  | Trig-082803-7 | AZ |  | Percent Complete | EQU | 1.2.2.8.1 | 1.2.2.8.1.9 |  |
| 185 | 1.2.2.8.1.10 | Test MSPLIT cards |  | 8w | 2005-05-10 | 2005-07-06 | 184 |  |  | 2005-02-02 | 2005-03-29 | 8w | 103d |  |  | ElecTechU [20%]; ElecEngU [5%]; PhysicistU [5%]; MandSPass [99296%] | 96h |  | 992.96 | 992.96 |  | Trig-082803-7 | AZ |  | Percent Complete | EQU | 1.2.2.8.1 | 1.2.2.8.1.10 |  |

Notes:
- 155: WBS Definition- / This summary task describes the design, fabrication and testing of the Muon Trigger Crate Manager. One manager is needed for the crate of MTCxx cards. This card is already used in the run2a muon level 1 muon system.
- 156: WBS Definition- / Modify existing MTCM design to fix known minor problems. / M&S Labor BOE- / Engineer who designed run2a MTCM will be making modifications. / M&S labor = 96h of EEU = $1148.16 / M&S labor pays 20% of EEU salary + ere + overhead, university 80% / M&S Equipment BOE- / There is no M&Sequipment associated with this task. / M&S total = $1148.16
- 157: WBS Definition- / Procure the parts to build all MTCM cards needed by the cal-track matching system, including spares. / M&S Labor BOE- / Same engineer as in run2a will be responsible for procurement and has all records of prices and vendors. / M&S labor = 48h of EEU = $574.08 / M&S labor pays 20% of EEU salary + ere + overhead, university 80% / M&S Equipment BOE- / The cost is based on parts cost for the Run 2a MTCM's x 1.1 / 3 cards @ $2684 = $8052 / See BOE binder for detailed itemization of costs. / M&S total = $8626.08
- 158: WBS Definition- / Fabricate and assmble 3 MTCM cards, including 2 spares. / M&S Labor BOE- / Same engineer as in run2a will be responsible for tracking the fabrication and assembly. / M&S labor = 24h of EEU = $287.04 / M&S labor pays 20% of EEU salary + ere + overhead, university 80% / M&S Equipment BOE- / 3 cards @ $1408 = $4224 / Unit costs based on actual costs of MTCxx fabrication and assemply in run2a x 1.1. / See BOE binder for PO's. / M&S total = $4511.04
- 159: WBS Definition / milestone:
- 160: WBS Definition- / Test functionality of MTCM cards on the existing Level1 muon test stand. / M&S Labor BOE- / Based on Run2a MTCM testing rate of 1 week/card (cumulative time) / M&S labor = 144h of EEU = $1722.24 / M&S labor pays 20% of EEU salary + ere + overhead, university 80% / M&S Equipment BOE- / No M&S equipment on this task / M&S total = $1722.24
- 161: WBS Definition- / This summary task describes the design, production, and testing of the "muon trigger flavor board" which mounts on the MTCxx and does the actual matching algorithm.
- 162: WBS definition - / Develop and simulate a prototype algorithm to match tracks with calorimeter clusters in the cal-trk match FPGA's / Labor BOE - / Modification of existing Level 1 muon algorithms with match tracks with muon hits. Time estimate based on run2a experience optimizing existing algorithms
- 164: WBS Definition- / Modify existing Run2a flavor board design to use more powerful FPGA's and provide serial link output. Work includes schematic, layout, and FPGA program development and simulation / M&S Labor BOE- / EEU who designed run2a muon trigger flavor board will be doing the design and layout. ETU who worked on run2a muon trigger flavor board FPGA simulations will be doing the FPGA design and simulation. The time is based on the run2a experience of about two months at half time for design and layout. This board contains an additional complication of a serial link which would lengthen the time. However we have also already completed some groundwork on the design of the board itself which would shorten the time. The physicist labor is to help translate the simulation algorithm into an FPGA algorithm. / M&S Labor BOE- / M&S labor = 192h of EEU and 320h of ETU= $6304.32 / M&S labor pays 20% of EEU salary + ere + overhead, university 80% / M&S labor pays full ETU salary + ere + overhead / M&S Equipment BOE- / No M&S equipment on this task / M&S total = $6304.32
- 165: WBS Definition- / Procure the parts needed for flavor board prototypes / M&S Labor BOE- / Same engineer as in run2a will be responsible for procurement and has all records of prices and vendors. / M&S labor = 8h of EEU = $95.68 / M&S labor pays 20% of EEU salary + ere + overhead, university 80% / M&S Equipment BOE- / See BOE binder for cost based on parts. Cost based on Run2a MTFB boards but with new FPGA; 2 boards @ $770 = $1540 / M&S total = $1635.68
- 166: WBS Definition- / Fabricate and assemble two prototype MTFB flavor boards / M&S Labor BOE- / Same engineer as in run2a will be responsible for tracking the fabrication and assembly. / M&S labor = 16h of EEU = 191.36$ / M&S labor pays 20% of EEU salary + ere + overhead, university 80% / M&S Equipment BOE- / 2 boards at $2220 = $4440 / Unit costs based on actual costs of MTFB assembly * 1.1. Assembly costs were $72/board plus NRE charges. Fabrication costs are the average of 2 quotes. See BOE binder for run2a po and quotes. / M&S total = $4631.36
- 167: WBS Definition- / milestone; to track prototyping status of MTFB
- 168: WBS Definition- / Test functionality of prototype MTFB on existing Level-1 muon test stand. / M&S Labor BOE- / Based on the time required to test the production MTFB cards in run 2a of one board per day (full-time) plus additional time for testing new downloading, boundary scan testing, and serial link features. / M&S labor = 32h of EEU and 128h of ETU= $1985.92 / M&S labor pays 20% of EEU salary + ere + overhead, university 80% / M&S labor pays full ETU salary + ere + overhead / M&S Equipment BOE / There is no M&S equipment associated with this task / M&S total = $1985.92
- 170: WBS Definition- / Procure the parts to build all MTFB cards needed by the cal-track matching system, including spares. / M&S Labor BOE- / Same engineer as in run2a will be responsible for procurement and has all records of prices and vendors. / M&S labor = 12.8h of EEU = $153.09 / M&S labor pays 20% of EEU salary + ere + overhead, university 80% / M&S Equipment BOE- / See BOE binder for detailed itemization of costs. Based on run2a MTFB costs plus a new FPGA / 11 boards @ $770 = $8470 / M&S total = $8623.09
- 171: WBS Definition- / Fabricate 11 MTFB cards, including 2 spares / M&S Labor BOE- / Same engineer as in run2a will be responsible for tracking the fabrication and assembly. / M&S labor = 24h of EEU = $287.04 / M&S labor pays 20% of EEU salary + ere + overhead, university 80% / M&S Equipment BOE- / 11 boards @ $569 = $6259 / Unit costs based on actual costs of MTFB assembly * 1.1. Assembly costs were $72/board plus NRE charges. Fabrication costs are the average of 2 quotes. See BOE binder for run2a po and quotes / M&S total = $6485.54
- 172: WBS Definition- / milestone: to track production status of MTFB's
- 173: WBS Definition / Test functionality of MTFB cards on the Level1 muon test stand. / M&S Labor BOE- / Based on Run2a MTFB rate of 1 board/day (full time) plus additional time for trouble-shooting / M&S labor = 32h of EEU and 192h of ETU = $2787.52 / M&S labor pays 20% of EEU salary + ere + overhead, university 80% / M&S labor pays full ETU salary + ere + overhead / M&S Equipment BOE- / There are no M&S equipment costs associated with this task / M&S total = $2787.52
- 174: WBS Definition- / This summary element includes various infrastructure components such as cabling, crates, backplanes and power supplies.
- 176: WBS Definition- / Procure the cables and connectors needed by the cal-track matching system including spares. / M&S Labor BOE- / Approximately 3 days of work to re-order cables and connectors that were used in the run2a Level 1 muon trigger. / M&S labor = 19.2h of EEU = $229.63 / M&S labor pays 20% of EEU salary + ere + overhead, university 80% / M&S Equipment BOE- / Run 2a costs x 1.1. See BOE binder for Run 2a PO's. See xls spreadsheet for connector details Costs are connector for one end plus connector for the other end plus 1/8 connector shell costs are for cables from the "front ends" to the splitter cards (bnc to sma) and from the splitter cards to the mtcxx cards (conec to conec) and on board the mtcxx cards (conec to mcx). / M&S Equipment total = $16409.63 / M&S total = $16639.36
- 177: WBS Definition / Assemble cables at Fermilab and a smaller number at arizona eg the first couple sets would be done at arizona to determine length and test procedure. / Labor BOE- / Based on Run 2a experience of 2 complete cables per hour (cutting, termination, testing, rework, lableling). / M&S labor = 48h of ETU = $601.20 / M&S labor pays full ETU salary + ere + overhead / M&S total = $601.20
- 178: WBS Definition- / Procure two custom VME crates for MTCxx cards for cal-trk match. / M&S Labor BOE / Mostly waiting for order to be filled; about 3/4 of a week total interacting with vendor. The crate is special-ordered by Tre New through Electronic Solutions. / M&S labor = 31.2h of EEU = $373.15 / M&S labor pays 20% of EEU salary + ere + overhead, university 80% / M&S Equipment BOE- / See BOE binder for vendor quote / M&S equipment total = 2 x $4300 = $8600 / M&S total = $8973.15
- 179: WBS Definition- / Procure 3 6u embedded processors and form factor adapters for control and downloading of the MTCxx crates. / M&S Labor BOE- / One day to place order and follow up. / M&S labor = 10.4h of EEU = $124.38 / M&S labor pays 20% of EEU salary + ere + overhead, university 80% / M&S Equipment BOE- / See BOE binder for vendor quote = 2 processors @ 3655 = 7310 / Form adaptors are 2 x $529 = $1058 from run 2a experience / M&S equipment total = $8368 / M&S total = $8434.38
- 180: WBS Definition- / Procure power supplies for MTCxx crate. / M&S Labor BOE- / Mostly waiting for order to be filled; about one day of getting quotes, placing order, / and follow-up / M&S labor = 10.4h of EEU = $124.38 / M&S labor pays 20% of EEU salary + ere + overhead, university 80% / M&S Equipment BOE- / Vendor quote x 1.1 (see BOE binder) / Price is for 4 supplies including 2 spares @$3391.3 / They are packaged as 2 x 2 supplies each = $13565.2 / M&S total = $13689.58
- 181: WBS Definition- / Assemble and test power supplies for MTCxx crates. / M&S Labor BOE- / Run 2a supplies took about 1 month per supply on average to assemble and test with a full-time technician assigned to the task needed for parts ordering is 10.4h of ElecEngU = $124.38 in addition to ElecTechF. Some parts are orded by the ElecTechF from the fermilab stockroom. / M&S Equipment BOE- / Costs were estimated using run 2a costs There is some uncertainty as to whether we must re-order the display and monitor PCB's. See BOE binder for a spreadsheet of the costs. Basically i added many/most of the costs for 6 crates and divided by 6. 2 supply cases (each containing 2 supplies) will be built at $2190 / case. This includes display and monitor electronics. / M&S equipment total = $4180 / M&S total = $4304.38
- 182: WBS Definition / Procure crate, power backplane, and power supplies for MSPLIT cards for MTCxx cards. / M&S Labor BOE- / Same ElecTechU who ordered parts for run2a will do so again for run 2b. / M&S labor = 32h of ETU = $400.80 / M&S labor pays ETU salary + ere + overhead / The backplanes will be spares from Run 2a but they must be assembled by the ElecTechU. / M&S Equipment BOE- / See BOE binder. Based on run 2a costs x 1.1 except the power supply which we estimate using the supply catalog price. / M&S equipment total = $408.80 / M&S total = $809.60
- 183: WBS Definition- / Procure the parts needed for MSPLIT cards / M&S Labor BOE- / Same ElecTechU as in run2a will be responsible for procurement and has all records of prices and vendors. / M&S labor = 24h of EEU = $300.6 / M&S labor pays ETU salary + ere + overhead / M&S Equipment BOE / See BOE binder for spreadsheet. Cost based on Run2a MSPLIT costs x 1.1 / 14 boards @ $514.8 = $7207.2 / M&S total = $7507.8
- 184: WBS Definition- / Fabricate 14 splitter cards including 2 spares. / M&S Labor BOE / Same engineer as in Run 2a will be responsible for tracking the fabrication and assembly. Same ElecTechU as in Run 2a will do the assembly. The full-time assembly rate in Run 2a was 1 board per day. / M&S labor = 24h of EEU and 96h of ETU= $1489.44 / M&S labor pays 20% of EEU salary + ere + overhead / M&S labor pays full ETU salary + ere + overhead / M&S Equipment BOE- / 14 boards @ $808.5 = $11319 / Unit costs based on actual costs of run2a MSPLIT fabrication x 1.1. Assembly will be by Arizona technician. See BOE binder for run2a p.o. / M&S total = $12808.44
- 185: WBS Definition- / Test functionality of MSPLIT cards on existing run2a test stand. / M&S Labor BOE- / Based on Run2a MSPLIT rate of 2 boards/day (full time) for complete testing. Additional time needed for debugging and fixes. / M&S labor = 16h of EEU and 64h of ETU = $992.96 / M&S labor pays 20% of EEU salary + ere + overhead / M&S labor pays full ETU salary + ere + overhead / M&S Equipment BOE- / There are no M&S equipment costs associated with this task. / M&S total = $992.96

| ID | WBS | Task | Type | Duration | Start | Finish | Predecessors | Complete | Remaining | Baseline start | Baseline finish | Baseline duration | Total slack | Free slack | Constraint | Resources | Work | Actual work | Cost | Baseline cost | Actual cost | Text24 | Text27 | Text26 | Text28 | Text29 | Text30 |
| --- | --- | --- | --- | --- | --- | --- | --- | --- | --- | --- | --- | --- | --- | --- | --- | --- | --- | --- | --- | --- | --- | --- | --- | --- | --- | --- | --- |
| 186 | 1.2.2.8.2 | **Fermilab Tasks** |  | 200d | 2004-05-28 A | 2005-03-22 |  | 23% | 153.94d | 2003-10-22 | 2004-05-19 | 141d | 177d |  |  |  | 495.2h | 111.84h | 19,312.8 | 29,640 | 4,361.76 | Trig-082803-7 | FNAL |  |  |  |  |
| 187 | 1.2.2.8.2.1 | Assemble cables |  | 26w | 2004-08-30 A | 2005-03-14 | 177SS | 20% | 20.8w | 2004-05-24 | 2004-11-24 | 26w | 183d |  | start no earlier than 2004-08-30 | ElecTechF [23%] | 239.2h | 47.84h | 9,328.8 | 9,328.8 | 1,865.76 | Trig-082803-7 | FNAL | Percent Complete | EQU | 1.2.2.8.2 | 1.2.2.8.2.1 |
| 188 | 1.2.2.8.2.2 | Assemble and test power supplies |  | 40w | 2004-05-28 A | 2005-03-22 | 181SS | 25% | 30w | 2004-01-20 | 2004-10-28 | 40w | 177d |  |  | ElecTechF [16%] | 256h | 64h | 9,984 | 9,984 | 2,496 | Trig-082803-7 | FNAL | Percent Complete | EQU | 1.2.2.8.2 | 1.2.2.8.2.2 |
| 189 | 1.2.2.9 | L1 Trigger Cal-Trk Match Production and Testing Completed | milestone | 0w | 2005-05-16 | 2005-05-16 | 144, 154, 173, 181, 177 |  |  | 2006-01-03 | 2006-01-03 | 0w | 138d | 54d |  |  |  |  |  |  |  |  |  |  |  |  |  |
| 190 | 1.2.3 | **Level 1 Tracking** |  | 676d | 2002-11-07 A | 2005-08-02 |  | 49% | 345.82d | 2002-11-12 | 2006-01-10 | 777d | 84d |  |  |  | 15219.6h | 6617.64h | 1,266,616.9 | 889,118.47 | 391,459 |  |  |  |  |  |  |
| 191 | 1.2.3.1 | Prototype L1 Central Track Trigger Algorithm Coded And Simulated With FPGA Simulation Tools | milestone | 0w | 2002-11-07 A | 2002-11-07 A | 511SS+40w | 100% |  | 2002-11-12 | 2002-11-12 | 0w |  |  |  |  |  |  |  |  |  |  |  |  |  |  |  |
| 192 | 1.2.3.2 | **Develop Target CTT Algorithm** |  | 154d | 2002-11-07 A | 2003-06-25 A | 511SS+40w | 100% |  | 2002-11-13 | 2003-09-15 | 206d |  |  |  |  | 1232h | 1232h | 85,272 | 85,272 | 85,272 |  |  |  |  |  |  |
| 193 | 1.2.3.2.1 | Develop firmware for target CTT algorithm |  | 22.8w | 2002-11-07 A | 2003-04-29 A | 511SS+40w | 100% |  | 2002-11-13 | 2003-07-31 | 35w |  |  |  | ElecEngU; InKind | 912h | 912h | 72,352 | 72,352 | 72,352 |  | BU | Percent Complete | INK-MRI2 |  |  |
| 194 | 1.2.3.2.2 | Fit CTT firmware in selected FPGA, do timing studies |  | 8w | 2003-04-30 A | 2003-06-25 A | 193 | 100% |  | 2003-08-01 | 2003-09-15 | 6.2w |  |  |  | ElecEngU; InKind | 320h | 320h | 12,920 | 12,920 | 12,920 |  | BU | Percent Complete | INK-MRI2 |  |  |
| 195 | 1.2.3.3 | Target L1 Central Track Trigger Algorithm Firmware Coded And Simulated With FPGA Simulation Tools | milestone | 0w | 2003-06-25 A | 2003-06-25 A | 192 | 100% |  | 2003-09-15 | 2003-09-15 | 0w |  |  |  |  |  |  |  |  |  |  |  |  |  |  |  |
| 196 | 1.2.3.4 | **Develop Test Procedures** |  | 211d | 2003-06-26 A | 2004-05-03 A |  | 100% |  | 2003-09-16 | 2003-10-31 | 34d |  |  |  |  | 720.13h | 720.13h | 1,550.4 | 1,550.4 | 1,550.4 |  |  |  |  |  |  |
| 197 | 1.2.3.4.1 | Develop test procedures |  | 42.2w | 2003-06-26 A | 2004-05-03 A | 195 | 100% |  | 2003-06-26 | 2004-01-23 | 28w |  |  |  | ElecEngU [10%]; InKind [155040%] | 65.47h | 65.47h | 1,550.4 | 1,550.4 | 1,550.4 |  | BU | Percent Complete | INK-MRI2 |  |  |
| 198 | 1.2.3.4.2 | Develop test procedures |  | 42.2w | 2003-06-26 A | 2004-05-03 A | 195 | 100% |  | 2003-06-26 | 2004-01-23 | 28w |  |  |  | PhysicistU | 654.67h | 654.67h |  |  |  |  | BU | Percent Complete | INK-OTHER |  |  |
| 199 | 1.2.3.5 | **DFEA Preproduction I** |  | 211d | 2003-06-26 A | 2004-05-03 A |  | 100% |  | 2003-09-16 | 2004-06-09 | 181d |  |  |  |  | 1459.91h | 1459.91h | 106,347.6 | 106,347.6 | 106,347.6 |  |  |  |  |  |  |
| 200 | 1.2.3.5.1 | **MRI Tasks - BU** |  | 211d | 2003-06-26 A | 2004-05-03 A |  | 100% |  | 2003-09-16 | 2004-06-09 | 181d |  |  |  |  | 1455.11h | 1455.11h | 50,258.6 | 50,258.6 | 50,258.6 |  |  |  |  |  |  |
| 201 | 1.2.3.5.1.1 | Layout |  | 11.2w | 2003-06-26 A | 2003-09-15 A | 192 | 100% |  | 2003-09-16 | 2003-11-24 | 10w |  |  |  | ElecEngU; ElecTechU [10%]; InKind | 492.8h | 492.8h | 22,739 | 22,739 | 22,739 |  | BU | Percent Complete | INK-MRI2 |  |  |
| 202 | 1.2.3.5.1.2 | Procure preproduction DFEA parts |  | 5.4w | 2003-08-22 A | 2003-09-30 A | 201FS-2w | 100% |  | 2003-11-25 | 2004-01-09 | 5w |  |  |  | ElecTechU [20%]; InKind [206720%] | 43.2h | 43.2h | 2,067.2 | 2,067.2 | 2,067.2 |  | BU | Percent Complete | INK-MRI2 |  |  |
| 203 | 1.2.3.5.1.3 | PCB fabrication |  | 4w | 2003-09-22 A | 2003-10-17 A | 208 | 100% |  | 2004-01-12 | 2004-01-28 | 2.4w |  |  |  | ElecTechU [20%]; InKind [103360%] | 32h | 32h | 1,033.6 | 1,033.6 | 1,033.6 |  | BU | Percent Complete | INK-MRI2 |  |  |
| 204 | 1.2.3.5.1.4 | Assembly |  | 8.8w | 2003-10-20 A | 2003-12-22 A | 209 | 100% |  | 2004-01-29 | 2004-02-24 | 3.8w |  |  |  | ElecTechU [15%]; InKind [116280%] | 17.11h | 17.11h | 1,162.8 | 1,162.8 | 1,162.8 |  | BU | Percent Complete | INK-MRI2 |  |  |
| 205 | 1.2.3.5.1.5 | Test |  | 17.4w | 2003-12-23 A | 2004-05-03 A | 210 | 100% |  | 2004-02-25 | 2004-06-09 | 15w |  |  |  | ElecEngU [75%]; InKind; PhysicistU [50%] | 870h | 870h | 23,256 | 23,256 | 23,256 |  | BU | Percent Complete | INK-MRI2 |  |  |
| 206 | 1.2.3.5.2 | **DOE EQ Tasks - BU** |  | 124d | 2003-06-26 A | 2003-12-22 A |  | 100% |  | 2003-09-16 | 2004-02-24 | 106d |  |  |  |  | 4.8h | 4.8h | 56,089 | 56,089 | 56,089 |  |  |  |  |  |  |
| 207 | 1.2.3.5.2.1 | Procure preproduction DFEA FPGAs |  | 6w | 2003-06-26 A | 2003-08-07 A | 192 | 100% |  | 2003-09-16 | 2004-01-09 | 15w |  |  |  | MandSPass; PhysicistU [2%] | 4.8h | 4.8h | 48,000 | 48,000 | 48,000 |  | BU | Percent Complete | EQU | 1.2.3.5.2 | 1.2.3.5.2.1 |
| 208 | 1.2.3.5.2.2 | Procure preproduction DFEA parts |  | 5.4w | 2003-08-22 A | 2003-09-30 A | 201FS-2w | 100% |  | 2003-11-25 | 2004-01-09 | 5w |  |  |  | MandSPass [150000%] |  |  | 1,500 | 1,500 | 1,500 |  | BU | Percent Complete | EQU | 1.2.3.5.2 | 1.2.3.5.2.2 |
| 209 | 1.2.3.5.2.3 | PCB fabrication |  | 4w | 2003-09-22 A | 2003-10-17 A | 208 | 100% |  | 2004-01-12 | 2004-01-28 | 2.4w |  |  |  | MandSPass [580100%] |  |  | 5,801 | 5,801 | 5,801 |  | BU | Percent Complete | EQU | 1.2.3.5.2 | 1.2.3.5.2.3 |
| 210 | 1.2.3.5.2.4 | Assembly |  | 8.8w | 2003-10-20 A | 2003-12-22 A | 209 | 100% |  | 2004-01-29 | 2004-02-24 | 3.8w |  |  |  | MandSPass [78800%] |  |  | 788 | 788 | 788 |  | BU | Percent Complete | EQU | 1.2.3.5.2 | 1.2.3.5.2.4 |

Notes:
- 187: WBS Definition / Assemble cables at Fermilab and a smaller number at arizona eg the first couple sets would be done at arizona to determine length and test procedure. / Labor BOE- / Based on Run 2a experience of 2 complete cables per hour (cutting, termination, testing, rework, lableling). 12 wks of tech time at 50% ( 6 wks of work) / M&S BOE- / see corresponding Arizona task
- 188: WBS Definition- / Assemble and test power supplies for MTCxx crates. / M&S Labor BOE- / 26 weeks of fermilab tech time at 50% (13 weeks of work) / M&S Equipment BOE- / See arizona task
- 189: WBS Definition- / milestone: track matching system complete except for intallation and commissioning / Text9: milestone
- 190: WBS Definition- / This summary element provides for improvements in the existing track trigger. It includes design and development of algorithms that utilize larger FPGAs, and development and procurement of new Digital Front-End (DFE) boards that utilize these FPGAs. / Text9: This summary element provides for improvements in the existing track trigger. It includes design and development of algorithms that utilize larger FPGAs, and development and procurement of new Digital Front-End (DFE) boards that utilize these FPGAs.
- 191: WBS Definition- / milestone: once this is done, FPGAs can be chosen / Text9: milestone
- 192: WBS Definition- / Develop VHDL code for the FPGA's to implement the track finding equations and othe board functions. / Text9: develop VHDL code for the FPGA's to implement the track finding equations and othe board functions
- 193: WBS Definition- / Design the DFEA board firmware to use more powerful FPGA's and provide the outputs to l1muon and l2ctt. / Labor BOE- / The engineer who designed run2a STC trigger flavor board will be doing the design. The STC board is similar in complexity and took us 6 months to complete the firmware. The current work estimate was increased by a month for the engineer to get familiar with the cabling and the input structure (which is fairly complex) to the DFEA. / M&S BOE- / Labor charges based on at the BU EDF rate of $40/hr and an overhead of 61.5%.
- 194: WBS Definition- / Understand the resources used by the L1CTT algorithm for all 4 pt bins, the input and the ouptut result sort leading to the selection of the FPGA to be used. Timing studies need to be carried out to make sure the algorithm and associated overhead fits in the specified 790ns window. / Labor BOE- / The resource allocation, FPGA selection and the timing studies /tuning of the firware will be done by the same engineer who worked on the STC. This task took 3 weeks for the STC. We have added 2 more weeks due to the increased complexity of the L1CTT design. / M&S BOE- / Labor charges based on at the BU EDF rate of $40/hr and an overhead of 61.5%.
- 195: WBS Definition- / milestone: / Text9: milestone
- 196: WBS Definition- / Develop test procedure code, based on Run2a. The test procedures for testing the full functionality of the prototype boards will be developed. We will use the same test stand hardware as used for the Run2a DFEA tests. However, since the internals of the firmware will be changed, the test procedures have to be rewritten. The specifications for the test procedure will be defined by the engineer who develops the firmware. / Text9: develop test procedure code, based on Run2a
- 197: WBS Definition- / Develop test procedure code, based on Run2a / Labor BOE- / The specifications for the test procedure will be defined by the engineer who develops the firmware, together with a BU physicist. The estimate of engineering fraction is based on hours spent by the engineer for the STC test procedure developments. / M&S Labor BOE- / Labor charges based on the BU EDF rate of $40/hr and an overhead of 61.5%. / Text9: develop test procedure code, based on Run2a
- 198: WBS Definition- / Develop test procedure code, based on Run2a / Labor BOE- / The specifications for the test procedure will be defined by the engineer who develops the firmware together with a BU physicist. Engineering effort is assigned to the previous task (1.2.3.4.1) / Text9: develop test procedure code, based on Run2a
- 199: WBS Definition- / Design and build complete functional prototypes for the Digital Front-End Axial daughter boards. / Text9: design an build complete functional prototypes for the Digital Front-End Axial daughter boards
- 201: WBS Definition- / Lay out prototype 1 of DFEA. / Labor BOE- / Run2a STC card layout experience. It took about 5 weeks for layout and verification for the STC card. DFEA will have chips with a factor of 2 output pins on the FPGAs as well as the board layout will be more complex - so we have added 3 more weeks to this phase. / M&S BOE- / Labor charges based on the BU EDF rate of $40/hr and an overhead of 61.5%.
- 202: WBS Definition- / Procure the parts for building two prototype DFEA. / Labor BOE- / BU technical staff will be responsible for procurement of parts and has experience for procuring parts for the Run1a STC. Estimate based on time spent to order STC parts. / M&S BOE - / Labor charges based on the BU EDF rate of $40/hr and an overhead of 61.5%.
- 203: WBS Definition- / PCB fabrication of the DFEA board at vendor site. / Labor BOE- / Based on Run2a STC - includes collecting the files needed by the vendor for PCB fabrication, and to be done by the same person as for the STC. / M&S BOE - / Labor charges based on the BU EDF rate of $40/hr and an overhead of 61.5%. / Text9: assemble 3 prototype boards and test on test stands
- 204: WBS Definition- / Assembly of the DFEA prototype boards at venodr site. / Labor BOE- / Based on Run2a STC - includes collecting the parts needed by the vendor for PCB assembly. Will be done by the same person as STC. / M&S BOE - / Labor charges based on the BU EDF rate of $40/hr and an overhead of 61.5%.
- 205: WBS Definition- / DFEA prototype board testing. / Labor BOE- / Based on Run2a STC - It took 3 months of a full time physicist and an engineer working at 75% for testing the first prototypes of the STC. / M&S BOE - / Labor charges based on the BU EDF rate of $40/hr and an overhead of 61.5%.
- 207: WBS Definition- / Procure the Xilinx chips for assembly of 6 prototype DFEA. We will assemble only 3 boards for the prototype I round, and 3 in the second. However since the lead times are large, procuring the FPGA all during the first round is necessary and buying more than 10 at a time generaly is 10-15% cheaper than 9 or less chips. / Labor BOE- / n/a / M&S BOE - / Cost for 24 XC2V6000 FPGA, based on 2000$ per FPGA. If the FPGA prices remain high at the time of purchase, we will prototype a scaled-down version of the board with 2 pT bins instead of 4. See supporting document in BOE binder.
- 208: WBS Definition- / Procure the parts for building two prototype DFEA. / Labor BOE- / n/a / M&S BOE - / Cost based on per board prototype parts for the STC - $750/board.
- 209: WBS Definition- / PCB fabrication of the DFEA board at vendor site / Labor BOE- / n/a / M&S BOE - / Based on Run2a STC vendor quote - $3731+240+450 + 1080+300 = 5801. Includes bare board, stencil, tooling, test, Stencil -NRE, programming-NRE. See BOE binder. / Text9: assemble 3 prototype boards and test on test stands
- 210: WBS Definition- / Assembly of the DFEA prototype boards at vendor site. / M&S BOE - / Based on Run2a STC vendor quote - see BOE binder.

| ID | WBS | Task | Type | Duration | Start | Finish | Predecessors | Complete | Remaining | Baseline start | Baseline finish | Baseline duration | Total slack | Free slack | Constraint | Resources | Work | Actual work | Cost | Baseline cost | Actual cost | Text26 | Text27 | Text28 | Text29 | Text30 |
| --- | --- | --- | --- | --- | --- | --- | --- | --- | --- | --- | --- | --- | --- | --- | --- | --- | --- | --- | --- | --- | --- | --- | --- | --- | --- | --- |
| 211 | 1.2.3.6 | **DFEA Preproduction II** |  | 183d | 2004-03-16 A | 2004-12-02 |  | 57% | 78.6d | 2004-03-16 | 2004-07-29 | 96d | 247d |  |  |  | 1988h | 874.72h | 50,160 | 56,388.12 | 32,280 |  |  |  |  |  |
| 212 | 1.2.3.6.1 | **MRI Tasks - BU** |  | 6d | 2004-03-16 A | 2004-03-23 A |  | 100% |  | 2004-03-16 | 2004-07-29 | 96d |  |  |  |  |  |  |  | 26,951.12 |  |  |  |  |  |  |
| 213 | 1.2.3.6.1.1 | Layout |  | 1d | 2004-03-16 A | 2004-03-16 A |  | 100% |  | 2004-03-16 | 2004-04-19 | 5w |  |  | start no earlier than 2004-03-16 |  |  |  |  | 12,920 |  | Percent Complete | BU | INK-MRI1 |  |  |
| 214 | 1.2.3.6.1.2 | PCB fabrication |  | 1d | 2004-03-17 A | 2004-03-17 A | 213 | 100% |  | 2004-04-20 | 2004-05-05 | 2.4w |  |  |  |  |  |  |  | 1,033.6 |  | Percent Complete | BU | INK-MRI1 |  |  |
| 215 | 1.2.3.6.1.3 | Procure preproduction parts |  | 1d | 2004-03-18 A | 2004-03-18 A | 214 | 100% |  | 2004-04-06 | 2004-04-30 | 3.8w |  |  |  |  |  |  |  | 77.52 |  | Percent Complete | BU | INK-MRI1 |  |  |
| 216 | 1.2.3.6.1.4 | Assembly |  | 1d | 2004-03-19 A | 2004-03-19 A | 215 | 100% |  | 2004-05-03 | 2004-05-18 | 2.4w |  |  |  |  |  |  |  | 1,033.6 |  | Percent Complete | BU | INK-MRI1 |  |  |
| 217 | 1.2.3.6.1.5 | Test |  | 1d | 2004-03-22 A | 2004-03-22 A | 216 | 100% |  | 2004-05-19 | 2004-07-29 | 10w |  |  |  |  |  |  |  | 10,336 |  | Percent Complete | BU | INK-MRI1 |  |  |
| 218 | 1.2.3.6.1.6 | Test at Fermilab |  | 1d | 2004-03-23 A | 2004-03-23 A | 217 | 100% |  | 2004-06-03 | 2004-07-27 | 7.6w |  |  |  |  |  |  |  | 1,550.4 |  | Percent Complete | BU | INK-MRI1 |  |  |
| 219 | 1.2.3.6.2 | **DOE EQ Tasks-BU** |  | 3d | 2004-05-17 A | 2004-05-19 A |  | 100% |  | 2004-04-06 | 2004-05-18 | 31d |  |  |  |  |  |  |  | 6,789 |  |  |  |  |  |  |
| 220 | 1.2.3.6.2.1 | PCB fabrication |  | 1d | 2004-05-17 A | 2004-05-17 A |  | 100% |  | 2004-04-20 | 2004-05-05 | 2.4w |  |  | start no earlier than 2004-10-25 |  |  |  |  | 5,801 |  | Percent Complete | BU | EQU | 1.2.3.6.2 | 1.2.3.6.2.1 |
| 221 | 1.2.3.6.2.2 | Procure preproduction parts |  | 1d | 2004-05-18 A | 2004-05-18 A | 220 | 100% |  | 2004-04-06 | 2004-04-30 | 3.8w |  |  |  |  |  |  |  | 200 |  | Percent Complete | BU | EQU | 1.2.3.6.2 | 1.2.3.6.2.2 |
| 222 | 1.2.3.6.2.3 | Assembly |  | 1d | 2004-05-19 A | 2004-05-19 A | 221 | 100% |  | 2004-05-03 | 2004-05-18 | 2.4w |  |  |  |  |  |  |  | 788 |  | Percent Complete | BU | EQU | 1.2.3.6.2 | 1.2.3.6.2.3 |
| 223 | 1.2.3.6.3 | Test at Fermilab |  | 1d | 2004-05-20 A | 2004-05-20 A | 222 | 100% |  | 2004-06-03 | 2004-07-27 | 7.6w |  |  |  |  |  |  |  | 22,648 |  | Percent Complete | FNAL | EQU | 1.2.3.6.3 | 1.2.3.6.3 |
| 224 | 1.2.3.6.4 | Test at Fermilab |  | 1d | 2004-05-21 A | 2004-05-21 A | 223 | 100% |  | 2004-06-03 | 2004-07-27 | 7.6w |  |  |  |  |  |  |  |  |  | Percent Complete | KU | INK-OTHER |  |  |
| 225 | 1.2.3.6.5 | Test at Fermilab |  | 1d | 2004-05-24 A | 2004-05-24 A | 224 | 100% |  | 2004-06-03 | 2004-07-27 | 7.6w |  |  |  |  |  |  |  |  |  | Percent Complete | ND | INK-OTHER |  |  |
| 226 | 1.2.3.6.6 | L1 Central Track Trigger DFEA Prototype Tested At Fermilab | milestone | 0w | 2004-12-02 | 2004-12-02 | 238 |  |  | 2004-10-11 | 2004-10-11 | 0w | 84d | 0d |  |  |  |  |  |  |  |  |  |  |  |  |
| 227 | 1.2.3.6.7 | **MRI Tasks - BU** |  | 102d | 2004-04-26 A | 2004-09-17 |  | 90% | 10.43d | 2004-04-26 | 2004-10-04 | 113d | 299d |  |  |  | 988h | 874.72h | 32,280 | 37,680 | 32,280 |  |  |  |  |  |
| 228 | 1.2.3.6.7.1 | **Layout+Schematic** |  | 39d | 2004-04-26 A | 2004-06-18 A |  | 100% |  | 2004-04-26 | 2004-06-14 | 35d |  |  |  |  | 400h | 400h | 5,400 | 5,400 | 5,400 | Percent Complete |  |  |  |  |
| 229 | 1.2.3.6.7.1.1 | Schematic |  | 4.2w | 2004-04-26 A | 2004-05-24 A | 337FS+1d | 100% |  | 2004-04-26 | 2004-04-30 | 1w |  |  |  | ElecEngU; InKind [180000%] | 168h | 168h | 1,800 | 1,800 | 1,800 | Percent Complete | BU | INK-MRI2 |  |  |
| 230 | 1.2.3.6.7.1.2 | Layout |  | 5.8w | 2004-05-10 A | 2004-06-18 A | 338FS+1d | 100% |  | 2004-06-01 | 2004-06-14 | 2w |  |  |  | ElecEngU; InKind [360000%] | 232h | 232h | 3,600 | 3,600 | 3,600 | Percent Complete | BU | INK-MRI2 |  |  |
| 231 | 1.2.3.6.7.2 | PCB fabrication |  | 3w | 2004-06-21 A | 2004-07-12 A | 228 | 100% |  | 2004-06-15 | 2004-07-06 | 3w |  |  |  | ElecTechU [10%]; InKind [220000%] | 12h | 12h | 2,200 | 2,200 | 2,200 | Percent Complete | BU | INK-MRI2 |  |  |
| 232 | 1.2.3.6.7.3 | Procure preproduction parts |  | 2w | 2004-06-28 A | 2004-07-12 A | 228FS+1w | 100% |  | 2004-06-22 | 2004-07-06 | 2w |  |  |  | ElecTechU [1%]; InKind | 0.8h | 0.8h | 11,280 | 11,280 | 11,280 | Percent Complete | BU | INK-MRI2 |  |  |
| 233 | 1.2.3.6.7.4 | Assembly |  | 2.2w | 2004-07-16 A | 2004-07-30 A | 231FS+3d | 100% |  | 2004-07-12 | 2004-08-06 | 4w |  |  |  | ElecTechU [10%]; InKind [140000%] | 8.8h | 8.8h | 1,400 | 1,400 | 1,400 | Percent Complete | BU | INK-MRI2 |  |  |
| 234 | 1.2.3.6.7.5 | Test |  | 6w | 2004-08-02 A | 2004-09-13 | 233 | 80% | 1.2w | 2004-08-09 | 2004-09-03 | 4w | 303d |  |  | ElecEngU [50%]; InKind [840000%]; PhysicistU; ElecTechU [50%] | 480h | 384h | 8,400 | 8,400 | 8,400 | Percent Complete | BU | INK-MRI2 |  |  |
| 235 | 1.2.3.6.7.6 | DFEA Firmware |  | 3mo | 2004-06-24 A | 2004-09-17 | 357SS | 80% | 0.6mo | 2004-07-12 | 2004-10-04 | 3mo | 299d |  |  | ElecEngU [18%]; InKind [360000%] | 86.4h | 69.12h | 3,600 | 3,600 | 3,600 | Percent Complete | BU | INK-MRI2 |  |  |
| 236 | 1.2.3.6.8 | Test at Fermilab |  | 6w | 2004-10-13 | 2004-11-23 | 297FS+1w |  |  | 2004-09-07 | 2004-10-18 | 6w | 252d | 0d |  | ElecTechF [50%]; ElecEngF | 360h |  | 17,880 | 17,880 |  | Percent Complete | FNAL | EQU | 1.2.3.6.8 | 1.2.3.6.8 |
| 237 | 1.2.3.6.9 | Test at Fermilab |  | 8w | 2004-10-06 | 2004-12-02 | 297 |  |  | 2004-08-30 | 2004-10-11 | 6w | 247d |  |  | PhysicistU | 320h |  |  |  |  | Percent Complete | KU | INK-OTHER |  |  |
| 238 | 1.2.3.6.10 | Test at Fermilab |  | 8w | 2004-10-06 | 2004-12-02 | 297 |  |  | 2004-08-30 | 2004-10-11 | 6w | 84d | 0d |  | PhysicistU | 320h |  |  |  |  | Percent Complete | ND | INK-OTHER |  |  |

Notes:
- 211: WBS Definition- / Design and build complete functional prototypes for the Digital Front-End Axial daughter boards. / Text9: design an build complete functional prototypes for the Digital Front-End Axial daughter boards
- 213: WBS Definition- / Modifications to the first layout, uncovered while testing. Any changes which need to be made due to our experience with testing, verification of the new layout. / M&S BOE- / Labor charges based on the BU EDF rate of $40/hr and an overhead of 61.5%. / Labor BOE- / Run2a STC card layout experience. Estimate based on time taken for the STC. It took 4 weeks to make the necessary changes and verification of the layout. / Task zeroed out and resources removed as per Meena Narain's April 2004 PMG schedule. / Text9: modifications to the first layout, uncovered while testing
- 214: WBS Definition- / PCB fabrication of the DFEA board prototype II at vendor site. / Labor BOE- / Based on Run2a STC - includes collecting the files needed by the vendor for PCB fabrication. / M&S BOE - / Labor charges based on the BU EDF rate of $40/hr and an overhead of 61.5%.
- 215: WBS Definition- / Procure the parts for building two prototype DFEA. / Labor BOE- / BU technical staff will be responsible for procurement of parts and has experience for procuring parts for the Run1a STC. / M&S BOE - / Labor charges based on the BU EDF rate of $40/hr and an overhead of 61.5%.
- 216: WBS Definition- / Assembly of the DFEA prototype boards at vendor site. / Labor BOE- / Based on Run2a STC - includes collecting the parts needed by the vendor for PCB assembly. / M&S BOE - / Labor charges based on the BU EDF rate of $40/hr and an overhead of 61.5%.
- 217: WBS Definition- / DFEA prototype II board testing / M&S BOE - / Labor charges based on the BU EDF rate of $40/hr and an overhead of 61.5%. / Labor BOE- / Based on Run2a STC - Initial tests took 2 months of a full time physicist for testing the second prototypes of the STC. This included processing several events for a stress test of the system. The engineer was involved half time and worked together with the physicist to certify that we are ready for production. We will follow the same model here, as it worked well for Run2a STC. / Text9: assemble 3 prototype boards and test on test stands
- 218: WBS Definition- / Test prototypes in special runs in the real Dzero trigger. / Labor BOE- / This will be a first test of the DFEA boards at Fermilab. The DFEA boards will be tested using the modified Run2a DFEA infrastructure. This setup will be a collaboration between engineer at FNAL, technical person at FNAL, and a physicist who has been involved in the prototype testing. The BU engineer who designed the board will act as a consultant to get the FNAL stand running. / M&S BOE- / Labor charges based on the BU EDF rate of $40/hr and an overhead of 61.5%. / Text9: test prototypes in special runs in the real Dzero trigger
- 220: WBS Definition- / PCB fabrication of the DFEA board prototype II at vendor site. / Labor BOE- / n/a / M&S BOE - / Based on Run2a STC vendor quote - $3731+240+450 + 1080+300 = 5801. Includes bare board, stencil, tooling, test, Stencil -NRE, programming-NRE- see BOE binder.
- 221: WBS Definition- / Procure the parts for building two prototype DFEA. / Labor BOE- / n/a / M&S BOE - / Cost based on per board prototype parts for the STC during the second round of prototype- $100/board - as most of the parts would have been bought in the first round of prototype. Resistors, capacitors, voltage regulators sometimes need to be bulk ordered.
- 222: WBS Definition- / Assembly of the DFEA prototype boards at vendor site. / Labor BOE- / n/a / M&S BOE - / Based on Run2a STC vendor quote - see BOE binder.
- 223: WBS Definition- / Test prototypes in special runs in the real Dzero trigger. / Labor BOE- / This will be a first test of the DFEA boards at Fermilab. The DFEA boards will be tested using the modified Run2a DFEA infrastructure. This task holds the FNAL elec engineering and elec tech portion of the labor for that testing task. / Text9: test prototypes in special runs in the real Dzero trigger
- 224: WBS Definition- / Test prototypes in special runs in the real Dzero trigger. / Labor BOE- / This will be a first test of the DFEA boards at Fermilab. The DFEA boards will be tested using the modified Run2a DFEA infrastructure. There will be physicist which will be trained on testing the boards using the FNAL test stand. They will be involved in testing the production setup. This task holds the KU physicist labor.
- 225: WBS Definition- / Test prototypes in special runs in the real Dzero trigger / Labor BOE- / This will be a first test of the DFEA boards at Fermilab. The DFEA boards will be tested using the modified Run2a DFEA infrastructure. There will be physicist which will be trained on testing the boards using the FNAL test stand. They will be involved in testing the production setup. This task holds the ND physicist labor.
- 226: WBS Definition- / milestone: / Text9: milestone
- 228: Text9: modifications to the first layout, uncovered while testing
- 229: WBS Definition- / Modifications to the first layout, uncovered while testing. Any changes which need to be made due to our experience with testing, verification of the new layout. / M&S BOE- / Labor charges based on the BU EDF rate of $45/hr. / Labor BOE- / Run2a STC card layout experience. Estimate based on time taken for the STC. It took 1 week to make the necessary changes in the schematic
- 230: WBS Definition- / Modifications to the first layout, uncovered while testing. Any changes which need to be made due to our experience with testing, verification of the new layout. / M&S BOE- / Labor charges based on the BU EDF rate of $45/hr. / Labor BOE- / Run2a STC card layout experience. Estimate based on time taken for the STC. It took 3 weeks to make the necessary changes and verification of the layout (including layout).
- 231: WBS Definition- / PCB fabrication of the DFEA board prototype II at vendor site. / Labor BOE- / Based on Run2a STC - includes collecting the files needed by the vendor for PCB fabrication. / Labor charges based on the BU EDF rate of $45/hr. / M&S BOE - / $2000 - revised quote April 2004 for 5 PCB
- 232: WBS Definition- / Procure the parts for building 5 prototype DFEA. / Labor BOE- / BU technical staff will be responsible for procurement of parts and has experience for procuring parts for the Run1a STC. / Labor charges based on the BU EDF rate of $45/hr, for about 22 hrs / M&S BOE - / FPGA XC2V4000 ($10K) + parts (280$)
- 233: WBS Definition- / Assembly of the DFEA prototype boards at vendor site. / Labor BOE- / Based on Run2a STC - includes collecting the parts needed by the vendor for PCB assembly. / Labor charges based on the BU EDF rate of $45/hr for about 5 hrs / M&S BOE - / updated quote april2004 (1200$).
- 234: WBS Definition- / DFEA prototype II board testing / M&S BOE - / Labor charges based on the BU EDF rate of $45/hr. Assign20 hrs of work (10 hours smoke test, / 10 hrs test reworked boards if needed) / Labor BOE- / Based on Run2a STC - Initial tests took 2 months of a full time physicist for testing the second prototypes of the STC. This included processing several events for a stress test of the system. The engineer was involved half time and worked together with the physicist to certify that we are ready for production. We will follow the same model here, as it worked well for Run2a STC. We also add 50% of electrical tech to speed up the tests. rate 45$/hr (20 hrs of labor). / Also 1200$ for board rework. / Text9: assemble 3 prototype boards and test on test stands
- 235: WBS Definition- / Test prototypes in special runs in the real Dzero trigger. / Labor BOE- / This will be a first test of the DFEA boards at Fermilab. The DFEA boards will be tested using the modified Run2a DFEA infrastructure. This setup will be a collaboration between engineer at FNAL, technical person at FNAL, and a physicist who has been involved in the prototype testing. The BU engineer who designed the board will act as a consultant to get the FNAL stand running. / M&S BOE- / Labor charges based on the BU EDF rate of $45/hr. / Text9: test prototypes in special runs in the real Dzero trigger
- 236: WBS Definition- / Test prototypes in special runs in the real Dzero trigger. / Labor BOE- / This will be a first test of the DFEA boards at Fermilab. The DFEA boards will be tested using the modified Run2a DFEA infrastructure. This task holds the FNAL elec engineering and elec tech portion of the labor for that testing task. / Text9: test prototypes in special runs in the real Dzero trigger
- 237: WBS Definition- / Test prototypes in special runs in the real Dzero trigger. / Labor BOE- / This will be a first test of the DFEA boards at Fermilab. The DFEA boards will be tested using the modified Run2a DFEA infrastructure. There will be physicist which will be trained on testing the boards using the FNAL test stand. They will be involved in testing the production setup. This task holds the KU physicist labor.
- 238: WBS Definition- / Test prototypes in special runs in the real Dzero trigger / Labor BOE- / This will be a first test of the DFEA boards at Fermilab. The DFEA boards will be tested using the modified Run2a DFEA infrastructure. There will be physicist which will be trained on testing the boards using the FNAL test stand. They will be involved in testing the production setup. This task holds the ND physicist labor.

| ID | WBS | Task | Type | Duration | Start | Finish | Predecessors | Complete | Remaining | Baseline start | Baseline finish | Baseline duration | Total slack | Free slack | Constraint | Resources | Work | Cost | Baseline cost | Text26 | Text27 | Text28 | Text29 | Text30 | Text23 |
| --- | --- | --- | --- | --- | --- | --- | --- | --- | --- | --- | --- | --- | --- | --- | --- | --- | --- | --- | --- | --- | --- | --- | --- | --- | --- |
| 239 | 1.2.3.7 | **DFEA Production** |  | 309d | 2004-04-19 A | 2005-07-14 |  | 2% | 301.56d | 2004-10-25 | 2006-01-10 | 295d | 97d |  |  |  | 3397.6h | 706,978 | 639,560.35 |  |  |  |  |  |  |
| 240 | 1.2.3.7.1 | **MRI Tasks - BU** |  | 8d | 2004-04-19 A | 2004-04-28 A |  | 100% |  | 2004-11-03 | 2006-01-10 | 288d |  |  |  |  |  |  | 397,954.35 |  |  |  |  |  |  |
| 241 | 1.2.3.7.1.1 | Procure FPGAs |  | 1d | 2004-04-19 A | 2004-04-19 A |  | 100% |  | 2004-12-14 | 2005-07-01 | 27w |  |  | start no earlier than 2004-04-19 |  |  |  | 356,000 | Percent Complete | BU | INK-MRI2 |  |  |  |
| 242 | 1.2.3.7.1.2 | Procure FPGAs |  | 1d | 2004-04-20 A | 2004-04-20 A | 241 | 100% |  | 2004-11-03 | 2005-05-24 | 27w |  |  |  |  |  |  | 516.8 | Percent Complete | BU | INK-MRI2 |  |  |  |
| 243 | 1.2.3.7.1.3 | Design, layout |  | 1d | 2004-04-21 A | 2004-04-21 A | 242 | 100% |  | 2004-11-03 | 2004-12-13 | 5.4w |  |  |  |  |  |  | 10,336 | Percent Complete | BU | INK-MRI2 |  |  |  |
| 244 | 1.2.3.7.1.4 | Procure production parts |  | 1d | 2004-04-22 A | 2004-04-22 A | 243 | 100% |  | 2004-12-14 | 2005-02-17 | 8w |  |  |  |  |  |  | 1,550.4 | Percent Complete | BU | INK-MRI2 |  |  |  |
| 245 | 1.2.3.7.1.5 | PCB Fabricate |  | 1d | 2004-04-23 A | 2004-04-23 A | 244 | 100% |  | 2005-01-13 | 2005-03-10 | 8w |  |  |  |  |  |  | 775.2 | Percent Complete | BU | INK-MRI2 |  |  |  |
| 246 | 1.2.3.7.1.6 | Assembly |  | 1d | 2004-04-26 A | 2004-04-26 A | 245 | 100% |  | 2005-03-11 | 2005-04-18 | 5.4w |  |  |  |  |  |  | 351.95 | Percent Complete | BU | INK-MRI2 |  |  |  |
| 247 | 1.2.3.7.1.7 | Bench test |  | 1d | 2004-04-27 A | 2004-04-27 A | 246 | 100% |  | 2005-04-19 | 2005-07-05 | 10.8w |  |  |  |  |  |  | 15,504 | Percent Complete | BU | INK-MRI2 |  |  |  |
| 248 | 1.2.3.7.1.8 | Test at Fermilab |  | 1d | 2004-04-28 A | 2004-04-28 A | 247 | 100% |  | 2005-05-03 | 2006-01-10 | 33.8w |  |  |  |  |  |  | 12,920 | Percent Complete | BU | INK-MRI2 |  |  |  |
| 249 | 1.2.3.7.2 | **DOE EQ Tasks-BU** |  | 6d | 2004-04-19 A | 2004-04-26 A |  | 100% |  | 2004-10-25 | 2006-01-10 | 295d |  |  |  |  |  |  | 150,588 |  |  |  |  |  |  |
| 250 | 1.2.3.7.2.1 | Procure FPGAs |  | 1d | 2004-04-19 A | 2004-04-19 A |  | 100% |  | 2004-12-14 | 2005-07-01 | 27w |  |  | start no earlier than 2004-04-19 |  |  |  | 83,296 | Percent Complete | BU | EQU | 1.2.3.7.2 | 1.2.3.7.2.1 |  |
| 251 | 1.2.3.7.2.2 | Production readiness review-BU |  | 1d | 2004-04-20 A | 2004-04-20 A | 250 | 100% |  | 2004-10-25 | 2004-11-02 | 1.4w |  |  |  |  |  |  | 1,292 | Percent Complete | BU | EQU | 1.2.3.7.2 | 1.2.3.7.2.2 |  |
| 252 | 1.2.3.7.2.3 | Procure production parts |  | 1d | 2004-04-21 A | 2004-04-21 A | 251 | 100% |  | 2004-12-14 | 2005-02-17 | 8w |  |  |  |  |  |  | 17,600 | Percent Complete | BU | EQU | 1.2.3.7.2 | 1.2.3.7.2.3 |  |
| 253 | 1.2.3.7.2.4 | PCB Fabricate |  | 1d | 2004-04-22 A | 2004-04-22 A | 252 | 100% |  | 2005-01-13 | 2005-03-10 | 8w |  |  |  |  |  |  | 30,800 | Percent Complete | BU | EQU | 1.2.3.7.2 | 1.2.3.7.2.4 |  |
| 254 | 1.2.3.7.2.5 | Assembly |  | 1d | 2004-04-23 A | 2004-04-23 A | 253 | 100% |  | 2005-03-11 | 2005-04-18 | 5.4w |  |  |  |  |  |  | 8,800 | Percent Complete | BU | EQU | 1.2.3.7.2 | 1.2.3.7.2.5 |  |
| 255 | 1.2.3.7.2.6 | Board rework |  | 1d | 2004-04-26 A | 2004-04-26 A | 254 | 100% |  | 2005-05-03 | 2006-01-10 | 33.8w |  |  |  |  |  |  | 8,800 | Percent Complete | BU | EQU | 1.2.3.7.2 | 1.2.3.7.2.6 |  |
| 256 | 1.2.3.7.3 | Production readiness review-Fermilab |  | 1d | 2004-04-27 A | 2004-04-27 A | 255 | 100% |  | 2004-10-25 | 2004-11-02 | 1.4w |  |  |  |  |  |  | 1,540 | Percent Complete | FNAL | EQU | 1.2.3.7.3 | 1.2.3.7.3 |  |
| 257 | 1.2.3.7.4 | Test at Fermilab |  | 1d | 2004-04-28 A | 2004-04-28 A | 256 | 100% |  | 2005-05-03 | 2006-01-10 | 33.8w |  |  |  |  |  |  |  | Percent Complete | KU | INK-OTHER |  |  |  |
| 258 | 1.2.3.7.5 | Test at Fermilab |  | 1d | 2004-04-29 A | 2004-04-29 A | 257 | 100% |  | 2005-05-03 | 2006-01-10 | 33.8w |  |  |  |  |  |  | 36,750 | Percent Complete | ND | EQU | 1.2.3.7.5 | 1.2.3.7.5 |  |
| 259 | 1.2.3.7.6 | Test at Fermilab |  | 1d | 2004-04-30 A | 2004-04-30 A | 258 | 100% |  | 2005-05-03 | 2006-01-10 | 33.8w |  |  |  |  |  |  | 52,728 | Percent Complete | FNAL | EQU | 1.2.3.7.6 | 1.2.3.7.6 |  |
| 260 | 1.2.3.7.7 | L1 Central Track Trigger Production And Testing Complete | milestone | 0w | 2005-07-14 | 2005-07-14 | 282 |  |  | 2006-01-10 | 2006-01-10 | 0w | 97d | 13d |  |  |  |  |  |  |  |  |  |  |  |
| 261 | 1.2.3.7.8 | **DOE EQ Tasks - BU** |  | 165d | 2004-11-09 | 2005-07-14 |  |  |  | 2004-10-04 | 2005-05-23 | 155d | 97d |  |  |  | 1217.6h | 197,340 | 27,340 |  |  |  |  |  |  |
| 262 | 1.2.3.7.8.1 | FPGA choice (XC2V4000 vs XC2V6000) | milestone | 0d | 2004-11-09 | 2004-11-09 | 236SS+4w |  |  | 2004-10-04 | 2004-10-04 | 0d | 262d |  |  |  |  |  |  |  |  |  |  |  |  |
| 263 | 1.2.3.7.8.2 | Procure FPGAs |  | 10w | 2004-12-10 | 2005-03-01 | 266FS-2w |  |  | 2004-10-19 | 2005-01-07 | 10w | 192d |  |  | MandSPass |  | 170,000 |  | Percent Complete | BU | EQU | 1.2.3.7.8.2 | 1.2.3.7.8.2 | CC |
| 264 | 1.2.3.7.8.3 | Production Readniness review |  | 1w | 2004-12-03 | 2004-12-09 | 238 |  |  | 2004-10-12 | 2004-10-18 | 1w | 97d | 0d |  | PhysicistU; MandSPass [90000%]; ElecEngU [50%] | 60h | 900 | 900 | Percent Complete | BU | EQU | 1.2.3.7.8.3 | 1.2.3.7.8.3 | CC |
| 265 | 1.2.3.7.8.4 | PRR (DFEA) include decision on DFEm/DFEA merge | milestone | 0d | 2004-12-09 | 2004-12-09 | 264 |  |  | 2004-10-18 | 2004-10-18 | 0d | 97d | 0d | start no earlier than 2004-04-22 |  |  |  |  |  |  |  |  |  |  |
| 266 | 1.2.3.7.8.5 | Design, layout |  | 2w | 2004-12-10 | 2004-12-23 | 265 |  |  | 2004-10-19 | 2004-11-01 | 2w | 97d | 0d |  | ElecEngU [50%]; ElecTechU [50%]; MandSPass [180000%] | 80h | 1,800 | 1,800 | Percent Complete | BU | EQU | 1.2.3.7.8.5 | 1.2.3.7.8.5 | CC |
| 267 | 1.2.3.7.8.6 | Procure production parts |  | 6w | 2005-01-04 | 2005-02-15 | 266 |  |  | 2004-11-02 | 2004-12-15 | 6w | 202d |  |  | ElecTechU [10%]; MandSPass [120000%] | 24h | 1,200 | 1,200 | Percent Complete | BU | EQU | 1.2.3.7.8.6 | 1.2.3.7.8.6 | CC |
| 268 | 1.2.3.7.8.7 | PCB Fabricate |  | 6w | 2005-01-26 | 2005-03-08 | 276SS+3w |  |  | 2004-11-23 | 2005-01-14 | 6w | 187d |  |  | ElecTechU [5%]; MandSPass [20000%] | 12h | 200 | 200 | Percent Complete | BU | EQU | 1.2.3.7.8.7 | 1.2.3.7.8.7 | CC |
| 269 | 1.2.3.7.8.8 | Assembly |  | 4w | 2005-03-09 | 2005-04-05 | 277 |  |  | 2005-01-18 | 2005-02-14 | 4w | 167d |  |  | ElecTechU [3%]; MandSPass [20000%] | 4.8h | 200 | 200 | Percent Complete | BU | EQU | 1.2.3.7.8.8 | 1.2.3.7.8.8 | CC |

Notes:
- 239: WBS Definition- / This summary task covers the production of the final version of the DFEA's. / Risk Mitigation- / Cost: There are 3 factors which may affect the "Cost": / 1) Xilinx chip prices may not completely follow vendor projected quote. / 2) We may need XC2V8000 chips due to equation growth when we put in effects of various inefficiencies and misalignments in the modeling of the CFT in the simulations. / 3) The board will use parts which are a factor of 2.5 denser and complicated than the current Run2a DFEA boards. This may lead to higher vendor quotes for PCB fabrication and assembly compared to Run2a quotes included in the BOE. / All of these factors may lead to a cost increase which is a significant fraction of project cost. We have address these risks by including a 70% contingency on the XC2V FPGA costs, a 30%contingency on the PCB fabrication, and a 50% contingency on the production parts.
- 241: WBS Definition- / Procure the FPGAs needed for implementing the target algorithm. This is delayed until needed in order to take advantage of price reductions with time. / Labor BOE- / n/a / M&S BOE- / Procure the XC2V FPGAs for all 88 boards (80+8 spares). vendor quote, BOE binder.
- 242: WBS Definition- / Procure the FPGAs needed for implementing the target algorithm. This is delayed until needed in order to take advantage of price reductions with time. / Labor BOE- / Run2a experience - placing the order and negotiating lead times - same time as spent ordering Run2a STC Xilinc chips. / M&S BOE- / Labor charges based on the BU EDF rate of $40/hr and an overhead of 61.5%.
- 243: WBS Definition- / Make any necessary modifications to prototype II design. / M&S BOE- / Labor charges based on the BU EDF rate of $40/hr and an overhead of 61.5%. / Labor BOE- / Modification of production layout, checking of all layouts based on Run2a STC experience. It took 4 weeks for the final STC production layout and verification. We use the same estimate here.
- 244: WBS Definition- / Procure the parts for building 88 production DFEA. / Labor BOE- / BU technical staff will be responsible for procurement of parts and has experience for procuring parts for the Run1a STC. / M&S BOE - / Labor charges based on the BU EDF rate of $40/hr and an overhead of 61.5%.
- 245: WBS Definition- / PCB fabrication of the DFEA production board. / Labor BOE- / Based on Run2a STC - includes collecting the files needed by the vendor for PCB fabrication. / M&S BOE - / Labor charges based on the BU EDF rate of $40/hr and an overhead of 61.5%. / Text9: test each production board on the test stand before intallation
- 246: WBS Definition- / Assembly of the DFEA production boards. / Labor BOE- / Based on Run2a STC - includes collecting the parts needed by the vendor for PCB assembly. / M&S BOE - / Labor charges based on the BU EDF rate of $40/hr and an overhead of 61.5%.
- 247: WBS Definition- / Test each production board on the test stand before intallation. / M&S BOE- / Labor charges based on the BU EDF rate of $40/hr and an overhead of 61.5%. / Labor BOE- / Test 10 boards a week. To be done by BU EDF engineer in conjunction with a physicist. / Text9: test each production board on the test stand before intallation
- 248: WBS Definition- / Re-test each board after delivery to Fermilab. / M&S BOE- / Labor charges based on the BU EDF rate of $40/hr and an overhead of 61.5%. / Labor BOE- / Testing of the DFEA boards at Fermilab will be done using the modified Run2a DFEA infrastructure. This setup will be a collaboration between enginner at FNAL, technical person at FNAL, and a physicist who has been involved in the prototype testing. Alll of these personnel will have been trained on the prototype test phase. We expect to complete the entire test chain using the datapump and be able to test one board every day. This will allow 7 weeks for rework/retest of some of the boards if necessary. / Text9: test each production board on the test stand before intallation
- 250: WBS Definition- / Procure the FPGAs needed for implementing the target algorithm. This is delayed until needed in order to take advantage of price reductions with time. / Labor BOE- / n/a / M&S BOE- / Procure the XC2V FPGAs for all 88 boards (80+8 spares). vendor quote, BOE binder.
- 251: WBS Definition- / Review and sign-off process prior to entering into production of the Digital Front-End Axial boards - BU participation / Labor BOE- / 1 week of a university electrical engineer at 50%
- 252: WBS Definition- / Procure the parts for building 88 production DFEA. / Labor BOE- / n/a / M&S BOE - / Cost based on per board prototype parts for the STC - $200/board. See BOE binder.
- 253: WBS Definition- / PCB fabrication of the DFEA production board. / Labor BOE- / n/a / M&S BOE - / Based on Run2a DFEA vendor quote - see BOE binder - $350/board / Text9: test each production board on the test stand before intallation
- 254: WBS Definition- / Assembly of the DFEA production boards. / Labor BOE- / n/a / M&S BOE - / Based on Run2a DFE vendor quote - see BOE binder - 100$/board.
- 255: WBS Definition- / Rework of FPGA assemblies on DFEA boards / M&S BOE- / Testing of the DFEA boards at Fermilab will be done using the modified Run2a DFEA infrastructure. We had several problems with FPGA contacts on the Run2a STC boards and this needed rework. This project will have 4 times more FPGAs on the board. Therefore we allocate an average $100 per board for PFGA rework based on vendor quote for Run2a board rework. Quote in BOE binder.
- 256: WBS Definition- / Review and sign-off process prior to entering into production of the Digital Front-End Axial boards - Fermilab participation / Labor BOE- / 1wek of a fermilba Electricalengineerat 50%
- 257: WBS Definition- / Test production boards in special runs in the real Dzero trigger. / Labor BOE- / Done by physicist. Testing of the DFEA boards at Fermilab will be done using the modified Run2a DFEA infrastructure. This setup will be a collaboration between enginner at FNAL, technical person at FNAL, and a physicist who has been involved in the prototype testing. all of these personnel will have been trained on the prototype test phase. We expect to complete the entire test chain using the datapump and be able to test one board every day. This will allow 7 weeks for rework/retest of some of the boards if necessary.
- 258: WBS Definition- / Test production boards in special runs in the real Dzero trigger. / M&S BOE: 25 weeks of Norte Dame engineer at $3609/wk (including 25% benefits and 48.5% indirect). = $90,234 / Labor BOE- / Done by physicist. Testing of the DFEA boards at Fermilab will be done using the modified Run2a DFEA infrastructure. This setup will be a collaboration between enginner at FNAL, technical person at FNAL, and a physicist who has been involved in the prototype testing. all of these personnel will have been trained on the prototype test phase. We expect to complete the entire test chain using the datapump and be able to test one board every day. This will allow 7 weeks for rework/retest of some of the boards if necessary.
- 259: WBS Definition- / Test production boards in special runs in the real Dzero trigger. / Labor BOE- / Done by physicist. Testing of the DFEA boards at Fermilab will be done using the modified Run2a DFEA infrastructure. This setup will be a collaboration between enginner at FNAL, technical person at FNAL, and a physicist who has been involved in the prototype testing. all of these personnel will have been trained on the prototype test phase. We expect to complete the entire test chain using the datapump and be able to test one board every day. This will allow 7 weeks for rework/retest of some of the boards if necessary.
- 260: WBS Definition- / milestone: track trigger complete except for installation and commissioning / 14 April 2004 - New completion date based on restructured tasks for CTT work from Meena Narain. / Text9: milestone
- 263: WBS Definition- / Procure the FPGAs needed for implementing the target algorithm. This is delayed until needed in order to take advantage of price reductions with time. / Labor BOE- / n/a / M&S BOE- / Procure the XC2V FPGAs for all 88 boards (80+8 spares). vendor quote, BOE binder.
- 264: WBS Definition- / Review and sign-off process prior to entering into production of the Digital Front-End Axial boards - Fermilab participation / Labor BOE- / 1wek of Electricalengineerat 50%
- 266: WBS Definition- / Make any necessary modifications to prototype II design. / M&S BOE- / Labor charges based on the BU EDF rate of $45/hr for 1 week / Labor BOE- / Modification of production layout, checking of all layouts based on Run2a STC experience. It took 4 weeks for the final STC production layout and verification. We use the same estimate here.
- 267: WBS Definition- / Procure the parts for building 88 production DFEA. / Labor BOE- / BU technical staff will be responsible for procurement of parts and has experience for procuring parts for the Run1a STC. / M&S BOE - / Labor charges based on the BU EDF rate of $45/hr.
- 268: WBS Definition- / PCB fabrication of the DFEA production board. / Labor BOE- / Based on Run2a STC - includes collecting the files needed by the vendor for PCB fabrication. / M&S BOE - / Labor charges based on the BU EDF rate of $45/hr. / Text9: test each production board on the test stand before intallation
- 269: WBS Definition- / Assembly of the DFEA production boards. / Labor BOE- / Based on Run2a STC - includes collecting the parts needed by the vendor for PCB assembly. / M&S BOE - / Labor charges based on the BU EDF rate of $45/hr.

| ID | WBS | Task | Type | Duration | Start | Finish | Predecessors | Complete | Remaining | Baseline start | Baseline finish | Baseline duration | Total slack | Free slack | Constraint | Resources | Work | Actual work | Cost | Baseline cost | Actual cost | Text26 | Text27 | Text28 | Text29 | Text30 |
| --- | --- | --- | --- | --- | --- | --- | --- | --- | --- | --- | --- | --- | --- | --- | --- | --- | --- | --- | --- | --- | --- | --- | --- | --- | --- | --- |
| 270 | 1.2.3.7.8.9 | **Bench Tests** |  | 70d | 2005-04-06 | 2005-07-14 | 278 |  |  | 2005-02-15 | 2005-05-23 | 70d | 97d |  |  |  | 720h |  | 8,640 | 8,640 |  | Percent Complete |  |  |  |  |
| 271 | 1.2.3.7.8.9.1 | Bench tests at BU |  | 8w | 2005-04-06 | 2005-06-01 |  |  |  | 2005-02-15 | 2005-04-11 | 8w | 97d | 0d |  | ElecEngU [25%]; PhysicistU [50%]; MandSPass [360000%] | 240h |  | 3,600 | 3,600 |  | Percent Complete | BU | EQU | 1.2.3.7.8.9 | 1.2.3.7.8.9.1 |
| 272 | 1.2.3.7.8.9.2 | Board rework+Integration |  | 12w | 2005-04-20 | 2005-07-14 | 271SS+2w |  |  | 2005-03-01 | 2005-05-23 | 12w | 97d |  |  | PhysicistU; MandSPass [504000%] | 480h |  | 5,040 | 5,040 |  | Percent Complete | BU | EQU | 1.2.3.7.8.9 | 1.2.3.7.8.9.2 |
| 273 | 1.2.3.7.8.10 | DFEA firmware |  | 6mo | 2005-01-06 | 2005-06-24 | 266FS+2d |  |  | 2004-11-04 | 2005-05-04 | 6mo | 110d |  |  | ElecEngU [33%]; InKind | 316.8h |  | 14,400 | 14,400 |  | Percent Complete |  | INK-OTHER |  |  |
| 274 | 1.2.3.7.11 | **MRI Tasks-BU** |  | 100d | 2005-01-04 | 2005-05-24 |  |  |  | 2004-11-02 | 2005-04-04 | 100d | 97d |  |  |  |  |  | 453,068 | 453,068 |  |  |  |  |  |  |
| 275 | 1.2.3.7.11.1 | Procure FPGAs |  | 20w | 2005-01-04 | 2005-05-24 | 266 |  |  | 2004-11-02 | 2005-04-04 | 20w | 132d |  |  | InKind |  |  | 439,296 | 439,296 |  | Percent Complete | BU | INK-MRI2 |  |  |
| 276 | 1.2.3.7.11.2 | Procure production parts |  | 6w | 2005-01-04 | 2005-02-15 | 266 |  |  | 2004-11-02 | 2004-12-15 | 6w | 97d | 0d |  | InKind [552200%] |  |  | 5,522 | 5,522 |  | Percent Complete | BU | INK-MRI2 |  |  |
| 277 | 1.2.3.7.11.3 | PCB Fabricate |  | 6w | 2005-01-26 | 2005-03-08 | 276SS+3w |  |  | 2004-11-23 | 2005-01-14 | 6w | 97d | 0d |  | InKind [380000%] |  |  | 3,800 | 3,800 |  | Percent Complete | BU | INK-MRI2 |  |  |
| 278 | 1.2.3.7.11.4 | Assembly |  | 4w | 2005-03-09 | 2005-04-05 | 277 |  |  | 2005-01-18 | 2005-02-14 | 4w | 97d | 0d |  | InKind [445000%] |  |  | 4,450 | 4,450 |  | Percent Complete | BU | INK-MRI2 |  |  |
| 279 | 1.2.3.7.12 | Production readiness review-Fermilab |  | 1w | 2004-12-03 | 2004-12-09 | 238 |  |  | 2004-10-12 | 2004-10-18 | 1w | 242d |  |  | ElecEngF [50%] | 20h |  | 1,100 | 1,100 |  | Percent Complete | FNAL | EQU | 1.2.3.7.12 | 1.2.3.7.12 |
| 280 | 1.2.3.7.13 | Test at Fermilab |  | 12w | 2005-04-20 | 2005-07-14 | 271SS+2w |  |  | 2005-03-01 | 2005-05-23 | 12w | 97d |  |  | PhysicistU | 480h |  |  |  |  | Percent Complete | KU | INK-OTHER |  |  |
| 281 | 1.2.3.7.14 | Test at Fermilab |  | 12w | 2005-04-20 | 2005-07-14 | 271SS+2w |  |  | 2005-03-01 | 2005-05-23 | 12w | 97d |  |  | PhysicistU; MandS; ElecTechU | 960h |  | 36,750 | 36,750 |  | Percent Complete | ND | EQU | 1.2.3.7.14 | 1.2.3.7.14 |
| 282 | 1.2.3.7.15 | Test at Fermilab |  | 12w | 2005-04-20 | 2005-07-14 | 271SS+2w |  |  | 2005-03-01 | 2005-05-23 | 12w | 97d | 0d |  | PhysicistF [50%]; ElecTechF | 720h |  | 18,720 | 18,720 |  | Percent Complete | FNAL | EQU | 1.2.3.7.15 | 1.2.3.7.15 |
| 283 | 1.2.3.8 | **DFEA Backplane (BP)** |  | 196d | 2004-01-14 A | 2004-10-19 |  | 77% | 44.21d | 2004-01-14 | 2004-09-13 | 170d | 277d |  |  |  | 236h | 96h | 24,580 | 24,580 | 21,280 |  |  |  |  |  |
| 284 | 1.2.3.8.1 | hardware spec |  | 21d | 2004-01-14 A | 2004-02-12 A |  | 100% |  | 2004-01-14 | 2004-02-12 | 21d |  |  | finish no earlier than 2004-02-12 | ElecEngF [20%] | 33.6h | 33.6h | 1,848 | 1,848 | 1,848 | Percent Complete | FNAL | EQU | 1.2.3.8 | 1.2.3.8.1 |
| 285 | 1.2.3.8.2 | timing spec (for CC/BP/DFEA) |  | 14d | 2004-01-27 A | 2004-02-13 A |  | 100% |  | 2004-01-27 | 2004-02-13 | 14d |  |  | finish no earlier than 2004-02-13 | ElecEngF [20%] | 22.4h | 22.4h | 1,232 | 1,232 | 1,232 | Percent Complete | FNAL | EQU | 1.2.3.8 | 1.2.3.8.2 |
| 286 | 1.2.3.8.3 | interface specs (hardware+timing) finished | milestone | 0d | 2004-03-08 A | 2004-03-08 A | 285 | 100% |  | 2004-03-08 | 2004-03-08 | 0d |  |  | start no earlier than 2004-03-08 |  |  |  |  |  |  |  |  |  |  |  |
| 287 | 1.2.3.8.4 | PRR (incl. Signoff on 48 V and Backplane pinout/pinthrough) | milestone | 0d | 2004-04-30 A | 2004-04-30 A | 286 | 100% |  | 2004-04-30 | 2004-04-30 | 0d |  |  | start no earlier than 2004-04-30 |  |  |  |  |  |  |  |  |  |  |  |
| 288 | 1.2.3.8.5 | get quotes; decide on vendor |  | 1mo | 2004-03-19 A | 2004-04-15 A | 286 | 100% |  | 2004-03-19 | 2004-04-15 | 1mo |  |  | start no earlier than 2004-03-19 | ElecEngF [25%] | 40h | 40h | 2,200 | 2,200 | 2,200 | Percent Complete | FNAL | EQU | 1.2.3.8 | 1.2.3.8.5 |
| 289 | 1.2.3.8.6 | schematic (vendor) |  | 0.7mo | 2004-05-24 A | 2004-06-11 A | 287, 288 | 100% |  | 2004-04-30 | 2004-05-27 | 1mo |  |  |  |  |  |  |  |  |  | Percent Complete | FNAL | EQU | 1.2.3.8 | 1.2.3.8.6 |
| 290 | 1.2.3.8.7 | schematic review |  | 2d | 2004-06-14 A | 2004-06-15 A | 289 | 100% |  | 2004-05-28 | 2004-06-01 | 2d |  |  |  |  |  |  |  |  |  | Percent Complete | FNAL | EQU | 1.2.3.8 | 1.2.3.8.7 |
| 291 | 1.2.3.8.8 | layout at vendor |  | 0.55mo | 2004-06-16 A | 2004-06-30 A | 290 | 100% |  | 2004-06-02 | 2004-06-29 | 1mo |  |  |  |  |  |  |  |  |  | Percent Complete | FNAL | EQU | 1.2.3.8 | 1.2.3.8.8 |
| 292 | 1.2.3.8.9 | layout review |  | 2d | 2004-07-01 A | 2004-07-05 A | 291 | 100% |  | 2004-06-30 | 2004-07-01 | 2d |  |  |  |  |  |  |  |  |  | Percent Complete | FNAL | EQU | 1.2.3.8 | 1.2.3.8.9 |
| 293 | 1.2.3.8.10 | ready for production | milestone | 0d | 2004-07-05 A | 2004-07-05 A | 292 | 100% |  | 2004-07-01 | 2004-07-01 | 0d |  |  |  |  |  |  |  |  |  |  |  |  |  |  |
| 294 | 1.2.3.8.11 | production + vendor checkout |  | 0.95mo | 2004-07-06 A | 2004-07-30 A | 293 | 100% |  | 2004-07-05 | 2004-07-30 | 1mo |  |  |  | MandS |  |  | 16,000 | 16,000 | 16,000 | Percent Complete | FNAL | EQU | 1.2.3.8 | 1.2.3.8.11 |
| 295 | 1.2.3.8.12 | first BP received | milestone | 0d | 2004-08-16 A | 2004-08-16 A | 294FS+2.2w | 100% |  | 2004-07-30 | 2004-07-30 | 0d |  |  |  |  |  |  |  |  |  |  |  |  |  |  |
| 296 | 1.2.3.8.13 | FNAL checkout |  | 2w | 2004-09-08 | 2004-09-21 | 295FS+3w |  |  | 2004-08-02 | 2004-08-13 | 2w | 84d | 0d |  | ElecEngF [25%] | 20h |  | 1,100 | 1,100 |  | Percent Complete | FNAL | EQU | 1.2.3.8 | 1.2.3.8.13 |
| 297 | 1.2.3.8.14 | crate assembly + bench test |  | 2w | 2004-09-22 | 2004-10-05 | 296 |  |  | 2004-08-16 | 2004-08-27 | 2w | 84d | 0d |  | ElecEngF [25%] | 20h |  | 1,100 | 1,100 |  | Percent Complete | FNAL | EQU | 1.2.3.8 | 1.2.3.8.14 |
| 298 | 1.2.3.8.15 | test with CC |  | 2w | 2004-10-06 | 2004-10-19 | 297, 311 |  |  | 2004-08-30 | 2004-09-13 | 2w | 116d | 0d |  | ElecEngF [25%]; PhysicistU | 100h |  | 1,100 | 1,100 |  | Percent Complete | FNAL | EQU | 1.2.3.8 | 1.2.3.8.15 |
| 299 | 1.2.3.8.16 | Ready for platform test crate installation | milestone | 0d | 2004-10-19 | 2004-10-19 | 298 |  |  | 2004-09-13 | 2004-09-13 | 0d | 277d |  |  |  |  |  |  |  |  |  |  |  |  |  |

Notes:
- 270: WBS Definition- / Test each production board on the test stand before intallation. / M&S BOE- / Labor charges based on the BU EDF rate of $40/hr and an overhead of 61.5%. / Labor BOE- / Test 10 boards a week. To be done by BU EDF engineer in conjunction with a physicist. / Text9: test each production board on the test stand before intallation
- 271: WBS Definition- / Test each production board on the test stand before intallation. / M&S BOE- / Labor charges based on the BU EDF rate of $45/hr. / Labor BOE- / Test 10 boards a week. To be done by BU EDF engineer in conjunction with a physicist. / Text9: test each production board on the test stand before intallation
- 272: WBS Definition- / Rework of FPGA assemblies on DFEA boards / M&S BOE- / Testing of the DFEA boards at Fermilab will be done using the modified Run2a DFEA infrastructure. We had several problems with FPGA contacts on the Run2a STC boards and this needed rework. This project will have 4 times more FPGAs on the board. Therefore we allocate an average $100 per board for PFGA rework based on vendor quote for Run2a board rework. Quote in BOE binder.
- 273: WBS Definition- / Re-test each board after delivery to Fermilab. / M&S BOE- / Labor charges based on the BU EDF rate of $45/hr . / Labor BOE- / Design, development, integration and tests of the DFEA firmware for 2 months
- 275: WBS Definition- / Procure the FPGAs needed for implementing the target algorithm. This is delayed until needed in order to take advantage of price reductions with time. / Labor BOE- / n/a / M&S BOE- / Procure the XC2V FPGAs for all 88 boards (80+8 spares). vendor quote, BOE binder.
- 276: WBS Definition- / Procure the parts for building 100 production DFEA. / Labor BOE- / n/a / M&S BOE - / Cost based on per board prototype parts for the STC - $55/board revised quote April 2004. / quantities less than 100 are not available always. so estimate for 100 hundred boards.
- 277: WBS Definition- / PCB fabrication of the DFEA production board. / Labor BOE- / n/a / M&S BOE - / Based on Run2a DFEA vendor quote - see BOE binder - $38/board- quotes for 100 boards (april 2004) / Text9: test each production board on the test stand before intallation
- 278: WBS Definition- / Assembly of the DFEA production boards. / Labor BOE- / n/a / M&S BOE - / Based on Run2a DFE vendor quote - see BOE binder - 44.50$/board for 100 boards. / revised quote April 2004
- 279: WBS Definition- / Review and sign-off process prior to entering into production of the Digital Front-End Axial boards - Fermilab participation / Labor BOE- / 1wek of a fermilba Electricalengineerat 50%
- 280: WBS Definition- / Test production boards in special runs in the real Dzero trigger. / Labor BOE- / Done by physicist. Testing of the DFEA boards at Fermilab will be done using the modified Run2a DFEA infrastructure. This setup will be a collaboration between enginner at FNAL, technical person at FNAL, and a physicist who has been involved in the prototype testing. all of these personnel will have been trained on the prototype test phase. We expect to complete the entire test chain using the datapump and be able to test one board every day. This will allow 7 weeks for rework/retest of some of the boards if necessary.
- 281: WBS Definition- / Test production boards in special runs in the real Dzero trigger. / M&S BOE: 25 weeks of Norte Dame engineer at $3609/wk (including 25% benefits and 48.5% indirect). = $90,234 / Labor BOE- / Done by physicist. Testing of the DFEA boards at Fermilab will be done using the modified Run2a DFEA infrastructure. This setup will be a collaboration between enginner at FNAL, technical person at FNAL, and a physicist who has been involved in the prototype testing. all of these personnel will have been trained on the prototype test phase. We expect to complete the entire test chain using the datapump and be able to test one board every day. This will allow 7 weeks for rework/retest of some of the boards if necessary.
- 282: WBS Definition- / Test production boards in special runs in the real Dzero trigger. / Labor BOE- / Done by physicist. Testing of the DFEA boards at Fermilab will be done using the modified Run2a DFEA infrastructure. This setup will be a collaboration between enginner at FNAL, technical person at FNAL, and a physicist who has been involved in the prototype testing. all of these personnel will have been trained on the prototype test phase. We expect to complete the entire test chain using the datapump and be able to test one board every day. This will allow 7 weeks for rework/retest of some of the boards if necessary.
- 284: Jamieson Olsen
- 285: JO
- 288: JO
- 294: $6000 NRE / $2000 each backplane / 5 backplanes total
- 296: JO
- 297: JO
- 298: JO + Oana

| ID | WBS | Task | Type | Duration | Start | Finish | Predecessors | Complete | Remaining | Baseline start | Baseline finish | Baseline duration | Total slack | Free slack | Constraint | Resources | Work | Actual work | Cost | Baseline cost | Actual cost | Text26 | Text27 | Text28 | Text29 | Text30 | Text23 |
| --- | --- | --- | --- | --- | --- | --- | --- | --- | --- | --- | --- | --- | --- | --- | --- | --- | --- | --- | --- | --- | --- | --- | --- | --- | --- | --- | --- |
| 300 | 1.2.3.9 | **DFEA Crate Controller (CC)** |  | 356d | 2003-12-01 A | 2005-05-10 |  | 47% | 187.08d | 2003-12-01 | 2005-03-29 | 326d | 142d |  |  |  | 1223.02h | 465.4h | 70,266.1 | 70,100 | 32,457 |  |  |  |  |  |  |
| 301 | 1.2.3.9.1 | interface specs |  | 1mo | 2003-12-01 A | 2004-01-06 A |  | 100% |  | 2003-12-01 | 2004-01-06 | 1mo |  |  | start no earlier than 2003-12-01 | ElecEngF | 160h | 160h | 8,800 | 8,800 | 8,800 | Percent Complete | FNAL | EQU | 1.2.3.9 | 1.2.3.9.1 |  |
| 302 | 1.2.3.9.2 | schematic |  | 2mo | 2004-03-15 A | 2004-05-07 A | 301 | 100% |  | 2004-03-15 | 2004-05-07 | 2mo |  |  | start no earlier than 2004-03-15 | ElecEngF [25%] | 80h | 80h | 4,400 | 4,400 | 4,400 | Percent Complete | FNAL | EQU | 1.2.3.9 | 1.2.3.9.2 |  |
| 303 | 1.2.3.9.3 | Decision to use 48 V power distribution scheme or 3.3 V | milestone | 0d | 2004-05-07 A | 2004-05-07 A | 302 | 100% |  | 2004-05-07 | 2004-05-07 | 0d |  |  |  |  |  |  |  |  |  |  |  |  |  |  |  |
| 304 | 1.2.3.9.4 | production readiness review (PRR) |  | 2w | 2004-05-10 A | 2004-05-21 A | 303 | 100% |  | 2004-05-10 | 2004-05-21 | 2w |  |  |  |  |  |  |  |  |  | Percent Complete | FNAL | EQU | 1.2.3.9 | 1.2.3.9.4 |  |
| 305 | 1.2.3.9.5 | layout; order long leadtime parts |  | 1mo | 2004-05-10 A | 2004-06-07 A | 302 | 100% |  | 2004-05-10 | 2004-06-07 | 1mo |  |  |  | ElecEngF [25%] | 40h | 40h | 2,200 | 2,200 | 2,200 | Percent Complete | FNAL | EQU | 1.2.3.9 | 1.2.3.9.5 |  |
| 306 | 1.2.3.9.6 | PCB production + vendor testing |  | 6w | 2004-07-05 A | 2004-08-13 A | 304, 305FS+18d | 100% |  | 2004-06-08 | 2004-06-21 | 2w |  |  | start no earlier than 2004-01-14 | MandS [750000%] |  |  | 7,500 | 7,500 | 7,500 | Percent Complete | FNAL | EQU | 1.2.3.9 | 1.2.3.9.6 |  |
| 307 | 1.2.3.9.7 | assembly (vendor + FNAL) |  | 1mo | 2004-07-19 A | 2004-08-13 A | 306FS-4w | 100% |  | 2004-06-22 | 2004-07-20 | 1mo |  |  | start no earlier than 2004-01-14 | ElecTechF [25%] | 40h | 40h | 1,560 | 1,560 | 1,560 | Percent Complete | FNAL | EQU | 1.2.3.9 | 1.2.3.9.7 |  |
| 308 | 1.2.3.9.8 | checkout |  | 2w | 2004-08-16 A | 2004-08-27 A | 307 | 100% |  | 2004-07-21 | 2004-08-03 | 2w |  |  | start no earlier than 2004-01-14 | ElecEngF [25%] | 20h | 20h | 1,100 | 1,100 | 1,100 | Percent Complete | FNAL | EQU | 1.2.3.9 | 1.2.3.9.8 |  |
| 309 | 1.2.3.9.9 | write test firmware |  | 5.5mo | 2004-04-09 A | 2004-09-14 |  | 75% | 1.38mo | 2004-04-09 | 2004-08-02 | 4mo | 121d | 0d | start no earlier than 2004-04-09 | ElecEngF [19%] | 163.02h | 125.4h | 8,966.1 | 8,800 | 6,897 | Percent Complete | FNAL | EQU | 1.2.3.9 | 1.2.3.9.9 | CC |
| 310 | 1.2.3.9.10 | finish production firmware |  | 8mo | 2004-09-15 | 2005-05-10 | 309 |  |  | 2004-08-03 | 2005-03-29 | 8mo | 142d |  |  | ElecEngF [25%] | 320h |  | 17,600 | 17,600 |  | Percent Complete | FNAL | EQU | 1.2.3.9 | 1.2.3.9.10 |  |
| 311 | 1.2.3.9.11 | bench test |  | 2w | 2004-09-15 | 2004-09-28 | 308, 309, 324SS+1.5mo |  |  | 2004-08-04 | 2004-08-17 | 2w | 121d | 0d | start no earlier than 2004-01-14 | ElecEngF [25%]; PhysicistU | 100h |  | 1,100 | 1,100 |  | Percent Complete | FNAL | EQU | 1.2.3.9 | 1.2.3.9.11 |  |
| 312 | 1.2.3.9.12 | 2nd prototype layout |  | 2w | 2004-09-29 | 2004-10-12 | 311 |  |  | 2004-08-18 | 2004-08-31 | 2w | 232d | 0d |  | ElecEngF [25%] | 20h |  | 1,100 | 1,100 |  | Percent Complete | FNAL | EQU | 1.2.3.9 | 1.2.3.9.12 |  |
| 313 | 1.2.3.9.13 | 2nd prototype PCB production + vendor testing |  | 2w | 2004-10-13 | 2004-10-26 | 312 |  |  | 2004-09-01 | 2004-09-15 | 2w | 232d | 0d |  | MandS [750000%] |  |  | 7,500 | 7,500 |  | Percent Complete | FNAL | EQU | 1.2.3.9 | 1.2.3.9.13 |  |
| 314 | 1.2.3.9.14 | 2nd prototype assembly |  | 1mo | 2004-10-27 | 2004-11-23 | 313 |  |  | 2004-09-16 | 2004-10-13 | 1mo | 232d | 0d |  | ElecTechF | 160h |  | 6,240 | 6,240 |  | Percent Complete | FNAL | EQU | 1.2.3.9 | 1.2.3.9.14 |  |
| 315 | 1.2.3.9.15 | 2nd prototype checkout |  | 2w | 2004-11-24 | 2004-12-09 | 314 |  |  | 2004-10-14 | 2004-10-27 | 2w | 232d | 0d |  | ElecEngF [25%] | 20h |  | 1,100 | 1,100 |  | Percent Complete | FNAL | EQU | 1.2.3.9 | 1.2.3.9.15 |  |
| 316 | 1.2.3.9.16 | 2nd prototype bench test |  | 2w | 2004-12-10 | 2004-12-23 | 315 |  |  | 2004-10-28 | 2004-11-10 | 2w | 232d | 0d |  | ElecEngF [25%]; PhysicistU | 100h |  | 1,100 | 1,100 |  | Percent Complete | FNAL | EQU | 1.2.3.9 | 1.2.3.9.16 |  |
| 317 | 1.2.3.9.17 | CC ready | milestone | 0d | 2004-12-23 | 2004-12-23 | 316 |  |  | 2004-11-10 | 2004-11-10 | 0d | 232d |  |  |  |  |  |  |  |  |  |  |  |  |  |  |
| 318 | 1.2.3.10 | **optical DCL (host)** |  | 221d | 2004-02-12 A | 2004-12-23 |  | 58% | 93.09d | 2004-02-12 | 2004-11-09 | 191d | 232d |  |  |  | 1162.56h | 506.16h | 34,372.8 | 38,180 | 26,082 |  |  |  |  |  |  |
| 319 | 1.2.3.10.1 | interface specs |  | 1mo | 2004-02-12 A | 2004-03-10 A |  | 100% |  | 2004-02-12 | 2004-03-10 | 1mo |  |  | start no earlier than 2004-02-12 | ElecEngF | 160h | 160h | 8,800 | 8,800 | 8,800 | Percent Complete | FNAL | EQU | 1.2.3.10 | 1.2.3.10.1 |  |
| 320 | 1.2.3.10.2 | hardware specs |  | 1mo | 2004-03-11 A | 2004-04-07 A | 319 | 100% |  | 2004-03-11 | 2004-04-07 | 1mo |  |  | start no earlier than 2004-01-14 | ElecEngF | 100h | 100h | 5,500 | 5,500 | 5,500 | Percent Complete | FNAL | EQU | 1.2.3.10 | 1.2.3.10.2 |  |
| 321 | 1.2.3.10.3 | specs done | milestone | 0d | 2004-04-09 A | 2004-04-09 A | 320 | 100% |  | 2004-04-09 | 2004-04-09 | 0d |  |  | start no earlier than 2004-04-09 |  |  |  |  |  |  |  |  |  |  |  |  |
| 322 | 1.2.3.10.4 | decide on hardware |  | 2.3mo | 2004-04-09 A | 2004-06-14 A | 321 | 100% |  | 2004-04-09 | 2004-05-06 | 1mo |  |  |  | ElecEngF [3%] | 10.56h | 10.56h | 580.8 | 440 | 580.8 | Percent Complete | FNAL | EQU | 1.2.3.10 | 1.2.3.10.4 | CC |
| 323 | 1.2.3.10.5 | hardware procurement |  | 1mo | 2004-05-17 A | 2004-06-14 A | 322FS-4w | 100% |  | 2004-05-07 | 2004-06-04 | 1mo |  |  | start no earlier than 2004-01-14 | ElecEngF [10%] | 16h | 16h | 880 | 880 | 880 | Percent Complete | FNAL | EQU | 1.2.3.10 | 1.2.3.10.5 |  |
| 324 | 1.2.3.10.6 | software: Linux driver |  | 1.8mo | 2004-04-09 A | 2004-05-28 A | 320 | 100% |  | 2004-04-09 | 2004-07-05 | 3mo |  |  | start no earlier than 2004-04-09 | CompProfF [50%] | 144h | 144h | 6,768 | 11,280 | 6,768 | Percent Complete | FNAL | EQU | 1.2.3.10 | 1.2.3.10.6 |  |
| 325 | 1.2.3.10.7 | software: EPICS driver + integration |  | 4.5mo | 2004-05-21 A | 2004-09-28 | 324SS+1.5mo | 30% | 3.15mo | 2004-05-21 | 2004-08-16 | 3mo | 232d | 0d | start no earlier than 2004-01-14 | CompProfF [35%] | 252h | 75.6h | 11,844 | 11,280 | 3,553.2 | Percent Complete | FNAL | EQU | 1.2.3.10 | 1.2.3.10.7 | CC |
| 326 | 1.2.3.10.8 | software: dfe_ware integration |  | 3mo | 2004-09-29 | 2004-12-23 | 319, 325 |  |  | 2004-08-17 | 2004-11-09 | 3mo | 232d |  | start no earlier than 2004-01-14 | PhysicistU | 480h |  |  |  |  | Percent Complete | FNAL | EQU | 1.2.3.10 | 1.2.3.10.8 |  |

Notes:
- 301: JO
- 302: JO / optical receivers for / a) download + control (adapting Ohio State example) / b) SCL / are integrated (changed from: SCL receiver as a daughter card)
- 305: 14th floor; need better time estimate
- 306: PO has to be all done before layout goes out
- 307: $1500 per Crate Controller; assumed 5 built
- 308: JO
- 309: JO
- 310: JO
- 311: JO + Oana
- 318: commodity hardware and driver software for / the host side of the / optical download ond control link; / the CC side is part of the CC task
- 319: JO
- 320: JO
- 323: 2004-4-22: For now (development and test) we are all set; we might need some extra hardware / (extra fiber ports for the switch, or copper-to-fiber gigabit converters) in the fall.
- 324: Ron Rechenmacher or equiv. / 2004-4-19: it seems very likely that this task will be substantially reduced / in complexity and duration, / and be taken care of by a combination of Geoff Savage (Comp.Prof.F), / Oana Boeriu (Phys.U) and Jamieson Olsen (ElecEngF)
- 325: Geoff Savage or equiv.
- 326: Yurii Maravin replacement

| ID | WBS | Task | Type | Duration | Start | Finish | Predecessors | Complete | Remaining | Baseline start | Baseline finish | Baseline duration | Total slack | Free slack | Constraint | Resources | Work | Actual work | Cost | Baseline cost | Actual cost | Text26 | Text27 | Text28 | Text29 | Text30 | Text23 |
| --- | --- | --- | --- | --- | --- | --- | --- | --- | --- | --- | --- | --- | --- | --- | --- | --- | --- | --- | --- | --- | --- | --- | --- | --- | --- | --- | --- |
| 327 | 1.2.3.11 | **LVDS Splitter** |  | 112d | 2004-05-03 A | 2004-10-08 |  | 64% | 40d | 2004-05-03 | 2004-09-22 | 100d | 284d |  |  |  | 226h | 126h | 18,430 | 22,500 | 9,930 |  |  |  |  |  |  |
| 328 | 1.2.3.11.1 | schematic |  | 2w | 2004-05-03 A | 2004-05-14 A |  | 100% |  | 2004-05-03 | 2004-05-14 | 2w |  |  | start no earlier than 2004-05-03 | ElecEngF | 80h | 80h | 4,400 | 4,400 | 4,400 | Percent Complete | FNAL | EQU | 1.2.3.11 | 1.2.3.11.1 |  |
| 329 | 1.2.3.11.2 | layout |  | 4w | 2004-05-17 A | 2004-06-14 A | 328 | 100% |  | 2004-05-17 | 2004-05-28 | 2w |  |  |  | ElecEngF [50%] | 44h | 44h | 2,420 | 4,400 | 2,420 | Percent Complete | FNAL | EQU | 1.2.3.11 | 1.2.3.11.2 |  |
| 330 | 1.2.3.11.3 | production |  | 8.2w | 2004-06-15 A | 2004-08-11 A | 329 | 100% |  | 2004-06-01 | 2004-06-28 | 1mo |  |  |  | MandS [300000%] |  |  | 3,000 | 3,000 | 3,000 | Percent Complete | FNAL | EQU | 1.2.3.11 | 1.2.3.11.3 |  |
| 331 | 1.2.3.11.4 | test |  | 0.2w | 2004-08-12 A | 2004-08-12 A | 330 | 100% |  | 2004-06-29 | 2004-07-27 | 1mo |  |  |  | ElecEngF [25%] | 2h | 2h | 110 | 2,200 | 110 | Percent Complete | FNAL | EQU | 1.2.3.11 | 1.2.3.11.4 |  |
| 332 | 1.2.3.11.5 | 2nd prototype layout |  | 2w | 2004-08-13 | 2004-08-26 | 331 |  |  | 2004-07-28 | 2004-08-10 | 2w | 284d | 0d |  | ElecEngF | 80h |  | 4,400 | 4,400 |  | Percent Complete | FNAL | EQU | 1.2.3.11 | 1.2.3.11.5 |  |
| 333 | 1.2.3.11.6 | 2nd prototype production |  | 1mo | 2004-08-27 | 2004-09-24 | 332 |  |  | 2004-08-11 | 2004-09-08 | 1mo | 284d | 0d |  | MandS [300000%] |  |  | 3,000 | 3,000 |  | Percent Complete | FNAL | EQU | 1.2.3.11 | 1.2.3.11.6 |  |
| 334 | 1.2.3.11.7 | 2nd prototype test |  | 2w | 2004-09-27 | 2004-10-08 | 333 |  |  | 2004-09-09 | 2004-09-22 | 2w | 284d | 0d |  | ElecEngF [25%] | 20h |  | 1,100 | 1,100 |  | Percent Complete | FNAL | EQU | 1.2.3.11 | 1.2.3.11.7 |  |
| 335 | 1.2.3.11.8 | ready for platform test | milestone | 0d | 2004-10-08 | 2004-10-08 | 334 |  |  | 2004-09-22 | 2004-09-22 | 0d | 284d |  |  |  |  |  |  |  |  |  |  |  |  |  |  |
| 336 | 1.2.3.12 | **DFE Motherboard (DFEM)** |  | 328d | 2004-04-09 A | 2005-08-02 |  | 25% | 247.54d | 2004-04-09 | 2005-06-10 | 292d | 84d | 0d |  |  | 3406.4h | 969.31h | 148,960 | 148,960 | 56,560 |  |  |  |  |  |  |
| 337 | 1.2.3.12.1 | Develop Schematic for MB Prototype I |  | 6.4w | 2004-04-09 A | 2004-05-24 A |  | 100% |  | 2004-04-09 | 2004-04-22 | 2w |  |  | start no earlier than 2004-04-09 | ElecEngU; MandSPass [360000%] | 256h | 256h | 3,600 | 3,600 | 3,600 | Percent Complete | BU | EQU | 1.2.3.12.1 | 1.2.3.12.1 | CC |
| 338 | 1.2.3.12.2 | Layout Prototype I |  | 6w | 2004-05-11 A | 2004-06-22 A | 303FF+2w, 337FS-2w | 100% |  | 2004-04-30 | 2004-05-27 | 4w |  |  |  | ElecEngU; MandSPass [720000%] | 240h | 240h | 7,200 | 7,200 | 7,200 | Percent Complete | BU | EQU | 1.2.3.12.2 | 1.2.3.12.2 | CC |
| 339 | 1.2.3.12.3 | Procure preproduction DFEM parts Prototype I |  | 8w | 2004-05-14 A | 2004-07-12 A | 338FS-3.4w | 100% |  | 2004-05-14 | 2004-06-22 | 5.4w |  |  | finish no earlier than 2004-07-20 | ElecTechU [20%]; InKind [256000%] | 64h | 64h | 2,560 | 2,560 | 2,560 | Percent Complete | BU | EQU | 1.2.3.12.3 | 1.2.3.12.3 | CC |
| 340 | 1.2.3.12.4 | PCB fabrication Prototype I |  | 2w | 2004-06-28 A | 2004-07-12 A | 338FS+3d | 100% |  | 2004-06-03 | 2004-06-23 | 3w |  |  |  | ElecTechU [20%]; InKind [400000%] | 16h | 16h | 4,000 | 4,000 | 4,000 | Percent Complete | BU | INK-MRI2 |  |  |  |
| 341 | 1.2.3.12.5 | Assembly Prototype I |  | 2w | 2004-07-16 A | 2004-07-29 A | 340FS+3d | 100% |  | 2004-06-29 | 2004-07-13 | 2w |  |  |  | ElecTechU [15%]; InKind [170000%] | 12h | 12h | 1,700 | 1,700 | 1,700 | Percent Complete | BU | INK-MRI2 |  |  |  |
| 342 | 1.2.3.12.6 | Test Prototype I |  | 6w | 2004-07-30 A | 2004-09-10 | 341 | 80% | 1.2w | 2004-07-14 | 2004-08-10 | 4w | 304d |  |  | ElecEngU [50%]; PhysicistU [50%]; InKind [530000%] | 240h | 192h | 5,300 | 5,300 | 5,300 | Percent Complete | BU | INK-MRI2 |  |  |  |
| 343 | 1.2.3.12.7 | Test at Fermilab Prototype I (+DFEA) |  | 6w | 2004-10-20 | 2004-12-02 | 298 |  |  | 2004-09-14 | 2004-10-25 | 6w | 247d |  |  | ElecEngU [50%]; PhysicistU; MandSPass [540000%] | 360h |  | 5,400 | 5,400 |  | Percent Complete | BU | EQU | 1.2.3.12.7 | 1.2.3.12.7 | CC |
| 344 | 1.2.3.12.8 | Schematic + Layout Prototype II |  | 2w | 2004-12-03 | 2004-12-16 | 226 |  |  | 2004-10-12 | 2004-10-25 | 2w | 84d | 0d |  | ElecEngU; ElecTechU [10%]; MandSPass [360000%] | 88h |  | 3,600 | 3,600 |  | Percent Complete | BU | EQU | 1.2.3.12.8 | 1.2.3.12.8 | CC |
| 345 | 1.2.3.12.9 | Procure preproduction DFEM parts Prototype II |  | 2w | 2004-12-03 | 2004-12-16 | 344FS-2w |  |  | 2004-10-12 | 2004-10-25 | 2w | 237d |  |  | ElecTechU [15%]; InKind [205000%] | 12h |  | 2,050 | 2,050 |  | Percent Complete | BU | INK-MRI2 |  |  |  |
| 346 | 1.2.3.12.10 | PCB fabrication Prototype II |  | 2w | 2005-01-04 | 2005-01-18 | 344FS+1w |  |  | 2004-11-02 | 2004-11-15 | 2w | 84d | 0d |  | ElecTechU [10%]; InKind [400000%] | 8h |  | 4,000 | 4,000 |  | Percent Complete | BU | INK-MRI2 |  |  |  |
| 347 | 1.2.3.12.11 | Assembly Prototype II |  | 3w | 2005-01-19 | 2005-02-08 | 346 |  |  | 2004-11-16 | 2004-12-08 | 3w | 84d | 0d |  | ElecTechU [10%]; InKind [170000%] | 12h |  | 1,700 | 1,700 |  | Percent Complete | BU | INK-MRI2 |  |  |  |
| 348 | 1.2.3.12.12 | Test Prototype II |  | 4w | 2005-02-14 | 2005-03-11 | 347FS+3d |  |  | 2004-12-14 | 2005-01-20 | 4w | 84d | 0d |  | ElecEngU [25%]; PhysicistU [50%]; MandSPass [180000%] | 120h |  | 1,800 | 1,800 |  | Percent Complete | BU | EQU | 1.2.3.12.12 | 1.2.3.12.12 | CC |
| 349 | 1.2.3.12.13 | Test at Fermilab Prototype II integrated into system at FNAL |  | 4w | 2005-02-28 | 2005-03-25 | 348SS+2w |  |  | 2005-01-06 | 2005-02-03 | 4w | 169d | 0d |  | ElecEngU [25%]; PhysicistU; MandSPass [180000%] | 200h |  | 1,800 | 1,800 |  | Percent Complete | BU | EQU | 1.2.3.12.13 | 1.2.3.12.13 | CC |
| 350 | 1.2.3.12.14 | Production readiness review-BU |  | 1w | 2005-03-28 | 2005-04-01 | 349 |  |  | 2005-02-04 | 2005-02-10 | 1w | 169d | 0d |  | ElecEngU [50%]; PhysicistU; MandSPass [180000%] | 60h |  | 1,800 | 1,800 |  | Percent Complete | BU | EQU | 1.2.3.12.14 | 1.2.3.12.14 | CC |
| 351 | 1.2.3.12.15 | PRR - DFEM | milestone | 0d | 2005-04-01 | 2005-04-01 | 350 |  |  | 2005-02-10 | 2005-02-10 | 0d | 169d |  |  |  |  |  |  |  |  |  |  |  |  |  |  |
| 352 | 1.2.3.12.16 | Procure production parts |  | 4w | 2005-03-14 | 2005-04-08 | 348 |  |  | 2005-01-21 | 2005-02-17 | 4w | 84d | 0d |  | ElecTechU [10%]; InKind | 16h |  | 25,500 | 25,500 |  | Percent Complete | BU | INK-MRI2 |  |  |  |
| 353 | 1.2.3.12.17 | PCB Fabricate |  | 3w | 2005-03-28 | 2005-04-15 | 352SS+2w |  |  | 2005-02-04 | 2005-02-24 | 3w | 84d | 0d |  | ElecTechU [5%]; InKind [585000%] | 6h |  | 5,850 | 5,850 |  | Percent Complete | BU | INK-MRI2 |  |  |  |
| 354 | 1.2.3.12.18 | Assembly |  | 3w | 2005-04-18 | 2005-05-06 | 353 |  |  | 2005-02-25 | 2005-03-17 | 3w | 84d | 0d |  | ElecTechU [3%]; InKind [380000%] | 3.6h |  | 3,800 | 3,800 |  | Percent Complete | BU | INK-MRI2 |  |  |  |
| 355 | 1.2.3.12.19 | Bench test+rework |  | 8w | 2005-05-09 | 2005-07-05 | 354 |  |  | 2005-03-18 | 2005-05-12 | 8w | 84d | 0d |  | ElecEngU [50%]; PhysicistU [50%]; MandSPass [270000%] | 320h |  | 2,700 | 2,700 |  | Percent Complete | BU | EQU | 1.2.3.12.19 | 1.2.3.12.19 |  |
| 356 | 1.2.3.12.20 | Test at Fermilab (integrated into system) |  | 10w | 2005-05-23 | 2005-08-02 | 355SS+2w |  |  | 2005-04-01 | 2005-06-10 | 10w | 84d |  |  | ElecEngU [20%]; PhysicistU; MandSPass [360000%] | 480h |  | 3,600 | 3,600 |  | Percent Complete | BU | EQU | 1.2.3.12.20 | 1.2.3.12.20 |  |
| 357 | 1.2.3.12.21 | MB Firmware |  | 6mo | 2004-06-24 A | 2004-12-14 | 230FS+3d, 228FS+3d | 70% | 1.8mo | 2004-06-18 | 2004-12-08 | 6mo | 239d | 0d |  | ElecEngU [18%]; MandSPass [720000%] | 172.8h | 120.96h | 7,200 | 7,200 | 7,200 | Percent Complete | BU | EQU | 1.2.3.12.21 | 1.2.3.12.21 |  |

Notes:
- 330: $150 per board (PCB + connectors), 20 boards
- 336: The specs will be developed by S. WU and E. Hazen from Boston Unversity EDF / Labor BOE- / Run2a STC card layout experience. / M&S BOE- / Labor charges based on the BU EDF rate of $45/hr
- 337: The specs will be developed by S. WU and E. Hazen from Boston Unversity EDF / Labor BOE- / Run2a STC card layout experience. / M&S BOE- / Labor charges based on the BU EDF rate of $45/hr
- 338: WBS Definition- / Lay out prototype 1 of DFEM. / Labor BOE- / Run2a STC card layout experience / M&S BOE- / Labor charges based on the BU EDF rate of $45/hr .
- 339: WBS Definition- / Procure the parts for building 5 prototype DFEM. / Labor BOE- / M&S BOE - / parts for MB preproduction. Estimate $512/DFEM. 2560 for 5 DFEM
- 340: WBS Definition- / PCB fabrication of the DFEA board at vendor site. / Labor BOE- / M&S BOE - / $4000 - based on venodr quote April 2004 / Text9: assemble 3 prototype boards and test on test stands
- 341: WBS Definition- / Assembly of the DFEA prototype boards at vendor site. / Labor BOE- / M&S BOE - / $1700 cost for assembly - based on vendor quote April 2004
- 342: WBS Definition- / DFEA prototype board testing. / Labor BOE- / Based on Run2a STC - It took 3 months of a full time physicist and an engineer working at 75% for testing the first prototypes of the STC. / M&S BOE - / Labor charges based on the BU EDF rate of $45/hr.
- 343: WBS Definition- / Test prototypes in special runs in the real Dzero trigger. / Labor BOE- / This will be a first test of the DFEA boards at Fermilab. The DFEA boards will be tested using the modified Run2a DFEA infrastructure. This setup will be a collaboration between engineer at FNAL, technical person at FNAL, and a physicist who has been involved in the prototype testing. The BU engineer who designed the board will act as a consultant to get the FNAL stand running. / M&S BOE- / Labor charges based on the BU EDF rate of $45/hr . / Text9: test prototypes in special runs in the real Dzero trigger
- 344: WBS Definition- / Lay out prototype 1 of DFEM. / Labor BOE- / Run2a STC card layout experience. It took about 5 weeks for layout and verification for the STC card. Add one more week to this phase to take into account BU spring break in March 2004 / M&S BOE- / Labor charges based on the BU EDF rate of $45/hr .
- 345: WBS Definition- / Procure the parts for building three prototype DFEM. / Labor BOE- / BU technical staff will be responsible for procurement of parts and has experience for procuring parts for the Run1a STC. Estimate based on time spent to order STC parts. / costed 3 days. / M&S BOE - / Labor charges based on the BU EDF rate of $45/hr.
- 346: WBS Definition- / PCB fabrication of the DFEA board at vendor site. / Labor BOE- / M&S BOE - / venodr quote April 2004 / Text9: assemble 3 prototype boards and test on test stands
- 347: WBS Definition- / Assembly of the DFEA prototype boards at venodr site. / Labor BOE- / M&S BOE - / vendor quote April 2004
- 348: WBS Definition- / DFEA prototype board testing. / Labor BOE- / Based on Run2a STC - It took 3 months of a full time physicist and an engineer working at 75% for testing the first prototypes of the STC. / M&S BOE - / Labor charges based on the BU EDF rate of $45/hr.
- 349: WBS Definition- / Test prototypes in special runs in the real Dzero trigger. / Labor BOE- / This will be a first test of the DFEA boards at Fermilab. The DFEA boards will be tested using the modified Run2a DFEA infrastructure. This setup will be a collaboration between engineer at FNAL, technical person at FNAL, and a physicist who has been involved in the prototype testing. The BU engineer who designed the board will act as a consultant to get the FNAL stand running. / M&S BOE- / Labor charges based on the BU EDF rate of $45/hr . / Text9: test prototypes in special runs in the real Dzero trigger
- 350: WBS Definition- / Review and sign-off process prior to entering into production of the Digital Front-End Axial boards - BU participation / Labor BOE- / 1 week of a university electrical engineer at 50% - rate 45$/hr
- 352: WBS Definition- / Procure the parts for building 50 production DFEM. / Labor BOE- / M&S BOE - / based on vendor quote $510/board
- 353: WBS Definition- / PCB fabrication of the DFEM production board. / Labor BOE- / Based on Run2a STC - includes collecting the files needed by the vendor for PCB fabrication. / M&S BOE - / Labor charges based on the BU EDF rate of $45/hr. / pcb fab quote from vendor (QApril 2004) / Text9: test each production board on the test stand before intallation
- 354: WBS Definition- / Assembly of the DFEA production boards. / Labor BOE- / M&S BOE - / quote from venodr PAril 2004
- 355: WBS Definition- / Test each production board on the test stand before intallation. / M&S BOE- / Labor charges based on the BU EDF rate of $45/hr. / Labor BOE- / Test 10 boards a week. To be done by BU EDF engineer in conjunction with a physicist. / Text9: test each production board on the test stand before intallation
- 356: WBS Definition- / Re-test each board after delivery to Fermilab. / M&S BOE- / Labor charges based on the BU EDF rate of $45/hr . / Labor BOE- / Testing of the DFEA boards at Fermilab will be done using the modified Run2a DFEA infrastructure. This setup will be a collaboration between enginner at FNAL, technical person at FNAL, and a physicist who has been involved in the prototype testing. Alll of these personnel will have been trained on the prototype test phase. We expect to complete the entire test chain using the datapump and be able to test one board every day. This will allow 7 weeks for rework/retest of some of the boards if necessary. / Text9: test each production board on the test stand before intallation
- 357: WBS Definition- / MB firmwarfe development by Shouxiang Wu / M&S BOE- / Labor charges based on the BU EDF rate of $45/hr . / Labor BOE- / Design, development of the MB firmware.

| ID | WBS | Task | Type | Duration | Start | Finish | Predecessors | Complete | Remaining | Baseline start | Baseline finish | Baseline duration | Total slack | Free slack | Constraint | Resources | Work | Actual work | Cost | Baseline cost | Actual cost | Text26 | Text27 | Text28 | Text29 | Text30 | Text23 |
| --- | --- | --- | --- | --- | --- | --- | --- | --- | --- | --- | --- | --- | --- | --- | --- | --- | --- | --- | --- | --- | --- | --- | --- | --- | --- | --- | --- |
| 358 | 1.2.3.12.22 | **Integration with DFEA** |  | 161d | 2004-10-20 | 2005-06-16 |  |  |  | 2004-09-14 | 2005-05-10 | 161d | 116d |  |  |  | 585.6h |  | 28,800 | 28,800 |  |  |  |  |  |  |  |
| 359 | 1.2.3.12.22.1 | Commision test setup |  | 4w | 2004-10-20 | 2004-11-16 | 298 |  |  | 2004-09-14 | 2004-10-11 | 4w | 116d | 0d |  | ElecEngU; MandSPass [720000%] | 160h |  | 7,200 | 7,200 |  | Percent Complete | BU | EQU | 1.2.3.12.22 | 1.2.3.12.22.1 |  |
| 360 | 1.2.3.12.22.2 | Integrate DFEC+DFEM |  | 2w | 2004-11-17 | 2004-12-02 | 359 |  |  | 2004-10-12 | 2004-10-25 | 2w | 116d | 0d |  | ElecEngU; MandSPass [360000%] | 80h |  | 3,600 | 3,600 |  | Percent Complete | BU | EQU | 1.2.3.12.22 | 1.2.3.12.22.2 |  |
| 361 | 1.2.3.12.22.3 | Integrate DB+MB |  | 2w | 2004-12-03 | 2004-12-16 | 360 |  |  | 2004-10-26 | 2004-11-08 | 2w | 116d | 0d |  | ElecEngU; MandSPass [360000%] | 80h |  | 3,600 | 3,600 |  | Percent Complete | BU | EQU | 1.2.3.12.22 | 1.2.3.12.22.3 |  |
| 362 | 1.2.3.12.22.4 | DB+MB infrastructure Firmware |  | 1mo | 2004-10-25 | 2004-11-19 | 359SS+3d |  |  | 2004-09-17 | 2004-10-14 | 1mo | 254d |  |  | ElecEngU; MandSPass [720000%] | 160h |  | 7,200 | 7,200 |  | Percent Complete | BU | EQU | 1.2.3.12.22 | 1.2.3.12.22.4 |  |
| 363 | 1.2.3.12.22.5 | System tests |  | 6mo | 2004-12-20 | 2005-06-16 | 361FS+1d |  |  | 2004-11-10 | 2005-05-10 | 6mo | 116d |  |  | MandSPass [720000%]; ElecEngU [11%] | 105.6h |  | 7,200 | 7,200 |  | Percent Complete | BU | EQU | 1.2.3.12.22 | 1.2.3.12.22.5 |  |
| 364 | 1.2.3.12.23 | BU Technician Support |  | 12mo | 2004-06-01 A | 2005-05-18 | 339SS+11d | 14% | 10.32mo | 2004-05-19 | 2005-05-06 | 12mo | 136d |  |  | ElecTechU [4%]; MandSPass [700000%] | 76.8h | 10.75h | 7,000 | 7,000 | 7,000 | Percent Complete | BU | EQU | 1.2.3.12.23 | 1.2.3.12.23 |  |
| 365 | 1.2.3.12.24 | DFEM Project management (E. Hazen) |  | 12mo | 2004-04-12 A | 2005-03-30 |  | 12% | 10.56mo | 2004-04-12 | 2005-03-30 | 12mo | 0d |  | start no earlier than 2004-04-12 | ElecEngU [25%]; MandS | 57.6h | 57.6h | 18,000 | 18,000 | 18,000 | Percent Complete | BU | EQU | 1.2.3.12.24 | 1.2.3.12.24 |  |
| 366 | 1.2.3.13 | **DSAT - DFEM/DFEA Standalone Tester** |  | 110d | 2004-04-09 A | 2004-09-14 |  | 94% | 6.47d | 2004-04-09 | 2004-09-09 | 107d | 302d |  |  |  | 168h | 168h | 19,700 | 19,700 | 19,700 |  |  |  |  |  |  |
| 367 | 1.2.3.13.1 | Specifications + Schematic |  | 4.2w | 2004-04-09 A | 2004-05-07 A |  | 100% |  | 2004-04-09 | 2004-04-29 | 3w |  |  | start no earlier than 2004-04-09 | ElecEngU; InKind [540000%] | 168h | 168h | 5,400 | 5,400 | 5,400 | Percent Complete | BU | INK-MRI2 |  |  |  |
| 368 | 1.2.3.13.2 | Layout |  | 4.6w | 2004-05-10 A | 2004-06-10 A | 367 | 100% |  | 2004-05-05 | 2004-05-25 | 3w |  |  |  | InKind [540000%] |  |  | 5,400 | 5,400 | 5,400 | Percent Complete | BU | INK-MRI2 |  |  |  |
| 369 | 1.2.3.13.3 | PCB Fabrication |  | 2.2w | 2004-06-16 A | 2004-06-30 A | 368FS+3d | 100% |  | 2004-06-01 | 2004-06-21 | 3w |  |  |  | InKind [200000%] |  |  | 2,000 | 2,000 | 2,000 | Percent Complete | BU | INK-MRI2 |  |  |  |
| 370 | 1.2.3.13.4 | Order Parts |  | 6.2w | 2004-05-17 A | 2004-06-29 A | 368SS+1w | 100% |  | 2004-05-12 | 2004-05-25 | 2w |  |  |  | InKind [50000%] |  |  | 500 | 500 | 500 | Percent Complete | BU | INK-MRI2 |  |  |  |
| 371 | 1.2.3.13.5 | PCB Assembly |  | 2w | 2004-06-30 A | 2004-07-14 A | 369FS+3d | 100% |  | 2004-06-25 | 2004-07-09 | 2w |  |  |  | InKind [100000%] |  |  | 1,000 | 1,000 | 1,000 | Percent Complete | BU | INK-MRI2 |  |  |  |
| 372 | 1.2.3.13.6 | Commissioning |  | 2mo | 2004-07-20 A | 2004-09-14 | 371FS+3d | 80% | 0.4mo | 2004-07-15 | 2004-09-09 | 2mo | 302d |  |  | InKind [540000%] |  |  | 5,400 | 5,400 | 5,400 | Percent Complete | BU | INK-MRI2 |  |  |  |
| 373 | 1.2.9 | L1 Trigger Upgrade Production and Testing Complete | milestone | 0w | 2005-08-02 | 2005-08-02 | 260, 189, 133, 336 |  |  | 2006-04-10 | 2006-04-10 | 0w | 84d |  |  |  |  |  |  |  |  |  |  |  |  |  |  |
| 374 | 1.2.4 | **Level 2 Beta Processor** |  | 323d | 2003-12-01 A | 2005-03-24 |  | 45% | 177.79d | 2004-08-09 | 2006-01-05 | 346d | 175d |  |  |  | 6614.8h | 1858.8h | 93,416.34 | 93,416.34 | 32,733.06 |  |  |  |  |  |  |
| 375 | 1.2.4.1 | **Finalize Targets For Run2b Beta Upgrades** |  | 222d | 2003-12-01 A | 2004-10-20 |  | 31% | 153.69d | 2004-08-09 | 2005-07-05 | 224d | 276d |  |  |  | 4640h | 880h |  |  |  |  |  |  |  |  |  |
| 376 | 1.2.4.1.1 | **UVA Tasks** |  | 207d | 2003-12-01 A | 2004-09-29 |  | 48% | 107.64d | 2004-08-09 | 2005-07-05 | 224d | 216d |  |  |  | 800h | 240h |  |  |  |  | UVA |  |  |  |  |
| 377 | 1.2.4.1.1.1 | Assess Performance of Run2a Betas |  | 8w | 2003-12-01 A | 2004-02-04 A |  | 100% |  | 2004-08-09 | 2004-10-12 | 9.2w |  |  | start no earlier than 2003-12-01 | PhysicistU [25%] | 80h | 80h |  |  |  | Percent Complete | UVA | INK-OTHER |  |  |  |
| 378 | 1.2.4.1.1.2 | Develop & Simulate New Run2b Algortihms |  | 16w | 2004-06-01 A | 2004-09-22 |  | 25% | 12w | 2004-10-13 | 2005-06-24 | 34.4w | 216d | 0d | start no earlier than 2004-06-01 | PhysicistU | 640h | 160h |  |  |  | Percent Complete | UVA | INK-OTHER |  |  |  |
| 379 | 1.2.4.1.1.3 | Production readiness review |  | 1w | 2004-09-23 | 2004-09-29 | 378 |  |  | 2005-06-27 | 2005-07-05 | 1.2w | 216d | 41d |  | PhysicistU [200%] | 80h |  |  |  |  | Percent Complete | UVA | INK-OTHER |  |  |  |
| 380 | 1.2.4.1.2 | **University-Other Tasks** |  | 222d | 2003-12-01 A | 2004-10-20 |  | 33% | 148d | 2004-08-09 | 2005-06-24 | 218d | 276d |  |  |  | 3200h | 640h |  |  |  |  |  |  |  |  |  |
| 381 | 1.2.4.1.2.1 | Assess Performance of Run2a Betas |  | 8w | 2003-12-01 A | 2004-02-04 A | 377SS | 100% |  | 2004-08-09 | 2004-10-12 | 9.2w |  |  |  | PhysicistU [200%] | 640h | 640h |  |  |  | Percent Complete |  | INK-OTHER |  |  |  |
| 382 | 1.2.4.1.2.2 | Develop & Simulate New Run2b Algortihms |  | 16w | 2004-06-29 | 2004-10-20 | 378SS+4w |  |  | 2004-10-13 | 2005-06-24 | 34.4w | 276d |  |  | PhysicistU [400%] | 2560h |  |  |  |  | Percent Complete |  | INK-OTHER |  |  | CC |

Notes:
- 359: M&S Labor BOE / Expect 20 days to setup the final test stand with the backplane and crate controllers from FNAL / Thus for 20 days, at the rate of 45$/hr, The total labor charge is 72,00$.
- 360: M&S Labor BOE / Expect 10 days for integration testing of the DFEC (from FNAL) and DFEM at BU. / For 10 days, at the rate of 45$/hr, The total labor charge is 3,600$.
- 361: M&S Labor BOE / Expect 10 days for integration testing of the DB and MB / For 10 days, at the rate of 45$/hr, The total labor charge is 3,600$.
- 362: WBS Definition- / Integrate DFEM / M&S BOE- / Labor charges based on the BU EDF rate of $45/hr . / Labor BOE- / Integration and tests of the DB+MB firmware.
- 364: M&S Labor BOE / Technical support for getting quotes, order parts, ships parts and information to vendors, / check with vendor on the status of the DFEA/DFEM project. For all prototype phases (II and III), / as well as th eproduction phase, we expect the technical support to spend 20 days on the project. / At the rate of $45/hr, we assign a total service charge of 7,000$.
- 365: M&S Labor BOE / Consultation and management of the DFEA and DFEM project provided by Eric Hazen at the BU EDF. / The rate is $45/hr. We anticipate Eric Hazen to spend 25% of his time in the next calendar year. / Thus for 50 working days at a cost of 45$/hr, we assign a total service charge of 18,000$.
- 367: The specs will be developed by S. WU and E. Hazen from Boston Unversity EDF / Labor BOE- / Run2a STC card layout experience. / M&S BOE- / Labor charges based on the BU EDF rate of $45/hr
- 368: M&S BOE-- / External vendor does the layout. based on similar work on Mulan experiment.
- 369: PCB fabrication for 2 test boards / Labor BOE- / M&S BOE- / Vendor quote April 2004
- 370: parts for the tester / Labor BOE- / M&S BOE- / based on the prototype tester experience
- 371: Assembly of tester / Labor BOE- / M&S BOE- / vendor quote April 2004
- 372: Labor BOE-- / test of the DSAt boards will be done at BU by Eric Hazen. Labor rate based on BU EDF charges of $45/hr.
- 373: WBS Definition- / milestone: All Level 1 trigger upgrade systems produced and tested.
- 374: WBS Definition- / This summary element includes the procurement of additional single-board computers (Level 2 Beta processors), associated hardware, and firmware support.
- 375: WBS Definition- / Find appropriate upgrade processor boards for L2Beta system and determine any necessary changes to the system to function wiht the new boards. This includes a study of software and firmware implications and also any hardware incompatibilities that may have to be addressed. The hardware issues would be limited to hard disk connections that differ between manufacturers.
- 377: WBS Definition- / Evauate performance of L2Beta processors in Run2a. Determine areas of greatest need for increased processing power. / Labor BOE- / Compile data on overall performance of L2Betas in Run2a. Rejection factors vs. Luminosity, efficiencies measured from data, etc. Estimate impact of Run2b luminosity and hardware upgrades on this performance. / M&S BOE-/ n/a
- 378: WBS Definition- / Develop Run2b algorithms for the Beta processors. / Labor BOE- / With trigger simulations of upgraded L1 systems and L2STT, develop trigger algorithms necessary deliver necessary rejection at L2 for Run2b. Measure algorithm timing in simulator to determing CPU requirements for each L2 subsystem. / M&S BOE-/ n/a
- 379: WBS Definition- / All components needed to test the prototype Beta are acquired and working.
- 381: WBS Definition- / Evauate performance of L2Beta processors in Run2a. Determine areas of greatest need for increased processing power. / Labor BOE- / Compile data on overall performance of L2Betas in Run2a. Rejection factors vs. Luminosity, efficiencies measured from data, etc. Estimate impact of Run2b luminosity and hardware upgrades on this performance. / M&S BOE- / n/a
- 382: WBS Definition- / Develop Run2b algorithms for the Beta processors. / Labor BOE- / With trigger simulations of upgraded L1 systems and L2STT, develop trigger algorithms necessary deliver necessary rejection at L2 for Run2b. Measure algorithm timing in simulator to determing CPU requirements for each L2 subsystem. / M&S BOE-/ n/a

| ID | WBS | Task | Type | Duration | Start | Finish | Predecessors | Complete | Remaining | Baseline start | Baseline finish | Baseline duration | Total slack | Free slack | Constraint | Resources | Work | Actual work | Cost | Baseline cost | Actual cost | Text26 | Text27 | Text28 | Text29 | Text30 |
| --- | --- | --- | --- | --- | --- | --- | --- | --- | --- | --- | --- | --- | --- | --- | --- | --- | --- | --- | --- | --- | --- | --- | --- | --- | --- | --- |
| 383 | 1.2.4.1.3 | **Orsay Tasks** |  | 80d | 2004-06-29 | 2004-10-20 |  |  |  | 2004-10-13 | 2005-06-24 | 172d | 276d |  |  |  | 640h |  |  |  |  |  |  |  |  |  |
| 384 | 1.2.4.1.3.1 | Develop & Simulate New Run2b Algortihms |  | 16w | 2004-06-29 | 2004-10-20 | 378SS+4w |  |  | 2004-10-13 | 2005-06-24 | 34.4w | 276d |  |  | PhysicistU | 640h |  |  |  |  | Percent Complete | ORS | INK-FOREIGN |  |  |
| 385 | 1.2.4.2 | **Develop Prototype** |  | 130d | 2004-03-18 A | 2004-09-20 |  | 73% | 35.75d | 2004-11-22 | 2005-05-16 | 116d | 298d |  |  |  | 1134.8h | 858.8h | 32,733.06 | 32,733.06 | 32,733.06 |  |  |  |  |  |
| 386 | 1.2.4.2.1 | **UVA Tasks** |  | 130d | 2004-03-18 A | 2004-09-20 |  | 77% | 30.18d | 2004-11-22 | 2005-01-04 | 23d | 298d |  |  |  | 560h | 430h |  |  |  |  |  |  |  |  |
| 387 | 1.2.4.2.1.1 | Survey processor market, chose candidate SBCs |  | 4w | 2004-03-18 A | 2004-04-14 A |  | 100% |  | 2004-11-22 | 2005-01-04 | 4.6w |  |  | start no earlier than 2004-03-18 | PhysicistU [25%] | 40h | 40h |  |  |  | Percent Complete | UVA | INK-OTHER |  |  |
| 388 | 1.2.4.2.1.2 | Evaluate software impact of new SBCs |  | 26w | 2004-03-18 A | 2004-09-20 | 387SS | 75% | 6.5w | 2004-11-22 | 2005-01-04 | 4.6w | 298d |  |  | PhysicistU [25%] | 260h | 195h |  |  |  | Percent Complete | UVA | INK-OTHER |  |  |
| 389 | 1.2.4.2.1.3 | Evaluate firmware impact of new SBCs (function) |  | 26w | 2004-03-18 A | 2004-09-20 | 387SS | 75% | 6.5w | 2004-11-22 | 2005-01-04 | 4.6w | 298d |  |  | PhysicistU [25%] | 260h | 195h |  |  |  | Percent Complete | UVA | INK-OTHER |  |  |
| 390 | 1.2.4.2.2 | Acquire 2 new processor SBCs for evaluation |  | 16w | 2004-04-15 A | 2004-08-06 | 387 | 50% | 8w | 2005-01-05 | 2005-04-12 | 13.8w | 328d |  |  | PhysicistU [5%]; MandS [816000%] | 32h | 16h | 8,160 | 8,160 | 8,160 | Percent Complete | UVA | EQU | 1.2.4.2.2 | 1.2.4.2.2 |
| 391 | 1.2.4.2.3 | **Orsay Tasks** |  | 130d | 2004-03-18 A | 2004-09-20 |  | 77% | 30.18d | 2004-11-22 | 2005-05-16 | 116d | 298d |  |  |  | 542.8h | 412.8h | 24,573.06 | 24,573.06 | 24,573.06 |  | ORS |  |  |  |
| 392 | 1.2.4.2.3.1 | Evaluate firmware impact of new SBCs (coding) |  | 26w | 2004-03-18 A | 2004-09-20 | 387SS | 75% | 6.5w | 2004-11-22 | 2005-01-04 | 4.6w | 298d |  |  | ElecEngU [50%]; InKind [824720%] | 520h | 390h | 8,247.2 | 8,247.2 | 8,247.2 | Percent Complete | ORS | INK-FOREIGN |  |  |
| 393 | 1.2.4.2.3.2 | Design disk adapter |  | 1w | 2004-04-15 A | 2004-04-21 A | 392SS+4w | 100% |  | 2005-01-05 | 2005-02-07 | 4.6w |  |  |  | ElecEngU [25%]; InKind [412360%] | 10h | 10h | 4,123.6 | 4,123.6 | 4,123.6 | Percent Complete | ORS | INK-FOREIGN |  |  |
| 394 | 1.2.4.2.3.3 | Specify/Acquire adapter components |  | 1d | 2004-04-22 A | 2004-04-22 A | 393 | 100% |  | 2005-02-08 | 2005-03-10 | 4.6w |  |  |  | ElecEngU [5%]; InKind [102472%] | 0.4h | 0.4h | 1,024.72 | 1,024.72 | 1,024.72 | Percent Complete | ORS | INK-FOREIGN |  |  |
| 395 | 1.2.4.2.3.4 | Layout adapter, generate artwork, etc |  | 1d | 2004-04-23 A | 2004-04-23 A | 394 | 100% |  | 2005-03-11 | 2005-03-28 | 2.4w |  |  |  | ElecEngU; InKind [824720%] | 8h | 8h | 8,247.2 | 8,247.2 | 8,247.2 | Percent Complete | ORS | INK-FOREIGN |  |  |
| 396 | 1.2.4.2.3.5 | Find manufacturer for disk adapters |  | 1d | 2004-04-26 A | 2004-04-26 A | 395 | 100% |  | 2005-03-29 | 2005-04-13 | 2.4w |  |  |  | ElecEngU [25%]; InKind [206180%] | 2h | 2h | 2,061.8 | 2,061.8 | 2,061.8 | Percent Complete | ORS | INK-FOREIGN |  |  |
| 397 | 1.2.4.2.3.6 | Produce prototype adapters |  | 1d | 2004-04-27 A | 2004-04-27 A | 396 | 100% |  | 2005-04-14 | 2005-05-06 | 3.4w |  |  |  | ElecEngU [5%]; InKind [86854%] | 0.4h | 0.4h | 868.54 | 868.54 | 868.54 | Percent Complete | ORS | INK-FOREIGN |  |  |
| 398 | 1.2.4.2.3.7 | Test prototype adapters |  | 1d | 2004-04-28 A | 2004-04-28 A | 397 | 100% |  | 2005-05-09 | 2005-05-16 | 1.2w |  |  |  | PhysicistU [25%] | 2h | 2h |  |  |  | Percent Complete | ORS | INK-FOREIGN |  |  |
| 399 | 1.2.4.2.4 | Level 2 Beta Trigger Prototype Preparation Complete | milestone | 0w | 2004-04-28 A | 2004-04-28 A | 398 | 100% |  | 2005-05-16 | 2005-05-16 | 0w |  |  |  |  |  |  |  |  |  |  |  |  |  |  |
| 400 | 1.2.4.3 | **Test Prototype** |  | 148d | 2004-04-29 A | 2004-11-29 |  | 23% | 114.36d | 2005-05-17 | 2005-08-23 | 69d | 250d |  |  |  | 760h | 120h | 19,793.28 | 19,793.28 |  |  |  |  |  |  |
| 401 | 1.2.4.3.1 | **UVA Tasks** |  | 148d | 2004-04-29 A | 2004-11-29 |  | 28% | 106.89d | 2005-05-17 | 2005-08-23 | 69d | 250d |  |  |  | 568h | 120h |  |  |  |  | UVA |  |  |  |
| 402 | 1.2.4.3.1.1 | Verify software compatibiity / hardware interface patches |  | 20w | 2004-04-29 A | 2004-09-20 | 399 | 50% | 10w | 2005-05-17 | 2005-07-21 | 9.2w | 298d | 68d |  | PhysicistU [30%] | 240h | 120h |  |  |  | Percent Complete | UVA | INK-OTHER |  |  |
| 403 | 1.2.4.3.1.2 | Verify processor operability in Beta motherboards |  | 12w | 2004-08-05 | 2004-10-28 | 402SS, 406SS |  |  | 2005-05-17 | 2005-07-21 | 9.2w | 175d | 0d |  | PhysicistU [60%] | 288h |  |  |  |  | Percent Complete | UVA | INK-OTHER |  |  |
| 404 | 1.2.4.3.1.3 | Shadow mode studies |  | 4w | 2004-10-29 | 2004-11-29 | 403 |  |  | 2005-07-22 | 2005-08-23 | 4.6w | 175d | 0d |  | PhysicistU [25%] | 40h |  |  |  |  | Percent Complete | UVA | INK-OTHER |  |  |
| 405 | 1.2.4.3.2 | **Orsay Tasks** |  | 40d | 2004-08-05 | 2004-09-30 |  |  |  | 2005-05-17 | 2005-07-21 | 46d | 175d |  |  |  | 192h |  | 19,793.28 | 19,793.28 |  |  |  |  |  |  |
| 406 | 1.2.4.3.2.1 | Firmware support and tuning |  | 8w | 2004-08-05 | 2004-09-30 | 399FS+9w |  |  | 2005-05-17 | 2005-07-21 | 9.2w | 175d | 0d | start no earlier than 2004-08-05 | ElecEngU [60%]; InKind | 192h |  | 19,793.28 | 19,793.28 |  | Percent Complete | ORS | INK-FOREIGN |  |  |
| 407 | 1.2.4.3.3 | Level 2 Beta Trigger Prototype Testing Complete | milestone | 0w | 2004-11-29 | 2004-11-29 | 404 |  |  | 2005-08-23 | 2005-08-23 | 0w | 250d |  |  |  |  |  |  |  |  |  |  |  |  |  |

Notes:
- 384: WBS Definition- / Develop Run2b algorithms for the Beta processors. / Labor BOE- / With trigger simulations of upgraded L1 systems and L2STT, develop trigger algorithms necessary deliver necessary rejection at L2 for Run2b. Measure algorithm timing in simulator to determing CPU requirements for each L2 subsystem. / M&S BOE-/ n/a
- 385: WBS Definition- / Find appropriate upgrade processor boards for L2Beta system and determine any necessary changes to the system to function wiht the new boards. This includes a study of software and firmware implications and also any hardware incompatibilities that may have to be addressed. The hardware issues would be limited to hard disk connections that differ between manufacturers.
- 387: WBS Definition- / Start search for upgraded processors. Compare cPCI processors on market for compaitibility and performance in L2Beta motherboards. / Labor BOE- / Experience w/ original Beta processors. Survey cPCI board manufactures, request literature and price quotes, and compare specifications of boards. / M&S BOE- / n/a
- 388: WBS Definition- / Determine if newer boards require changes to existing code. / Labor BOE- / Experience w/ design/development of hardware driver code for Run2a Alpha and Beta processors. / M&S BOE- / n/a
- 389: WBS Definition- / Determine extent of any necessary firmware changes to use new board and/or upgrade system performance. The only changes forseen are limited to interrupt generation firmware. / Labor BOE- / This task is equivalent to a small module included in the Run2a Beta firmware. Most of the technical issues should be uncovered in the market survey. Any proposed changes would then be disscussed with all L2 software experts. / M&S BOE- / Experience w/ original Beta processors. This task is equivalent to a small module included in the Run2a Beta firmware.
- 390: WBS Definition- / Acquire cPCI boards for software/firmware tests of upraded L2Beta system. / Labor BOE- / Experience w/ original Beta processors. Order lead times varied amoung manufacturers from 2-12 weeks. / M&S BOE- / Estimated from vendor quotes (prices range 30% across manufacturers due to differences in both base prices and available configurations). Quotes from Advantec and VMIC are included inthe project documentation.
- 392: WBS Definition- / Determine extent of any necessary firmware changes to use new board and/or upgrade system performance. The only changes forseen are limited to interrupt generation firmware. / Labor BOE- / In the Run2a beta project we typically have had 1 week turnaround on firmware changes involving protocol changes between our 9U board and the SBC. A recent project of similar scale involved changing of ouput buffering in internal FIFOs of our FPGA and completion simulation studies. New interrupt logic would require full simulation in order to check interactions with our internal state machines. Our project allows time for studies of two designs. / M&S BOE- / Experience w/ original Beta processors. This task is equivalent to a small module included in the Run2a Beta firmware.
- 393: WBS Definition- / cPCI manufacturers have no uniform standards for i/o pins, not specified by the cPCI specification. The new SBC choosen for the Betas may require a small passive adapter card to attach to the hard drive. / Labor BOE- / Space and Mechanical constraints must be addressed for the adapter design. Similar issues were addresses in the design of the 9U motherboard for the Run2a Beta project. Contingency estimate based on guidance for tasks w/o existing conceptual design. / M&S BOE- / n/a
- 394: WBS Definition- / Choose and purchase components for disk adapters: hard metric connectors, headers, cables. / Labor BOE- / Labor is limited to placing 1-2 online of telephone orders. / M&S BOE-/ Catalog pricing for connectors, cables. See catalog pricing from Newark in attached documentation for cost of major components. 12 boards + 10% spare parts ~ $200. Contingency based on guidance for quotations.
- 395: WBS Definition- / Generate artwork for the disk adapter. / Labor BOE- / The disk adapter design requires a small (~3inch by 1 inch) pcb w/ a hard metric connector, a 40pin header and 40 traces routed. The board would be passive and include 2 or 4 signal layers. Space and Mechanical constraints must be addressed for the adapter design. The estimate is base on 3 days electrical design and mechanical design. 2 days in house mechanical prototyping. 1 day layout. 1 day finialize artwork and review. (Layout Engineers + EE + Mech. staff may all be involved). Contingency estimate based on guidance for tasks w/o existing conceptual design. / M&S BOE-/ n/a
- 396: WBS Definition- / Find a manufacturer for the disk adapters. / Labor BOE- / Contracting the production of a small 2 to 4 layer PCB from a local manufacturer. 1 day for collecting quotes + 1.5 day for internal paperwork, transmitting artwork, etc. / M&S BOE- / n/a
- 397: WBS Definition- / Produce 2 prototype disk adapters / Labor BOE- / Labor is limited to coordinating manufacture w/ PCB company. Checking on production status, visual inspection of boards. / M&S BOE- / Based of Quotes from online survey (Included in attached documentation for PCB Express); 2 boards less than 9 square inches = $250
- 398: WBS Definition- / Test prototype disk adapters. / Labor BOE- / Based on experience with Run2a Beta boards. Plug it in and see if it works! If not check connections (again), repair and repeat. / M&S BOE- / n/a
- 399: WBS Definition- / milestone: All components needed to test the prototype Beta are acquired and working.
- 400: WBS Definition- / Verify operation of cPCI boards with L2Beta 9U motherboards.
- 402: WBS Definition- / Verify software and mother card functions w/ new SBC. / Labor BOE- / Experience w/ original Beta processors - make any necessary chnages to compile code on new boards or to access new registers. / M&S BOE- / n/a
- 403: WBS Definition- / Test an assembled card under typical I/O conditions. / Labor BOE- / Estimate from experience with Run2a Betas. / M&S BOE- / n/a
- 404: WBS Definition- / Time reserved for additional prototype studies and algorithm tests in 'shadow' mode while experiment is running.
- 406: WBS Definition- / Develop any necessary (or desired) firmware enhamcements. / Labor BOE- / We allot time for approximately 4 moderate firmware changes with full simulation stuties. (1 week each, same as estimate in 1.2.4.2.4) / M&S BOE- / n/a
- 407: WBS Definition- / milestone: The prototype Beta meets functional i/o requirements.

| ID | WBS | Task | Type | Duration | Start | Finish | Predecessors | Complete | Remaining | Baseline start | Baseline finish | Baseline duration | Total slack | Free slack | Constraint | Resources | Work | Actual work | Cost | Baseline cost | Actual cost | Text26 | Text27 | Text28 | Text29 | Text30 | Text24 | Text23 |
| --- | --- | --- | --- | --- | --- | --- | --- | --- | --- | --- | --- | --- | --- | --- | --- | --- | --- | --- | --- | --- | --- | --- | --- | --- | --- | --- | --- | --- |
| 408 | 1.2.4.4 | **Assemble Production Processors** |  | 95d | 2004-10-29 | 2005-03-24 |  |  |  | 2005-07-22 | 2006-01-05 | 110d | 175d |  |  |  | 80h |  | 40,890 | 40,890 |  |  |  |  |  |  |  |  |
| 409 | 1.2.4.4.1 | Produce Disk Adapters |  | 3w | 2004-10-29 | 2004-11-18 | 403 |  |  | 2005-07-22 | 2005-08-15 | 3.4w | 250d | 0d |  | InKind [105000%]; ElecTechU [10%] | 12h |  | 1,050 | 1,050 |  | Percent Complete | ORS | INK-FOREIGN |  |  |  |  |
| 410 | 1.2.4.4.2 | Finalize Run2b SBC order |  | 2w | 2004-11-30 | 2004-12-13 | 404, 379 |  |  | 2005-08-24 | 2005-09-09 | 2.4w | 175d | 0d |  | PhysicistU [30%] | 24h |  |  |  |  | Percent Complete | UVA | EQU | 1.2.4.4.2 | 1.2.4.4.2 |  |  |
| 411 | 1.2.4.4.3 | Acquire Run2b SBCs |  | 12w | 2004-12-14 | 2005-03-17 | 410 |  |  | 2005-09-12 | 2005-12-19 | 13.8w | 175d | 0d |  | PhysicistU [5%]; MandS | 24h |  | 39,840 | 39,840 |  | Percent Complete | UVA | EQU | 1.2.4.4.3 | 1.2.4.4.3 |  |  |
| 412 | 1.2.4.4.5 | Test production disk adapters |  | 1w | 2004-11-19 | 2004-11-29 | 409 |  |  | 2005-08-16 | 2005-08-23 | 1.2w | 250d | 75d |  | PhysicistU [25%] | 10h |  |  |  |  | Percent Complete | ORS | INK-FOREIGN |  |  |  |  |
| 413 | 1.2.4.4.4 | Test SBCs |  | 1w | 2005-03-18 | 2005-03-24 | 411 |  |  | 2005-12-20 | 2006-01-05 | 1.2w | 175d | 0d |  | PhysicistU [25%] | 10h |  |  |  |  | Percent Complete | UVA | INK-OTHER |  |  |  |  |
| 414 | 1.2.4.4.6 | L2 Beta Trigger Production And Testing Complete | milestone | 0w | 2005-03-24 | 2005-03-24 | 412, 413 |  |  | 2006-01-05 | 2006-01-05 | 0w | 175d | 6d |  |  |  |  |  |  |  |  |  |  |  |  |  |  |
| 415 | 1.2.5 | **Silicon Track Trigger Upgrade** |  | 548d | 2003-01-21 A | 2005-04-01 |  | 40% | 326.4d | 2003-01-21 | 2005-10-17 | 686d | 169d |  |  |  | 4883.19h | 847.99h | 209,760.78 | 235,242.84 | 84,405.78 |  |  |  |  |  |  |  |
| 416 | 1.2.5.1 | Place Parts Orders for L2 Silicon Track Trigger | milestone | 0w | 2003-12-15 A | 2003-12-15 A |  | 100% |  | 2003-04-01 | 2003-04-01 | 0w |  |  | start no earlier than 2003-12-15 |  |  |  |  |  |  |  |  |  |  |  |  |  |
| 417 | 1.2.5.20 | Production Readiness Review |  | 1w | 2004-09-10 | 2004-09-16 |  |  |  | 2005-05-02 | 2005-05-09 | 1.2w | 197d | 0d | start no earlier than 2004-09-10 | ElecEngU [50%]; PhysicistU; PhysicistF [20%]; MandSPass [129200%] | 68h |  | 1,292 | 1,292 |  | Percent Complete | BU | EQU | 1.2.5.20 | 1.2.5.20 |  |  |
| 418 | 1.2.5.2 | Begin L2 Silicon Track Trigger Run IIb PCB Production | milestone | 0w | 2004-09-16 | 2004-09-16 | 417 |  |  | 2005-05-09 | 2005-05-09 | 0w | 210d | 0d | start no earlier than 2004-08-02 |  |  |  |  |  |  |  |  |  |  |  |  |  |
| 419 | 1.2.5.3 | L2 Silicon Track Trigger Run IIb Inputs Finalized | milestone | 0w | 2003-12-15 A | 2003-12-15 A |  | 100% |  | 2003-09-02 | 2003-09-02 | 0w |  |  | start no earlier than 2003-12-15 |  |  |  |  |  |  |  |  |  |  |  |  |  |
| 420 | 1.2.5.4 | **VME Motherboard** |  | 268d | 2003-12-15 A | 2005-01-20 |  | 63% | 99.86d | 2003-09-02 | 2005-09-19 | 616d | 220d |  |  |  | 120h | 24h | 38,871 | 38,871 | 14,071 |  | BU |  |  |  | Trig-082803-11 |  |
| 421 | 1.2.5.4.1 | Place orders |  | 24h | 2003-12-15 A | 2003-12-17 A | 416 | 100% |  | 2003-09-02 | 2003-09-04 | 24h |  |  |  | ElecTechU; MandSPass [48000%] | 24h | 24h | 480 | 480 | 480 | Percent Complete | BU | EQU | 1.2.5.4 | 1.2.5.4.1 | Trig-082803-11 |  |
| 422 | 1.2.5.4.2 | Parts |  | 36w | 2003-12-18 A | 2004-09-09 | 421 | 90% | 3.6w | 2003-09-05 | 2003-10-30 | 8w | 245d | 25d | start no earlier than 2001-11-12 | MandSPass |  |  | 13,591 | 13,591 | 13,591 | Percent Complete | BU | EQU | 1.2.5.4 | 1.2.5.4.2 | Trig-082803-11 | CC |
| 423 | 1.2.5.4.3 | Fabricate PCB |  | 4w | 2004-09-17 | 2004-10-14 | 418 |  |  | 2005-05-10 | 2005-06-10 | 4.6w | 220d | 0d |  | MandSPass [780000%] |  |  | 7,800 | 7,800 |  | Percent Complete | BU | EQU | 1.2.5.4 | 1.2.5.4.3 |  |  |
| 424 | 1.2.5.4.4 | Assemble |  | 4w | 2004-10-15 | 2004-11-11 | 422, 423 |  |  | 2005-06-13 | 2005-07-14 | 4.6w | 220d | 0d |  | MandSPass |  |  | 14,600 | 14,600 |  | Percent Complete | BU | EQU | 1.2.5.4 | 1.2.5.4.4 |  |  |
| 425 | 1.2.5.4.5 | All L2 Silicon Track Trigger Motherboards Delivered | milestone | 0w | 2004-11-11 | 2004-11-11 | 424 |  |  | 2005-07-14 | 2005-07-14 | 0w | 220d | 0d |  |  |  |  |  |  |  |  |  |  |  |  |  |  |
| 426 | 1.2.5.4.6 | Test |  | 8w | 2004-11-12 | 2005-01-20 | 425 |  |  | 2005-07-15 | 2005-09-19 | 9.2w | 220d | 0d |  | ElecEngU [10%]; ElecTechU [20%]; MandSPass [240000%] | 96h |  | 2,400 | 2,400 |  | Percent Complete | BU | EQU | 1.2.5.4 | 1.2.5.4.6 |  |  |
| 427 | 1.2.5.4.8 | L2 Silicon Track Trigger Motherboard Production Complete | milestone | 0w | 2005-01-20 | 2005-01-20 | 426 |  |  | 2005-09-19 | 2005-09-19 | 0w | 220d | 51d |  |  |  |  |  |  |  |  |  |  |  |  |  |  |
| 428 | 1.2.5.5 | **STC Module** |  | 268d | 2003-12-15 A | 2005-01-20 |  | 26% | 198.52d | 2003-09-02 | 2005-09-29 | 624d | 220d |  |  |  | 62.4h | 24h | 22,658 | 22,658 | 16,266 |  | BU |  |  |  | Trig-082803-11 |  |
| 429 | 1.2.5.5.1 | Place orders |  | 0.6w | 2003-12-15 A | 2003-12-17 A | 416 | 100% |  | 2003-09-02 | 2003-09-04 | 0.6w |  |  |  | ElecTechU; MandSPass [48000%] | 24h | 24h | 480 | 480 | 480 | Percent Complete | BU | EQU | 1.2.5.5 | 1.2.5.5.1 | Trig-082803-11 |  |
| 430 | 1.2.5.5.2 | Parts |  | 5w | 2003-12-18 A | 2004-02-02 A | 429 | 100% |  | 2003-09-05 | 2003-10-30 | 8w |  |  | start no earlier than 2001-11-12 | MandSPass |  |  | 15,786 | 15,786 | 15,786 | Percent Complete | BU | EQU | 1.2.5.5 | 1.2.5.5.2 | Trig-082803-11 |  |
| 431 | 1.2.5.5.3 | Fabricate PCB |  | 4w | 2004-09-17 | 2004-10-14 | 418 |  |  | 2005-05-10 | 2005-06-14 | 5w | 220d | 0d |  | MandSPass [418200%] |  |  | 4,182 | 4,182 |  | Percent Complete | BU | EQU | 1.2.5.5 | 1.2.5.5.3 |  |  |
| 432 | 1.2.5.5.4 | Assemble |  | 4w | 2004-10-15 | 2004-11-11 | 430, 431 |  |  | 2005-06-15 | 2005-07-20 | 5w | 220d | 0d |  | MandSPass [109000%] |  |  | 1,090 | 1,090 |  | Percent Complete | BU | EQU | 1.2.5.5 | 1.2.5.5.4 |  |  |
| 433 | 1.2.5.5.5 | All L2 Silicon Track Trigger STCs Delivered | milestone | 0w | 2004-11-11 | 2004-11-11 | 432 |  |  | 2005-07-20 | 2005-07-20 | 0w | 220d | 0d |  |  |  |  |  |  |  |  |  |  |  |  |  |  |
| 434 | 1.2.5.5.6 | Test |  | 8w | 2004-11-12 | 2005-01-20 | 433 |  |  | 2005-07-21 | 2005-09-29 | 10w | 220d | 0d |  | ElecEngU [4%]; ElecTechU [8%]; MandSPass [112000%] | 38.4h |  | 1,120 | 1,120 |  | Percent Complete | BU | EQU | 1.2.5.5 | 1.2.5.5.6 |  |  |
| 435 | 1.2.5.5.8 | L2 Silicon Track Trigger STC Production Complete | milestone | 0w | 2005-01-20 | 2005-01-20 | 434 |  |  | 2005-09-29 | 2005-09-29 | 0w | 220d | 51d |  |  |  |  |  |  |  |  |  |  |  |  |  |  |

Notes:
- 408: WBS Definition- / Assemble Production Processors
- 409: WBS Definition- / Produce anapters for SBC hard drive connectors / Labor BOE- / Technican's time to coordinate production w/ manufacturer / M&S BOE- / Based of Quotes from online survey (Included in attached documentation for PCB Express) 35 boards less than 9 square inches ~ $500 based on 20 board estimate($375) + marginal cost/board of 8.75 for larger production ($375-$250(setup))/20. Extra PCBs over the 12 needed are inexpensive and will cover the contingency of needing to install more fast CPUs.
- 410: WBS Definition- / Finialize order details for cPCI boards for upgrade of system. / M&S BOE- / n/a / Labor BOE- / Experience w/ original Beta processors. Allow 2 weeks to get final quotes, possible quantity discounts, and to generate POs.
- 411: WBS Definition- / Procure full complement of SBC cards. / M&S BOE- / (Prices range 30% across manufacturers.) Based of Quotes from Advantech and VMIC (Included in attached documentation.) / Labor BOE- / Experience w/ original Beta processors. Manufactures lead times vary from 2-12 weeks, depending on stock in hand. / Rick Mitigation- / Cost: / Contingency is included for the purchase of 24 boards instead of 12. The base plan is to upgrade the only the most heavily loaded processors in Run2b. In the event that CPU demands across the system are greater than expected, 24 boards allow for the upgrade of ALL worker nodes in the system. A contingency of 130% is included: 100% for purchase of nodes + 30% for price CPU ranges as noted in the M&S BOE.
- 412: WBS Definition- / Test production disk drive adapters. / Labor BOE- / Cycle through all adapters on test stand to very disk access works. / M&S BOE- / n/a
- 413: WBS Definition- / Test SBC boards, retrun any defective boards for warranty repair/replacement. / Labor BOE- / Experience w/ original Beta processors - plug in all boards at test crate. Return any DOA boards. / M&S BOE- / n/a
- 414: WBS Definition- / milestone: All parts for upgrade Level 2 Betas in hand and working.
- 415: WBS Definition- / This summary element includes upgrades to the Run 2a silicon track trigger to adapt it to the increased number of inputs from the Run 2b silicon detector. It consists of the procurement of additional electronics boards of the Run 2a type. Also included are firmware changes, and additional cabling and connector hardware.
- 416: WBS Definition- / milestone:
- 417: WBS Definition- / Review and sign-off for PCB production.
- 418: WBS Definition- / milestone: beginRun IIb PCB production.
- 419: WBS Definition- / milestone - Format of inputs from upgraded L1CTT and new SMT are fixed.
- 420: WBS Definition- / Common 9Ux400 mm VME motherboard for all STT modules. Design is the same as for Run 2a. 20 boards needed.
- 421: WBS Definition- / Get quotes, place orders, ship parts, etc. / M&S Labor BoE- / 24 hours @ $20/hour for technician based on Run 2a experience for same boards.
- 422: WBS Definition- / Procure parts for motherboards. / M&S BOE- / POs from Run 2a purchase, adjusted for smaller quantities (see mb cost spreadsheet of Run 2a purchases.)
- 423: WBS Definition / Fabrication of PC boards for motherboards by outside vendor. / M&S BoE / Quote from Cirexx.
- 424: WBS Definition / Assembly of motherboards by outside vendor. / M&S BOE- / e-mail from Whitman: 20 boards @ $700/board + $600 NRE = $14,600
- 425: WBS Definition- / milestone: All 20 motherboards have been received from assembly house.
- 426: WBS Definition- / Test all functions of motherboards in test crate, fix problems as needed. / M&S Labor BOE- / per board for 20 boards: / 1 hour @ $40/h for electrical engineer / 4 hours @ $20/hour for technician / Based on Run 2A experience with same boards.
- 427: WBS Definition- / milestone: All motherboards have been tested for basic functionality and are ready to be installed at Fermilab.
- 428: WBS Definition- / Daughter board that processes raw data from SMT. Design is the same as for Run 2a; 7 boards needed.
- 429: WBS definition- / Get quotes, place orders, ship parts, etc. / M&S Labor BoE- / 24 hours @ $20/hour for technician based on Run 2a experience with same boards.
- 430: WBS Definition- / Procure parts for STCs. / M&S BOE / POs of Run 2a purchases adjusted for smaller quantities (see STC cost spreadsheet from Run 2a purchases) and quote from Insight Electronics for Xilinx FPGAs.
- 431: WBS Definition- / Fabrication of PC boards for STCs by outside vendor. / M&S BOE / Quote from Cirexx.
- 432: WBS Definition- / Assembly of STC boards by outside vendor. / M&S BOE / Quote by EMA for 70 STC + NRE (per board cost doubled to adjust for smaller quantity) / 7 boards * $70/board + $600 NRE = $1090.
- 433: WBS Definition- / milestone: all STCs have been received from assembly house
- 434: WBS Definition- / Test all functions of STCs in test crate, fix problems as needed. / M&S Labor BOE-/ per board for 7 boards: / 2 hours @ $40/h for electrical engineer / 4 hours @ $20/h for technician / based on Run 2a experience with same boards
- 435: WBS Definition- / milestone: All STCs have been tested for functionality and are ready to be installed at Fermilab

| ID | WBS | Task | Type | Duration | Start | Finish | Predecessors | Complete | Remaining | Baseline start | Baseline finish | Baseline duration | Total slack | Free slack | Constraint | Resources | Work | Actual work | Cost | Baseline cost | Actual cost | Text27 | Text26 | Text28 | Text29 | Text30 | Text24 |
| --- | --- | --- | --- | --- | --- | --- | --- | --- | --- | --- | --- | --- | --- | --- | --- | --- | --- | --- | --- | --- | --- | --- | --- | --- | --- | --- | --- |
| 436 | 1.2.5.6 | **VTM** |  | 86.5d | 2003-01-21 A | 2003-05-21 A |  | 100% |  | 2003-01-21 | 2003-11-11 | 208d |  |  |  |  |  |  |  | 25,144.88 |  | FNAL |  |  |  |  |  |
| 437 | 1.2.5.6.1 | Place order |  | 12h | 2003-01-21 A | 2003-01-22 A | 416 | 100% |  | 2003-01-21 | 2003-01-22 | 16h |  |  | start no earlier than 2003-01-21 |  |  |  |  | 624 |  | FNAL | Percent Complete | EQU | 1.2.5.6 | 1.2.5.6.1 |  |
| 438 | 1.2.5.6.2 | Production |  | 4w | 2003-01-22 A | 2003-02-19 A | 437 | 100% |  | 2003-01-23 | 2003-07-18 | 25w |  |  |  |  |  |  |  | 23,510 |  | FNAL | Percent Complete | EQU | 1.2.5.6 | 1.2.5.6.2 |  |
| 439 | 1.2.5.6.3 | Test |  | 13w | 2003-02-19 A | 2003-05-21 A | 438 | 100% |  | 2003-07-21 | 2003-11-11 | 16.2w |  |  |  |  |  |  |  | 1,010.88 |  | FNAL | Percent Complete | EQU | 1.2.5.6 | 1.2.5.6.3 |  |
| 440 | 1.2.5.6.5 | VTM Production Complete for L2 Silicon Track Trigger | milestone | 0w | 2003-05-21 A | 2003-05-21 A | 439 | 100% |  | 2003-11-11 | 2003-11-11 | 0w |  |  |  |  |  |  |  |  |  |  |  |  |  |  |  |
| 441 | 1.2.5.7 | **Link Transmitter Board** |  | 258d | 2003-12-15 A | 2005-01-05 |  | 63% | 95.84d | 2003-09-02 | 2005-08-31 | 604d | 230d |  |  |  | 91.2h | 12h | 10,749 | 10,749 | 6,801 | BU |  |  |  |  | Trig-082803-11 |
| 442 | 1.2.5.7.1 | Place orders |  | 12h | 2003-12-15 A | 2003-12-16 A | 416 | 100% |  | 2003-09-02 | 2003-09-03 | 12h |  |  |  | ElecTechU; MandSPass [24000%] | 12h | 12h | 240 | 240 | 240 | BU | Percent Complete | EQU | 1.2.5.7 | 1.2.5.7.1 | Trig-082803-11 |
| 443 | 1.2.5.7.2 | Parts |  | 32w | 2003-12-16 A | 2004-08-10 | 442 | 90% | 3.2w | 2003-09-03 | 2003-10-29 | 8w | 276.5d | 46.5d | start no earlier than 2001-11-12 | MandSPass [656100%] |  |  | 6,561 | 6,561 | 6,561 | BU | Percent Complete | EQU | 1.2.5.7 | 1.2.5.7.2 | Trig-082803-11 |
| 444 | 1.2.5.7.3 | Fabricate PCB |  | 4w | 2004-09-17 | 2004-10-14 | 418 |  |  | 2005-05-10 | 2005-06-10 | 4.6w | 230d | 0d |  | MandSPass [219000%] |  |  | 2,190 | 2,190 |  | BU | Percent Complete | EQU | 1.2.5.7 | 1.2.5.7.3 |  |
| 445 | 1.2.5.7.4 | Assemble |  | 4w | 2004-10-15 | 2004-11-11 | 443, 444 |  |  | 2005-06-13 | 2005-07-14 | 4.6w | 230d | 0d |  | MandSPass [71800%] |  |  | 718 | 718 |  | BU | Percent Complete | EQU | 1.2.5.7 | 1.2.5.7.4 |  |
| 446 | 1.2.5.7.5 | All L2 Silicon Track Trigger LTBs Delivered | milestone | 0w | 2004-11-11 | 2004-11-11 | 445 |  |  | 2005-07-14 | 2005-07-14 | 0w | 230d | 0d |  |  |  |  |  |  |  |  |  |  |  |  |  |
| 447 | 1.2.5.7.6 | Test |  | 6w | 2004-11-12 | 2005-01-05 | 446 |  |  | 2005-07-15 | 2005-08-31 | 6.8w | 230d | 0d |  | ElecTechU [33%]; MandSPass [104000%] | 79.2h |  | 1,040 | 1,040 |  | BU | Percent Complete | EQU | 1.2.5.7 | 1.2.5.7.6 |  |
| 448 | 1.2.5.7.8 | L2 Silicon Track Trigger LTB Production Complete | milestone | 0w | 2005-01-05 | 2005-01-05 | 447 |  |  | 2005-08-31 | 2005-08-31 | 0w | 230d | 61d |  |  |  |  |  |  |  |  |  |  |  |  |  |
| 449 | 1.2.5.8 | **Link Receiver Board** |  | 263d | 2003-12-15 A | 2005-01-12 |  | 62% | 101.2d | 2003-09-02 | 2005-09-09 | 610d | 225d |  |  |  | 96h | 12h | 13,177 | 13,177 | 9,537 | BU |  |  |  |  | Trig-082803-11 |
| 450 | 1.2.5.8.1 | Place orders |  | 12h | 2003-12-15 A | 2003-12-16 A | 416 | 100% |  | 2003-09-02 | 2003-09-03 | 12h |  |  |  | ElecTechU; MandSPass [24000%] | 12h | 12h | 240 | 240 | 240 | BU | Percent Complete | EQU | 1.2.5.8 | 1.2.5.8.1 | Trig-082803-11 |
| 451 | 1.2.5.8.2 | Parts |  | 32w | 2003-12-16 A | 2004-08-10 | 450 | 90% | 3.2w | 2003-09-03 | 2003-10-29 | 8w | 271.5d | 46.5d | start no earlier than 2001-11-12 | MandSPass [929700%] |  |  | 9,297 | 9,297 | 9,297 | BU | Percent Complete | EQU | 1.2.5.8 | 1.2.5.8.2 | Trig-082803-11 |
| 452 | 1.2.5.8.3 | Fabricate PCB |  | 4w | 2004-09-17 | 2004-10-14 | 418 |  |  | 2005-05-10 | 2005-06-10 | 4.6w | 225d | 0d |  | MandSPass [201000%] |  |  | 2,010 | 2,010 |  | BU | Percent Complete | EQU | 1.2.5.8 | 1.2.5.8.3 |  |
| 453 | 1.2.5.8.4 | Assemble |  | 4w | 2004-10-15 | 2004-11-11 | 451, 452 |  |  | 2005-06-13 | 2005-07-14 | 4.6w | 225d | 0d |  | MandSPass [71000%] |  |  | 710 | 710 |  | BU | Percent Complete | EQU | 1.2.5.8 | 1.2.5.8.4 |  |
| 454 | 1.2.5.8.5 | All L2 Silicon Track Trigger LRBs Delivered | milestone | 0w | 2004-11-11 | 2004-11-11 | 453 |  |  | 2005-07-14 | 2005-07-14 | 0w | 225d | 0d |  |  |  |  |  |  |  |  |  |  |  |  |  |
| 455 | 1.2.5.8.6 | Test |  | 7w | 2004-11-12 | 2005-01-12 | 454 |  |  | 2005-07-15 | 2005-09-09 | 8w | 225d | 0d |  | ElecTechU [30%]; MandSPass [92000%] | 84h |  | 920 | 920 |  | BU | Percent Complete | EQU | 1.2.5.8 | 1.2.5.8.6 |  |
| 456 | 1.2.5.8.8 | L2 Silicon Track Trigger LRB Production Complete | milestone | 0w | 2005-01-12 | 2005-01-12 | 455 |  |  | 2005-09-09 | 2005-09-09 | 0w | 225d | 56d |  |  |  |  |  |  |  |  |  |  |  |  |  |
| 457 | 1.2.5.9 | **BC Module** |  | 103d | 2004-09-17 | 2005-02-22 |  |  |  | 2003-09-02 | 2005-09-19 | 616d | 197d |  |  |  | 107.2h |  | 21,390 | 21,390 |  | CU |  |  |  |  | Trig-082803-11 |
| 458 | 1.2.5.9.1 | Place orders |  | 0.6w | 2004-09-17 | 2004-09-21 | 417 |  |  | 2003-09-02 | 2003-09-04 | 0.6w | 197d | 0d | start no earlier than 2004-01-30 | ElecTechU; MandSPass [48000%] | 24h |  | 480 | 480 |  | CU | Percent Complete | EQU | 1.2.5.9 | 1.2.5.9.1 | Trig-082803-11 |
| 459 | 1.2.5.9.2 | Parts |  | 8w | 2004-09-22 | 2004-11-16 | 458 |  |  | 2003-09-05 | 2003-10-30 | 8w | 197d | 0d | start no earlier than 2001-11-12 | MandSPass |  |  | 13,000 | 13,000 |  | CU | Percent Complete | EQU | 1.2.5.9 | 1.2.5.9.2 | Trig-082803-11 |
| 460 | 1.2.5.9.3 | Fabricate PCB |  | 4w | 2004-09-17 | 2004-10-14 | 418 |  |  | 2005-05-10 | 2005-06-10 | 4.6w | 220d | 23d |  | MandSPass [395000%] |  |  | 3,950 | 3,950 |  | CU | Percent Complete | EQU | 1.2.5.9 | 1.2.5.9.3 |  |
| 461 | 1.2.5.9.4 | Assemble |  | 4w | 2004-11-17 | 2004-12-16 | 459, 460 |  |  | 2005-06-13 | 2005-07-14 | 4.6w | 197d | 0d |  | MandSPass [196000%] |  |  | 1,960 | 1,960 |  | CU | Percent Complete | EQU | 1.2.5.9 | 1.2.5.9.4 |  |
| 462 | 1.2.5.9.5 | All L2 Silicon Track Trigger BCs Delivered | milestone | 0w | 2004-12-16 | 2004-12-16 | 461 |  |  | 2005-07-14 | 2005-07-14 | 0w | 197d | 0d |  |  |  |  |  |  |  |  |  |  |  |  |  |
| 463 | 1.2.5.9.6 | Test |  | 8w | 2004-12-17 | 2005-02-22 | 462 |  |  | 2005-07-15 | 2005-09-19 | 9.2w | 197d | 0d |  | ElecEngU [6%]; ElecTechU [20%]; MandSPass [200000%] | 83.2h |  | 2,000 | 2,000 |  | CU | Percent Complete | EQU | 1.2.5.9 | 1.2.5.9.6 |  |
| 464 | 1.2.5.9.8 | L2 Silicon Track Trigger BC Production Complete | milestone | 0w | 2005-02-22 | 2005-02-22 | 463 |  |  | 2005-09-19 | 2005-09-19 | 0w | 197d | 28d |  |  |  |  |  |  |  |  |  |  |  |  |  |

Notes:
- 436: WBS Definition- / VME Transition module with four Finisar optical receivers and HP g-link serial - parallel converters. Used to receive data from silicon detector front ends. Parts are becoming obsolete - need 6 more boards + 4 spares. / Risk Mitigation: / The VME transition module has four Finisar optical receivers and HP g-link serial-to-parallel converters. Some parts used on this board (among them the Finisar receivers) are about to become obsolete. This board was difficult to design and the redesign required if different parts have to be used could mean significant engineering costs. To minimize this risk we intend to purchase the six boards required for the Run 2B upgrade plus 4 spares as soon as possible.
- 437: WBS Definition- / Get quotes, place order. / Labor BoE- / 12 hours for a Fermilab technician
- 438: WBS Definition- / Procurement of parts, fabrication of PCB and assembly by outside vendor / M&S BOE- / Cost of VTM purchased from Circuit Service for Run 2a STT ($2351/VTM + 50% contingency).
- 439: WBS Definition- / Test VTMs / Labor BoE- / 20 h of Fermilab Electronics Technician
- 440: WBS Definition- / milestone: VTMs tested and ready for installation at D0
- 441: WBS Definition- / PC-MIP board with three serial link transmitters for intermodule data transfer. Design is the same as for Run 2a. We need 52 boards.
- 442: WBS definition- / Get quotes, place orders, ship parts, etc / M&S Labor BoE- / 12 hours @ $20/hour for technician (shared with LRB place order task) based on Run 2a experience with same boards.
- 443: WBS Definition- / Procure parts for LTBs / M&S BOE / POs from Run 2a purchases adjusted for smaller quantities (see LRB/LTB cost spreadsheet from Run 2a purchases)
- 444: WBS Definition- / Fabrication of LTB PC boards by outside vendor / M&S BoE / Quote from Cirexx for 330 boards + NRE (double per board cost to adjust for smaller quantity) / 52 boards * $30 + $180 (NRE) + $450 (NRE) = $2190
- 445: WBS Definition- / Assembly of LTB boards by outside vendor / M&S BOE / Quote from EMA for 330 boards. They will give us the same price for smaller quantity of boards. Amount quoted includes NRE costs. 52 boards * $9 + $250 (NRE) = $718
- 446: WBS Definition- / milestone: All LTBs have been received from the assembly house.
- 447: WBS Definition- / Test all functions of LTBs in test PC, fix problems as needed. / Labor BOE- / 1 hour @ $20/h for technician per board for 52 boards based on Run 2A experience with same boards.
- 448: WBS Definition- / milestone: All LTBs have been tested for basic functionality and are ready to be installed at Fermilab.
- 449: WBS Definition- / PC-MIP board with three serial link receivers for intermodule data transfer. Design is the same as for Run 2a. 46 boards needed.
- 450: WBS definition- / Get quotes, place orders, ship parts, etc / M&S Labor BOE- / 12 hours @ $20/hour for technician (shared effort with LTB place order task) based on Run 2a experience with same boards.
- 451: WBS Definition- / Procure parts for LRBs / M&S BOE / POs from Run 2a purchases adjusted for smaller quantities (see LRB/LTB cost spreadsheet from Run 2a purchases).
- 452: WBS Definition- / Fabrication of LRB PC boards by outside vendor / M&S BoE / Quote from Cirexx for 330 boards + NRE (double per board cost to adjust for quantity) / 46 boards * $30 + $180 (NRE) + $450 (NRE) = $2010
- 453: WBS Definition- / Assembly of LRB boards by outside vendor / M&S BoE / Quote from EMA for 150 boards. They will give us the same price for a smaller quantity of boards. Amount quoted includes NRE costs. 46 boards * $10 + $250 (NRE) = $710
- 454: WBS Definition- / milestone: All LRBs have been received from the assembly house
- 455: WBS Definition- / Test all functions of LRBs in test PC, fix problems as needed / M&S Labor BOE- / 1 hour @ $20/hour for technician per board for 46 boards based on Run2a experience with same boards.
- 456: WBS Definition- / milestone: All LRBs have been tested for basic functionality and are ready to be installed at Fermilab.
- 457: WBS Definition- / Daughter board that buffers data for readout to L3 when an L2 accept is issued. Design is the same as for Run 2a. 20 boards needed.
- 458: WBS definition- / Get quotes, place orders, ship parts, etc / M&S Labor BoE- / 24 hours @ $20/hour for technician based on Run 2a experience with same boards.
- 459: WBS Definition- / Place order for parts. / M&S BOE- / Cost of Run 2a purchases increased by approximately 10% to $650/board for smaller quantities / 20 boards * $650 = $13000
- 460: WBS Definition- / Fabrication of PC boards by outside vendor / M&S BoE- / Cost of Run 2A purchase adjusted for smaller quantity $950 (setup) + 20 boards * $150 = $3950
- 461: WBS Definition- / Assembly of boards by outside vendor / M&S BoE- / Cost of Run 2A purchase adjusted for smaller quantity $800 (setup) + 20 boards * $58 = $1960
- 462: WBS Definition- / milestone: All BCs have been received from the assembly house.
- 463: WBS Definition- / Test all functions of BCs in test crate, fix problems as needed. / M&S Labor BOE- / per board for 20 boards: / 1 hour @ $40/hour for electrical engineer / 3 hours @ $20/hour for technician / based on Run 2a experience with same boards.
- 464: WBS Definition- / milestone: All BCs have been tested for basic functionality and are ready to be installed at Fermilab.

| ID | WBS | Task | Type | Duration | Start | Finish | Predecessors | Complete | Remaining | Baseline start | Baseline finish | Baseline duration | Total slack | Free slack | Constraint | Resources | Work | Actual work | Cost | Baseline cost | Actual cost | Text24 | Text27 | Text26 | Text28 | Text29 | Text30 |
| --- | --- | --- | --- | --- | --- | --- | --- | --- | --- | --- | --- | --- | --- | --- | --- | --- | --- | --- | --- | --- | --- | --- | --- | --- | --- | --- | --- |
| 465 | 1.2.5.10 | **TFC Module** |  | 260d | 2004-01-20 A | 2005-02-03 |  | 25% | 195d | 2003-09-02 | 2005-10-17 | 636d | 210d |  |  |  | 100h |  | 42,397 | 42,397 | 25,997 | Trig-082803-11 | SUNYSB |  |  |  |  |
| 466 | 1.2.5.10.1 | Parts |  | 6w | 2004-01-20 A | 2004-03-01 A | 416 | 100% |  | 2003-09-02 | 2003-10-27 | 8w |  |  | start no earlier than 2004-01-20 | MandS |  |  | 25,997 | 25,997 | 25,997 | Trig-082803-11 | SUNYSB | Percent Complete | EQU | 1.2.5.10 | 1.2.5.10.1 |
| 467 | 1.2.5.10.2 | Fabricate PCB |  | 4w | 2004-09-17 | 2004-10-14 | 418 |  |  | 2005-05-10 | 2005-06-14 | 5w | 210d | 0d |  | MandS [780000%] |  |  | 7,800 | 7,800 |  |  | SUNYSB | Percent Complete | EQU | 1.2.5.10 | 1.2.5.10.2 |
| 468 | 1.2.5.10.3 | Assemble and rework |  | 4w | 2004-10-15 | 2004-11-11 | 466, 467 |  |  | 2005-06-15 | 2005-07-20 | 5w | 210d | 0d |  | MandS [460000%] |  |  | 4,600 | 4,600 |  |  | SUNYSB | Percent Complete | EQU | 1.2.5.10 | 1.2.5.10.3 |
| 469 | 1.2.5.10.4 | All L2 Silicon Track Trigger TFCs Delivered | milestone | 0w | 2004-11-11 | 2004-11-11 | 468 |  |  | 2005-07-20 | 2005-07-20 | 0w | 210d | 0d |  |  |  |  |  |  |  |  |  |  |  |  |  |
| 470 | 1.2.5.10.5 | Test |  | 10w | 2004-11-12 | 2005-02-03 | 469 |  |  | 2005-07-21 | 2005-10-17 | 12.4w | 210d | 0d |  | ElecEngU [25%]; MandS [400000%] | 100h |  | 4,000 | 4,000 |  |  | SUNYSB | Percent Complete | EQU | 1.2.5.10 | 1.2.5.10.5 |
| 471 | 1.2.5.10.7 | L2 Silicon Track Trigger TFC Production Complete | milestone | 0w | 2005-02-03 | 2005-02-03 | 470 |  |  | 2005-10-17 | 2005-10-17 | 0w | 210d | 41d |  |  |  |  |  |  |  |  |  |  |  |  |  |
| 472 | 1.2.5.11 | **Hotlink Repeaters** |  | 301d | 2004-01-20 A | 2005-04-01 |  | 30% | 211d | 2003-11-03 | 2004-08-24 | 200d | 169d |  |  |  | 1454.4h | 720h | 13,100 | 13,100 | 5,000 | Trig-082803-11 | SUNYSB |  |  |  |  |
| 473 | 1.2.5.11.1 | Design & prototyping |  | 36w | 2004-01-20 A | 2004-09-30 | 416 | 50% | 18w | 2003-11-03 | 2004-01-08 | 8w | 169d | 0d | start no earlier than 2004-01-20 | ElecEngU; MandS [500000%] | 1440h | 720h | 5,000 | 5,000 | 5,000 | Trig-082803-11 | SUNYSB | Percent Complete | EQU | 1.2.5.11 | 1.2.5.11.1 |
| 474 | 1.2.5.11.2 | Production |  | 15.2w | 2004-10-01 | 2005-01-28 | 473 |  |  | 2004-01-09 | 2004-04-02 | 12w | 169d | 0d |  | MandS [750000%] |  |  | 7,500 | 7,500 |  | Trig-082803-11 | SUNYSB | Percent Complete | EQU | 1.2.5.11 | 1.2.5.11.2 |
| 475 | 1.2.5.11.3 | Test |  | 9w | 2005-01-31 | 2005-04-01 | 474 |  |  | 2004-04-05 | 2004-08-24 | 20w | 169d | 0d |  | ElecTechU [4%]; MandS [60000%] | 14.4h |  | 600 | 600 |  | Trig-082803-11 | SUNYSB | Percent Complete | EQU | 1.2.5.11 | 1.2.5.11.3 |
| 476 | 1.2.5.11.5 | L2 Silicon Track Trigger Hotlink Repeaters Complete | milestone | 0w | 2005-04-01 | 2005-04-01 | 475 |  |  | 2004-08-24 | 2004-08-24 | 0w | 169d | 0d |  |  |  |  |  |  |  | Trig-082803-11 |  |  |  |  |  |
| 477 | 1.2.5.12 | **LVDS Cables** |  | 30d | 2004-09-01 | 2004-10-13 |  |  |  | 2004-09-01 | 2004-10-20 | 35d | 281d |  |  |  | 8h |  | 993 | 993 |  |  | BU |  |  |  |  |
| 478 | 1.2.5.12.1 | Fabricate |  | 4w | 2004-09-01 | 2004-09-29 | 416 |  |  | 2004-09-01 | 2004-10-04 | 4.6w | 281d | 0d | start no earlier than 2004-09-01 | MandSPass [83300%] |  |  | 833 | 833 |  |  | BU | Percent Complete | EQU | 1.2.5.12 | 1.2.5.12.1 |
| 479 | 1.2.5.12.2 | Test |  | 2w | 2004-09-30 | 2004-10-13 | 478 |  |  | 2004-10-05 | 2004-10-20 | 2.4w | 281d | 0d |  | ElecTechU [10%]; MandSPass [16000%] | 8h |  | 160 | 160 |  |  | BU | Percent Complete | EQU | 1.2.5.12 | 1.2.5.12.2 |
| 480 | 1.2.5.12.4 | L2 Silicon Track Trigger LVDS Cable Production Complete | milestone | 0w | 2004-10-13 | 2004-10-13 | 479 |  |  | 2004-10-20 | 2004-10-20 | 0w | 281d | 112d |  |  |  |  |  |  |  |  |  |  |  |  |  |
| 481 | 1.2.5.13 | **Splitters** |  | 277d | 2003-07-23 A | 2004-08-31 A |  | 100% |  | 2003-07-23 | 2004-01-13 | 115d |  |  |  |  | 23.99h | 23.99h | 4,185.78 | 4,185.78 | 4,185.78 | Trig-082803-11 | FNAL |  |  |  |  |
| 482 | 1.2.5.13.1 | Go out for bids |  | 2w | 2003-07-23 A | 2003-08-05 A | 416 | 100% |  | 2003-07-23 | 2003-08-05 | 2w |  |  |  |  |  |  |  |  |  | Trig-082803-11 | FNAL | Percent Complete | EQU | 1.2.5.13 | 1.2.5.13.1 |
| 483 | 1.2.5.13.2 | Procure |  | 4.8w | 2004-01-20 A | 2004-02-20 A | 482 | 100% |  | 2003-08-06 | 2003-11-26 | 16w |  |  | start no earlier than 2004-01-20 | MandS [325000%] |  |  | 3,250 | 3,250 | 3,250 | Trig-082803-11 | FNAL | Percent Complete | EQU | 1.2.5.13 | 1.2.5.13.2 |
| 484 | 1.2.5.13.3 | Test |  | 5w | 2004-07-28 A | 2004-08-31 A | 483FS+22w | 100% |  | 2003-12-01 | 2004-01-13 | 5w |  |  |  | ElecTechF [12%] | 23.99h | 23.99h | 935.78 | 1,085.5 | 935.78 | Trig-082803-11 | FNAL | Percent Complete | EQU | 1.2.5.13 | 1.2.5.13.3 |
| 485 | 1.2.5.13.5 | L2 Silicon Track Trigger Splitter Procurement Complete | milestone | 0w | 2004-08-31 A | 2004-08-31 A | 484 | 100% |  | 2004-01-13 | 2004-01-13 | 0w |  |  |  |  |  |  |  |  |  | Trig-082803-11 |  |  |  |  |  |
| 486 | 1.2.5.14 | **Fibers** |  | 192d | 2003-07-23 A | 2004-04-30 A |  | 100% |  | 2003-07-23 | 2004-01-06 | 110d |  |  |  |  | 32h | 32h | 2,548 | 2,548 | 2,548 | Trig-082803-11 | FNAL |  |  |  |  |
| 487 | 1.2.5.14.1 | Go out for bids |  | 2w | 2003-07-23 A | 2003-08-05 A | 416 | 100% |  | 2003-07-23 | 2003-08-05 | 2w |  |  |  |  |  |  |  |  |  | Trig-082803-11 | FNAL | Percent Complete | EQU | 1.2.5.14 | 1.2.5.14.1 |
| 488 | 1.2.5.14.2 | Procure |  | 0.8w | 2004-03-30 A | 2004-04-02 A | 487 | 100% |  | 2003-08-06 | 2003-11-26 | 16w |  |  | start no earlier than 2004-03-30 | MandS [130000%] |  |  | 1,300 | 1,300 | 1,300 | Trig-082803-11 | FNAL | Percent Complete | EQU | 1.2.5.14 | 1.2.5.14.2 |
| 489 | 1.2.5.14.3 | Test |  | 4w | 2004-04-05 A | 2004-04-30 A | 488 | 100% |  | 2003-12-01 | 2004-01-06 | 4w |  |  |  | ElecTechF [20%] | 32h | 32h | 1,248 | 1,435.2 | 1,248 | Trig-082803-11 | FNAL | Percent Complete | EQU | 1.2.5.14 | 1.2.5.14.3 |
| 490 | 1.2.5.14.5 | L2 Silicon Track Trigger Fiber Procurement Complete | milestone | 0w | 2004-04-30 A | 2004-04-30 A | 489 | 100% |  | 2004-01-06 | 2004-01-06 | 0w |  |  |  |  |  |  |  |  |  | Trig-082803-11 |  |  |  |  |  |
| 491 | 1.2.5.15 | L2 Silicon Track Trigger Hardware Production Complete | milestone | 0w | 2005-04-01 | 2005-04-01 | 427, 435, 448, 456, 464, 471, 480, 485, 490, 440, 476 |  |  | 2005-10-17 | 2005-10-17 | 0w | 169d | 0d |  |  |  |  |  |  |  |  |  |  |  |  |  |

Notes:
- 465: WBS Definition- / Daughter board that fits a trajectory to hits in SMT and CFT. Design is the same as for Run 2a. 8 boards needed.
- 466: WBS Definition- / Place order for parts / M&S BoE- / See spreadsheet and web quote from Texas Instruments.
- 467: WBS Definition- / Fabrication of PC boards by outside vendor. / M&S BoE- / PCB fabrication per P.O. to Circuit Technology Inc for Run 2A TFC boards; 8 boards * $975 = $7800
- 468: WBS Definition- / Assembly of boards by outside vendor; usually some BGAs require rework because bad solder joints appear during original assembly. / M&S BoE- / Quote from Micro Contract Manufacturing; rework $200/board by BEST; / 8 boards * ($375 (assembly) + $200 (rework)) = $4600
- 469: WBS Definition- / milestone: All TFCs have been received from the assembly house.
- 470: WBS Definition- / Test all functions of boards in test crate, fix problems as needed. / M&S Labor BOE- / 100 hours @ $40/hour for electrical engineer based on experience with same boards in Run 2a.
- 471: WBS Definition- / milestone: All TFCs have been tested for basic functionality and are ready to be installed at Fermilab.
- 472: WBS dictionary - / These boards are rquired to merge the outputs of two TFCs into a single hotlink output. They are boards that fit into the PC-MIP slots of the motherboard. They have a PCI target interface to receive the output of one TFC and a hotlink receiver to receive the output of another TFC, some logic in an Altera FPGA to merge the two streams, and a hotlink transmitter for output of the merged data to L2CTT. This is the only board that has to be designed for the Run 2b STT upgrade.
- 473: WBS Definition - / Develop precise specifications, engineering design and layout of the board; build a prototype and test it. / M&S BoE - / 4 weeks of engineering @ $1000/week + $1000 for prototype supplies
- 474: WBS Definition - / Order parts, produce of PC boards and assemble them. / M&S BoE- / Cost of hotlink transmitter board for Run 2a STT. This board has additional parts (hotlink receiver). The cost was increased by approximate cost of these parts. We need 12 boards + 3 spares @ $500/board.
- 475: WBS dictionary - / Test hotlink repeaters, fix problems as needed. / M&S Labor BoE - / 30 hours @ $20/hour for electronics technician based on experience with similar boards in Run 2a.
- 476: WBS Definition - / milestone: All hotlink repeaters tested and ready to be installed at D0.
- 477: WBS Definition- / Cables for LVDS serial links; need 125.
- 478: WBS Definition- / Fabrication of cables by outside vendor. / M&S BoE- / Quote from Inside Track Cabling, scaled to quantity of 125 - 125 cables * $200/30 = $833
- 479: WBS Definition- / Test cables. / M&S Labor BoE- / 8 h @ $20/hour for Electronics Tech based on tests of similar cables for Run 2a.
- 480: WBS Definition- / milestone: All LVDS cables have been received, tested and are ready to be installed at Fermilab.
- 481: WBS Definition- / Passive optical splitters to create data path into STT. We will need 13 units.
- 482: WBS Definition- / Get quotes for splitters. / Labor BoE- / 8h of Fermilab Electronics Tech
- 483: WBS Definition- / Place order for splitters / M&S BoE- / Quote from Run 2a purchase. We actually paid $250/unit rather than the quoted $280. / 13 units * $250 = $3250.
- 484: WBS Definition- / Test splitters / Labor BOE- / 24 hrs of a Fermilab tech for testing.
- 485: WBS Definition- / milestone: All splitters have been received, tested and are ready to be installed at Fermilab.
- 486: WBS Definition- / Optical fibers from splitters to VRBs and to STT. We will need 52 fibers.
- 487: WBS Definition- / Get quotes for fibers / Labor BoE- / 8h of Fermilab Electronics Tech
- 488: WBS Definition- / Place orders for fibers / M&S BOE- / Quote from Run 2a purchase - 52 fibers * $25 = $1300
- 489: WBS Definition- / Test fibers / Labor BOE- / 32 hrs of a Fermilab Tech
- 490: WBS Definition- / All optical fibers have been received, tested and are ready to be installed at Fermilab.
- 491: WBS Definition- / milestone- All hardware components are ready to be installed.

| ID | WBS | Task | Type | Duration | Start | Finish | Predecessors | Complete | Remaining | Baseline start | Baseline finish | Baseline duration | Total slack | Free slack | Constraint | Resources | Work | Actual work | Cost | Baseline cost | Text26 | Text27 | Text28 | Text29 | Text30 | Text24 |
| --- | --- | --- | --- | --- | --- | --- | --- | --- | --- | --- | --- | --- | --- | --- | --- | --- | --- | --- | --- | --- | --- | --- | --- | --- | --- | --- |
| 492 | 1.2.5.16 | **STC firmware** |  | 120d | 2004-08-16 | 2005-02-14 |  |  |  | 2003-09-02 | 2004-04-12 | 150d | 203d | 34d |  |  | 960h |  | 38,400 | 38,400 |  |  |  |  |  |  |
| 493 | 1.2.5.16.1 | Update STC firmware |  | 24w | 2004-08-16 | 2005-02-14 |  |  |  | 2003-09-02 | 2004-04-12 | 30w | 203d |  | start no earlier than 2004-08-16 | ElecEngU; MandSPass | 960h |  | 38,400 | 38,400 | Percent Complete | BU | EQU | 1.2.5.16.1 | 1.2.5.16.1 |  |
| 494 | 1.2.5.17 | **TFC Code** |  | 120d | 2004-08-02 | 2005-01-31 |  |  |  | 2003-09-02 | 2004-03-25 | 138d | 213d | 44d |  |  | 960h |  |  |  |  |  |  |  |  |  |
| 495 | 1.2.5.17.1 | Change TFC code |  | 24w | 2004-08-02 | 2005-01-31 | 419 |  |  | 2003-09-02 | 2004-03-25 | 27.6w | 213d |  | start no earlier than 2004-08-02 | PhysicistU | 960h |  |  |  | Percent Complete | SUNYSB | INK-OTHER |  |  |  |
| 496 | 1.2.5.18 | **Downloading & Monitoring** |  | 100d | 2004-08-02 | 2004-12-22 |  |  |  | 2003-09-02 | 2004-02-23 | 115d | 233d | 64d |  |  | 800h |  |  |  |  |  |  |  |  |  |
| 497 | 1.2.5.18.1 | Update downloading & monitoring software |  | 20w | 2004-08-02 | 2004-12-22 | 419 |  |  | 2003-09-02 | 2004-02-23 | 23w | 233d |  | start no earlier than 2004-08-02 | PhysicistU | 800h |  |  |  | Percent Complete | FSU | INK-OTHER |  |  |  |
| 498 | 1.2.5.19 | L2 Silicon Track Trigger Production and Testing Complete | milestone | 0w | 2005-04-01 | 2005-04-01 | 491, 492, 494, 496, 518 |  |  | 2005-10-17 | 2005-10-17 | 0w | 169d | 0d |  |  |  |  |  |  |  |  |  |  |  |  |
| 499 | 1.2.8 | L2 Trigger Upgrade Production and Testing Complete | milestone | 0w | 2005-04-01 | 2005-04-01 | 498, 414 |  |  | 2006-01-05 | 2006-01-05 | 0w | 169d |  |  |  |  |  |  |  |  |  |  |  |  |  |
| 500 | 1.2.6 | **Trigger Simulation** |  | 827d | 2001-11-01 A | 2005-03-09 |  | 75% | 209.57d | 2001-11-01 | 2004-05-04 | 619d | 186d |  |  |  | 16896.8h | 12363.4h |  |  |  |  |  |  |  |  |
| 501 | 1.2.6.1 | **L1 Cal Simulation Software** |  | 760d | 2001-11-01 A | 2004-11-22 |  | 78% | 168.93d | 2001-11-01 | 2004-01-05 | 534d | 253d |  |  |  | 3308.8h | 2898.4h |  |  |  |  |  |  |  |  |
| 502 | 1.2.6.1.1 | Develop prototype L1Cal trigger algorithm |  | 58.4w | 2001-11-01 A | 2003-01-13 A |  | 100% |  | 2001-11-01 | 2003-01-30 | 60.8w |  |  | start no earlier than 2001-11-01 | PhysicistU [50%]; StudentU [50%] | 1929.6h | 1929.6h |  |  | Percent Complete | CU | INK-OTHER |  |  |  |
| 503 | 1.2.6.1.2 | Optimize algorithm performance with simulations |  | 90w | 2003-01-14 A | 2004-10-27 | 502 | 65% | 31.5w | 2003-01-31 | 2004-01-05 | 46w | 271d |  | start no earlier than 2003-01-06 | PhysicistU [20%] | 720h | 468h |  |  | Percent Complete |  | INK-OTHER |  |  |  |
| 504 | 1.2.6.1.3 | Integrate algorithm into Dzero Trigger Simulation |  | 49.4w | 2003-02-03 A | 2004-01-30 A | 502 | 100% |  | 2003-02-03 | 2003-12-19 | 45w |  |  | start no earlier than 2003-02-03 | PhysicistU [20%] | 395.2h | 395.2h |  |  | Percent Complete | SAC | INK-FOREIGN |  |  | Trig-082803-12 |
| 505 | 1.2.6.1.4 | Integrate algorithm into Dzero Trigger Simulation |  | 33w | 2004-04-01 A | 2004-11-22 | 504 | 40% | 19.8w | 2004-02-02 | 2004-09-22 | 33w | 253d |  | start no earlier than 2003-02-03 | PhysicistU [20%] | 264h | 105.6h |  |  | Percent Complete | NEU | INK-OTHER |  |  | Trig-082803-12 |
| 506 | 1.2.6.2 | **L1 Cal/Track Match Simulation Software** |  | 530d | 2003-01-22 A | 2005-03-09 |  | 34% | 350d | 2003-01-22 | 2004-05-04 | 322d | 186d |  |  |  | 3728h | 1440h |  |  |  | AZ |  |  |  |  |
| 507 | 1.2.6.2.1 | Develop prototype L1Cal/Track match trigger algorithm |  | 90w | 2003-01-22 A | 2004-11-03 |  | 40% | 54w | 2003-01-22 | 2003-12-16 | 46w | 186d | 0d | start no earlier than 2003-01-22 | PhysicistU [50%]; StudentU [50%] | 3600h | 1440h |  |  | Percent Complete | AZ | INK-OTHER |  |  |  |
| 508 | 1.2.6.2.2 | Optimize algorithm performance with simulations |  | 10w | 2004-11-04 | 2005-01-26 | 507 |  |  | 2003-12-17 | 2004-03-17 | 11.6w | 186d | 0d | start no earlier than 2003-01-06 | PhysicistU [20%] | 80h |  |  |  | Percent Complete | AZ | INK-OTHER |  |  |  |
| 509 | 1.2.6.2.3 | Integrate algorithm into Dzero Trigger Simulation |  | 6w | 2005-01-27 | 2005-03-09 | 508 |  |  | 2004-03-18 | 2004-05-04 | 6.8w | 186d |  |  | PhysicistU [20%] | 48h |  |  |  | Percent Complete | AZ | INK-OTHER |  |  |  |
| 510 | 1.2.6.3 | **L1CTT Simulation** |  | 690d | 2002-02-01 A | 2004-11-03 |  | 87% | 88.17d | 2002-02-01 | 2004-02-18 | 508d | 266d |  |  |  | 9060h | 8025h |  |  |  |  |  |  |  |  |
| 511 | 1.2.6.3.1 | Develop prototype CTT algorithm |  | 48w | 2002-02-01 A | 2003-01-21 A |  | 100% |  | 2002-02-01 | 2003-02-14 | 51.6w |  |  | start no earlier than 2002-02-01 | PhysicistU [50%] | 960h | 960h |  |  | Percent Complete | KU | INK-OTHER |  |  |  |
| 512 | 1.2.6.3.2 | Develop prototype CTT algorithm |  | 48w | 2002-02-01 A | 2003-01-21 A |  | 100% |  | 2002-02-01 | 2003-02-14 | 51.6w |  |  | start no earlier than 2002-02-01 | PhysicistF | 1920h | 1920h |  |  | Percent Complete | FNAL | INK-OTHER |  |  |  |
| 513 | 1.2.6.3.3 | Develop prototype CTT algorithm |  | 48w | 2002-02-01 A | 2003-01-21 A |  | 100% |  | 2002-02-01 | 2003-02-14 | 51.6w |  |  | start no earlier than 2002-02-01 | PhysicistU [50%] | 960h | 960h |  |  | Percent Complete | ND | INK-OTHER |  |  |  |
| 514 | 1.2.6.3.4 | Develop prototype CTT algorithm |  | 48w | 2002-02-01 A | 2003-01-21 A |  | 100% |  | 2002-02-01 | 2003-02-14 | 51.6w |  |  | start no earlier than 2002-02-01 | PhysicistU [50%] | 960h | 960h |  |  | Percent Complete | BRN | INK-OTHER |  |  |  |
| 515 | 1.2.6.3.5 | Develop prototype CTT algorithm |  | 48w | 2002-02-01 A | 2003-01-21 A |  | 100% |  | 2002-02-01 | 2003-02-14 | 51.6w |  |  | start no earlier than 2002-02-01 | PhysicistU [50%] | 960h | 960h |  |  | Percent Complete | MAN | INK-FOREIGN |  |  |  |
| 516 | 1.2.6.3.6 | Optimize algorithm performance with simulations |  | 90w | 2003-01-22 A | 2004-11-03 | 511, 512, 513, 514, 515 | 80% | 18w | 2003-02-17 | 2004-02-18 | 50w | 266d |  |  | PhysicistU [50%] | 1800h | 1440h |  |  | Percent Complete |  | INK-OTHER |  |  |  |
| 517 | 1.2.6.3.7 | Integrate algorithm into Dzero Trigger Simulation |  | 75w | 2003-04-01 A | 2004-09-28 | 511, 512, 513, 514, 515 | 55% | 33.75w | 2003-02-17 | 2003-09-25 | 31.2w | 292d |  | start no earlier than 2003-04-01 | PhysicistU [50%] | 1500h | 825h |  |  | Percent Complete | MAN | INK-FOREIGN |  |  |  |

Notes:
- 492: WBS Definition- / Risk Mitigation: / The scope of this item is not yet that well defined, since the systems that provide inputs to the STT are all being redesigned for the upgrade. The engineering budgeted in this item will also serve as contingency in case any layouts have to be revised to accomodate changes due to obsolete parts. To mitigate this risk, I have assigned 100% contingency for this task.
- 493: WBS Definition- / Rewrite firmware for STC FPGA to accomodate changes in input data. / M&S Labor BOE- / Based on engineering effort to design STC firmware for Run 2a (960 hours @ $40/hour)
- 494: WBS Definition-
- 495: WBS Definition- / Rewrite software that runs in DSPs to do fits to increased number of silicon layers. / Labor BOE- / Based on effort required to design Run 2a TFC code
- 496: WBS Definition-
- 497: WBS Definition- / Update downloading and monitoring software. / Labor BOE- / Based on effort required to design Run 2a downloading & monitoring code.
- 498: WBS Definition- / milestone: STT is installed in MCH2 and all functions have been tested.
- 499: WBS Definition- / milestone: All upgrade Level 2 systems in hand and working
- 500: WBS Definition - / This summary task decribed the simulation tasks that are needed to design and optimize the trigger while it is being developed, and afterwards to provide standard tools for simulating the behavior of the as-built system.
- 501: WBS definition - / This summary task describes the development of simulation tools specifically for the Level 1 Calorimeter trigger.
- 502: WBS Definition- / Use Monte Carlo simulation to design and test algorithms for jet, EM and tau clustering and global summing. Develop performance criteria for these algorithms / Labor BOE- / Estimated from simulation effort expended so far. / Text9: Use Monte Carlo simulation to design and test algoritms for EM clustering, jet clustering, tau clusters, and global summing
- 503: WBS Definition - / Embed the stand-alone trigger simulation used for design studies of the run2b L1 calorimeter trigger into the general purpose DZero trigger simulation package ("trig_sim"). / Labor BOE - / 8 weeks of physicist time.
- 504: WBS Definition-
- 505: WBS Definition-
- 506: WBS definition - / This summary task describes the development of simulation tools specifically for the Level 1 Calorimeter trigger.
- 507: WBS Definition- / Use Monte Carlo simulation to design and test algorithms for jet, EM and tau clustering and global summing. Develop performance criteria for these algorithms / Labor BOE- / Estimated from simulation effort expended so far. / Text9: Use Monte Carlo simulation to design and test algoritms for EM clustering, jet clustering, tau clusters, and global summing
- 508: WBS definition - / Embed the stand-alone trigger simulation used for design studies of the run2b L1 calorimeter trigger into the general purpose DZero trigger simulation package ("trig_sim"). / Labor BOE - / 2 weeks of physicist time
- 509: WBS Definition-
- 510: WBS Definition- / Use Monte Carlo simulations and run 2a data to develop optimal equations for track finding and momentum binning. / Labor BOE- / Based on Run2a L1CTTsimulation experience. Most of the simulations are perfomed by physicists. / Text9: use Monte Carlo simulations and run 2a data to develop optimal equations for track finding and momentum binning
- 511: WBS Definition- / Use Monte Carlo simulations and run 2a data to develop optimal equations for track finding and momentum binning. / Labor BOE- / Based on Run2a L1CTTsimulation experience. Most of the simulations are perfomed by physicists. / Text9: use Monte Carlo simulations and run 2a data to develop optimal equations for track finding and momentum binning
- 512: WBS Definition- / Use Monte Carlo simulations and run 2a data to develop optimal equations for track finding and momentum binning. / Labor BOE- / Based on Run2a L1CTTsimulation experience. Most of the simulations are perfomed by physicists.
- 513: WBS Definition- / Use Monte Carlo simulations and run 2a data to develop optimal equations for track finding and momentum binning. / Labor BOE- / Based on Run2a L1CTTsimulation experience. Most of the simulations are perfomed by physicists.
- 514: WBS Definition- / Use Monte Carlo simulations and run 2a data to develop optimal equations for track finding and momentum binning. / Labor BOE- / Based on Run2a L1CTTsimulation experience. Most of the simulations are perfomed by physicists.
- 515: WBS Definition- / Use Monte Carlo simulations and run 2a data to develop optimal equations for track finding and momentum binning. / Labor BOE- / Based on Run2a L1CTTsimulation experience. Most of the simulations are perfomed by physicists.
- 516: WBS Definition-
- 517: WBS Definition-

| ID | WBS | Task | Duration | Start | Finish | Predecessors | Complete | Remaining | Baseline start | Baseline finish | Baseline duration | Total slack | Free slack | Constraint | Resources | Work | Actual work | Cost | Baseline cost | Actual cost | Text26 | Text27 | Text28 | Text29 | Text30 |
| --- | --- | --- | --- | --- | --- | --- | --- | --- | --- | --- | --- | --- | --- | --- | --- | --- | --- | --- | --- | --- | --- | --- | --- | --- | --- |
| 518 | 1.2.6.4 | **STT Simulator** | 100d | 2003-12-15 | 2004-05-12 |  |  |  | 2003-09-02 | 2004-02-23 | 115d | 388d | 219d |  |  | 800h |  |  |  |  |  |  |  |  |  |
| 519 | 1.2.6.4.1 | Update simulator | 20w | 2003-12-15 | 2004-05-12 | 419 |  |  | 2003-09-02 | 2004-02-23 | 23w | 388d |  |  | PhysicistU | 800h |  |  |  |  | Percent Complete | FSU | INK-OTHER |  |  |
| 520 | 1.2.7 | **Administration** | 520d | 2003-02-03 A | 2005-03-07 |  | 79% | 111d | 2003-02-03 | 2005-06-24 | 598d | 188d |  |  |  | 11648h | 9161.6h | 5,500 | 5,500 | 5,500 |  |  |  | 1.2.7 |  |
| 521 | 1.2.7.1 | Project Management | 104w | 2003-02-03 A | 2005-03-07 |  | 79% | 22.2w | 2003-02-03 | 2005-06-24 | 119.6w | 188d |  | start no earlier than 2003-02-03 | PhysicistU [280%] | 11648h | 9161.6h |  |  |  | Level of Effort | FNAL | EQU | 1.2.7 | 1.2.7.1 |
| 522 | 1.2.7.2 | Travel vendor and collaborator visits | 104w | 2003-02-03 A | 2005-03-07 |  | 79% | 22.2w | 2003-02-03 | 2005-06-24 | 119.6w | 188d |  | start no earlier than 2003-02-03 | MandS [350000%] |  |  | 3,500 | 3,500 | 3,500 | Level of Effort | FNAL | EQU | 1.2.7 | 1.2.7.2 |
| 523 | 1.2.7.3 | Shipping costs | 104w | 2003-02-03 A | 2005-03-07 |  | 79% | 22.2w | 2003-02-03 | 2005-06-24 | 119.6w | 188d |  | start no earlier than 2003-02-03 | MandS [200000%] |  |  | 2,000 | 2,000 | 2,000 | Level of Effort | FNAL | EQU | 1.2.7 | 1.2.7.3 |

Notes:
- 518: WBS definition - / This summary task describes the work needed to modify the run2a STT simulation to work with the run2b silicon detector and run2b STT hardware.
- 519: WBS Definition- / Update simulator to reflect changes in hardware. / Labor BOE- / Done by physicists
- 520: WBS Definition- / The summary task associated with administration of the trigger upgrade project including management, travel, shipping, purchasing support, technical support, and software licenses including both the R&D and project phases. / M&S BOE- / The cost BOEs are listed per item. The contingency is 50% for all project related items and 30% on the R&D phase which is nearing completion. / Labor BOE- / The contingency for all tasks is 50%. Physicist contingency is assigned 50%
- 521: WBS Definition- / The management carried out by the Run2b Trigger L2 and L3 project managers and their helpers. This task accounts for maintenance of the schedule, organizing meetings and reviews, maintaining and distrubuting documentation. / M&S BOE- / no costs associated with this item / Labor BOE- / There are two L2 managers of the trigger project that are physicists that are about half time on this task. There are nine Level 2 managers that spend about 20% of their time on administrative and organizational tasks for their projects. All are univeristy physicists. The error estimate is based on the experience so far in mounting the project.
- 522: WBS Definition- / Collaborator visits are needed to make contact with personnel on the projects, examine facilities and production, discuss technical choices, and meet with adminstrators as necessary. Major production of trigger elements will be carried out in Arizona, Boston, New York, and Saclay. / M&S BOE- / Saclay: one trip for two people to Saclay at $1500 per trip. / Others: four trips to Boston, New York, or Arizona at $500 per trip. / Total: $3500 / Labor BOE- / not applicable
- 523: WBS Definition- / Costs for shipping completed prototype and production boards from collaborating institutions (Arizona, Boston, Columbia, Sacaly) to Fermilab. / M&S BOE-- / Shipping costs for: / approximately 200 electonics cards / TOTAL $2000 / Labor BOE- / Not applicable
